# DIQUES PAQUETE 4 - PARTE BAJA - Rev 3

Schedule from Primavera P6, 2024-06-22 to 2025-10-15, data date 2024-06-22.

## Calendars

- 1 T - L-V: Mon-Sat 08:00-16:00; Sun off. Exceptions (off unless hours are given): 2024-06-29, 2024-07-23, 2024-07-29, 2024-08-06, 2024-08-30, 2024-10-08, 2024-11-01, 2024-12-09, 2024-12-25, 2025-01-01, 2025-04-17 to 2025-04-18, 2025-05-01, 2025-06-07, 2025-07-23, 2025-07-28 to 2025-07-29, 2025-08-06, 2025-08-30, 2025-10-08.

## Resources

| Resource | Group | Unit |
| --- | --- | --- |
| Peon | labor |  |
| Operador equipo Pesado | labor |  |
| Excavadora Cat 336 | equipment |  |
| Tractor D6 | equipment |  |
| Capataz | labor |  |
| Petroleo | material | gln |
| Cost | material |  |
| Tractor D8 | equipment |  |
| Operador equipo Liviano | labor |  |
| Retroexcavadora sobre llantas 94 hp | equipment |  |
| Cisterna 5000 gln | equipment |  |
| Motoniveladora 140K | equipment |  |
| Rodillo liso vibratorio 10 - 12 ton | equipment |  |
| Oficial | labor |  |
| Peon - Vigia | labor |  |
| Volquete 15 m3 | equipment |  |
| Cargador Frontal 966 | equipment |  |
| Chancadora Primaria | equipment |  |
| Chancadora LT200 | equipment |  |
| Zaranda Metso ST 4.8 168 HP | equipment |  |
| CANON POR EXTRACCION CANTERA | material |  |
| Camion grua 20 ton | equipment |  |
| Geotextil no tejido 200gr/m2 | material |  |
| Retroexcavadora sobre llantas 58 hp | equipment |  |
| Roca | material | m3 |
| Volquete 22 m3 | equipment |  |
| Peaje local | material |  |
| Operario | labor |  |
| Rodillo liso vibratorio 0.80 - 1.10 ton | equipment |  |
| Cerco perimétrico de Obra | material |  |
| ALMACEN PROVISIONAL | material |  |
| TALLER MECANICO | material |  |
| CARPA COMEDOR (CAMPO) | material |  |
| CONTENEDOR DE OFICINAS | material |  |
| ADITIVO CONTROLADOR DE POLVO | material |  |
| ARENA GRUESA | material |  |
| Tubería HDPE Corrugado de 600 mm | material |  |
| TUBERIA CORRUGADA HDPE D=1000 mm | material |  |
| TUBERIA CORRUGADA HDPE D=1200 mm | material |  |
| Topografo | labor |  |
| GPS | equipment |  |
| CEMENTO PORTLAND TIPO I (42.5 kg) | material |  |
| YESO BOLSA 20 KG | material |  |
| ESTACAS DE MADERA | material |  |
| PINTURA ESMALTE | material |  |
| MADERA TORNILLO | material |  |
| TUBERIA CORRUGADA HDPE D=630 mm | material |  |
| Carmix 4.0 m3 | equipment |  |
| PIEDRA CHANCADA | material |  |
| PLASTIMENT TM-40 - PLASTIFICANTE | material |  |
| ADITIVO CURADOR DE CONCRETO | material |  |
| ALAMBRE NEGRO #8 | material |  |
| CLAVOS PARA MADERA CON CABEZA DE 3" | material |  |
| LACA DESMOLDEADORA | material |  |
| MADERA TORNILLO INCLUYE CORTE PARA ENCOFRADO | material |  |
| TRIPLAY DE 18 mm FENOLICO P/ENCOFRADO | material |  |
| ALAMBRE NEGRO #16 | material |  |
| ACERO CORRUGADO fy = 4200 kg/cm2 GRADO 60 | material |  |
| Zaranda estatica | equipment |  |
| Tubería HDPE Corrugado de 900 mm | material |  |
| ANCLAJES | material |  |
| Suministro de Compuerta tipo CHARNELA, D=900mm | material |  |
| Suministro de Compuerta tipo CHARNELA, D=1200mm | material |  |
| TECNOPOR DE 1/2"X4X8' | material |  |
| SELLADOR ELASTICO POLIURETANO SIKAFLEX 1A | material |  |
| WATER STOP (anillos de estanqueidad); DN=900mm | material |  |
| WATER STOP (anillos de estanqueidad); DN=1200mm | material |  |
| PINTURA ASFALTICA | material |  |
| IMPRIMANTE ASFALTICO | material |  |
| CLAVOS PARA MADERA CON CABEZA | material |  |
| DESMOLDANTE PARA MADERA | material |  |
| TRIPLAY DE 19 mm PARA ENCOFRADO | material |  |
| DOWELL LISO Ø 3/4", L=500, c/0.50m | material |  |
| MATERIAL DE RESPALDO 1" PARA JUNTAS 20 mm | material |  |
| SELLO ELASTOMETRICO A BASE DE SILICONA | material |  |
| Suministro de Compuerta plana tipo tarjeta 1.00 x 1.00m | material |  |
| REJILLA METALICA 2.20x1.50m | material |  |
| MATERIAL DE RESPALDO 1/2" PARA JUNTAS 10 mm | material |  |

## Schedule

| ID | WBS | Activity | Type | Duration | Start | Finish | Predecessors | Total float | Free float | Resources | RCuad | Duracion | Metrado | Unidad |
| --- | --- | --- | --- | --- | --- | --- | --- | --- | --- | --- | --- | --- | --- | --- |
|  | 1 | **HITOS** |  |  | 2024-06-22 | 2025-10-14 |  |  |  |  |  |  |  |  |
| A1000 |  | Inicio de Obra - Acceso al Sitio | milestone | 0d | 2024-06-22 | 2024-06-22 |  | 0d |  |  | 0 | 0 |  |  |
| A1010 |  | Inicio de Habilitación y Mejoramiento de Accesos | milestone | 0d | 2024-07-12 | 2024-07-12 | A1000 SS+16d | 0d |  |  | 0 | 0 |  |  |
| A1020 |  | Inicio - Mov- Tierras - Diques Paquete 4 - Parte Baja | milestone | 0d | 2024-08-01 | 2024-08-01 | A1010 SS+15d | 0d |  |  | 0 | 0 |  |  |
| A1030 |  | Fin - Mov- Tierras - Diques Paquete 4 - Parte Baja | milestone | 0d | 2025-10-14 | 2025-10-14 | A3830 FF, A5620 FF, A3821 FF, A3770 FF, A3780 FF, A5600 FF | 0d |  |  | 0 | 0 |  |  |
|  | 2 | **OBRAS PROVISIONALES** |  |  | 2024-07-04 | 2025-10-15 |  |  |  |  |  |  |  |  |
| A3740 |  | Movilizacion de Maquinaria Pesada |  | 25d | 2024-07-04 | 2024-08-03 | A1000 SS+9d | 143d | 0d | Cost [200] | 0 | 31 | 1 | glb |
| A3760 |  | Mejoramiento y Habilitacion de Caminos de Acceso |  | 180d | 2024-07-12 | 2025-02-17 | A1010 SS | 81d | 0d | Oficial [276.8 h]; Peon [459.24 h]; Peon - Vigia [27.33 h]; Operador equipo Pesado [1136.96 h]; Operador equipo Liviano [203.88 h]; Cisterna 5000 gln [68.25 h]; Volquete 15 m3 [135.63 h]; Cargador Frontal 966 [57.78 h]; Chancadora LT200 [57.78 h]; Excavadora Cat 336 [246.35 h]; Motoniveladora 140K [138.4 h]; Rodillo liso vibratorio 10 - 12 ton [276.8 h]; Tractor D6 [302.06 h]; Zaranda Metso ST 4.8 168 HP [57.78 h]; Capataz [138.4 h]; Petroleo [7435.21 gln]; CANON POR EXTRACCION CANTERA [3460]; Cost [1440] | 0 | 220 | 8.65 | km |
| A3780 |  | Mantenimiento de Caminos de Acceso |  | 360d | 2024-07-12 | 2025-09-25 | A1010 SS | 15d |  | Oficial [1040 h]; Peon [1040 h]; Operador equipo Pesado [1040 h]; Operador equipo Liviano [2476.19 h]; Cisterna 5000 gln [2476.19 h]; Motoniveladora 140K [520 h]; Rodillo liso vibratorio 10 - 12 ton [520 h]; Capataz [208 h]; Petroleo [13492.8 gln]; ADITIVO CONTROLADOR DE POLVO [39000]; Cost [2880] | 0 | 440 | 13 | mes |
| A3730 |  | Campamento Provisional de Obra |  | 12d | 2024-07-19 | 2024-08-03 | A3740 SS+13d | 143d | 17d | Cost [96]; Operador equipo Liviano [551.72 h]; Cisterna 5000 gln [551.72 h]; Petroleo [32827.6 gln]; Cerco perimétrico de Obra [200]; ALMACEN PROVISIONAL [16]; TALLER MECANICO [16]; CARPA COMEDOR (CAMPO) [16]; CONTENEDOR DE OFICINAS [96] | 0 | 16 | 1 | glb |
| A3770 |  | Limpieza Manual de Material Vegetal y de Residuos |  | 346d | 2024-08-01 | 2025-09-26 | A1020 SS | 14d |  | Oficial [843.84 h]; Peon [1687.68 h]; Operador equipo Pesado [316.44 h]; Excavadora Cat 336 [105.48 h]; Tractor D6 [210.96 h]; Capataz [42.19 h]; Petroleo [2373.29 gln]; Cost [2768] | 0 | 422 | 105479.73 | m2 |
| A3810 |  | Cruce Provisional de Rio - 1 |  | 30d | 2024-08-26 | 2024-09-30 | A2070 SS+20d, A3730 | 126d | 45d | Operario [296.83 h]; Oficial [423.55 h]; Peon [790.72 h]; Peon - Vigia [30.38 h]; Operador equipo Pesado [303.13 h]; Operador equipo Liviano [591.85 h]; Cisterna 5000 gln [49.18 h]; Camion grua 20 ton [19.99 h]; Volquete 22 m3 [273.48 h]; Volquete 15 m3 [49.15 h]; Cargador Frontal 966 [78.15 h]; Chancadora LT200 [2.8 h]; Chancadora Primaria [50.12 h]; Excavadora Cat 336 [108.22 h]; Motoniveladora 140K [3.95 h]; Rodillo liso vibratorio 10 - 12 ton [29.9 h]; Rodillo liso vibratorio 0.80 - 1.10 ton [200.04 h]; Tractor D6 [27.18 h]; Zaranda Metso ST 4.8 168 HP [2.8 h]; Capataz [164.72 h]; Petroleo [3932.94 gln]; ARENA GRUESA [92.4]; TUBERIA CORRUGADA HDPE D=1200 mm [264]; CANON POR EXTRACCION CANTERA [168]; Cost [240] | 0 | 36 | 1 | glb |
| A3790 |  | Tuberia HDPE Corrugada f=600mm, para Caminos de Acceso (o similar) |  | 70d | 2024-11-25 | 2025-02-17 | A3760 FF | 81d | 0d | Operario [34.74 h]; Oficial [56.18 h]; Peon [81.04 h]; Peon - Vigia [0.41 h]; Operador equipo Pesado [20.2 h]; Operador equipo Liviano [21.59 h]; Cisterna 5000 gln [1.23 h]; Camion grua 20 ton [5 h]; Volquete 22 m3 [2.06 h]; Cargador Frontal 966 [1.84 h]; Chancadora Primaria [1.22 h]; Excavadora Cat 336 [17.15 h]; Rodillo liso vibratorio 0.80 - 1.10 ton [13.3 h]; Capataz [23.93 h]; Petroleo [219.38 gln]; ARENA GRUESA [7.92]; Tubería HDPE Corrugado de 600 mm [66]; Cost [560] | 0 | 85 | 60 | m |
| A3800 |  | Tuberia HDPE Corrugada f=1000mm, para Caminos de Acceso (o similar) |  | 70d | 2024-11-25 | 2025-02-17 | A3790 SS | 81d | 0d | Operario [39.1 h]; Oficial [40.7 h]; Peon [158.82 h]; Peon - Vigia [0.64 h]; Operador equipo Pesado [21.5 h]; Operador equipo Liviano [30.05 h]; Cisterna 5000 gln [1.88 h]; Camion grua 20 ton [4.17 h]; Volquete 22 m3 [3.17 h]; Cargador Frontal 966 [2.88 h]; Chancadora Primaria [1.92 h]; Excavadora Cat 336 [16.7 h]; Rodillo liso vibratorio 0.80 - 1.10 ton [20.84 h]; Capataz [13.8 h]; Petroleo [241.62 gln]; ARENA GRUESA [8.8]; TUBERIA CORRUGADA HDPE D=1000 mm [52.5]; Cost [560] | 0 | 85 | 50 | m |
| A3820 |  | Demolicion de Cruce Provisional - 1 |  | 12d | 2025-02-18 | 2025-03-03 | A3810 FS+70d, A3800 | 81d | 57d | Operario [108 h]; Oficial [108 h]; Peon [261 h]; Peon - Vigia [13.05 h]; Operador equipo Pesado [45 h]; Operador equipo Liviano [325.12 h]; Camion grua 20 ton [27 h]; Volquete 15 m3 [298.12 h]; Excavadora Cat 336 [45 h]; Capataz [19.8 h]; Petroleo [1325.25 gln]; Cost [96] | 0 | 14 | 2250 | m3 |
| A3811 |  | Cruce Provisional de Rio - 2 |  | 30d | 2025-05-13 | 2025-06-17 | A3820, A3060 SS+7d | 24d | 0d | Cost [240] | 0 | 36 |  |  |
| A3821 |  | Demolicion de Cruce Provisional - 2 |  | 12d | 2025-09-02 | 2025-09-15 | A3811 FS+60d | 24d |  | Cost [96] |  | 14 |  |  |
| A3750 |  | Desmovilizacion de Maquinaria Pesada |  | 15d | 2025-09-27 | 2025-10-15 | A1030 FF+1d | 0d |  | Cost [120] | 0 | 18 | 1 | glb |
|  | 3 | **TOPOGRAFIA** |  |  | 2024-07-12 | 2025-09-25 |  |  |  |  |  |  |  |  |
| A3830 |  | Trazo y Replanteo Inicial |  | 360d | 2024-07-12 | 2025-09-25 | A1010 SS | 15d |  | Peon [8000 h]; Topografo [8000 h]; GPS [4160 h]; CEMENTO PORTLAND TIPO I (42.5 kg) [5]; YESO BOLSA 20 KG [5]; ESTACAS DE MADERA [300]; PINTURA ESMALTE [10]; Cost [2880] | 0 | 440 |  |  |
|  | 4 | **DIQUES** |  |  | 2024-08-01 | 2025-10-14 |  |  |  |  |  |  |  |  |
| A5610 |  | Inicio - Diques | milestone | 0d | 2024-08-01 | 2024-08-01 | A1020 SS | 0d |  |  | 0 | 0 |  |  |
| A5620 |  | Fin - Diques | milestone | 0d | 2025-10-14 | 2025-10-14 | A5640 FF | 0d |  |  | 0 | 0 |  |  |
|  | 4 | **DIQUES - GRUPO 1** |  |  | 2024-08-01 | 2025-10-14 |  |  |  |  |  |  |  |  |
| A5630 |  | Inicio - Diques - Grupo 1 | milestone | 0d | 2024-08-01 | 2024-08-01 | A5610 SS | 0d |  |  | 0 | 0 |  |  |
| A5640 |  | Fin - Diques - Grupo 1 | milestone | 0d | 2025-10-14 | 2025-10-14 | A1380 FF, A2400 FF, A2690 FF, A3380 FF, A3720 FF | 0d |  |  | 0 | 0 |  |  |

| ID | WBS | Activity | Type | Duration | Start | Finish | Predecessors | Total float | Free float | Resources | RCuad | Duracion | Cuadrilla | Rendimiento | Metrado | Unidad | Turno | DurCal | Dur. Cal. | AGrupo |
| --- | --- | --- | --- | --- | --- | --- | --- | --- | --- | --- | --- | --- | --- | --- | --- | --- | --- | --- | --- | --- |
|  | 1 | **DE-PR-08-I** |  |  | 2024-08-01 | 2024-11-28 |  |  |  |  |  |  |  |  |  |  |  |  |  |  |
| A1370 |  | Inicio - DE-PR-08-I | milestone | 0d | 2024-08-01 | 2024-08-01 | A5630 SS | 5d | 0d |  | 0 | 0 |  |  |  |  |  |  |  |  |
| A1380 |  | Fin - DE-PR-08-I | milestone | 0d | 2024-11-28 | 2024-11-28 | A1090 FF, A1100 FF, A1110 FF, A1130 FF, A1150 FF, A1170 FF, A1230 FF, A1250 FF, A1270 FF, A1290 FF, A1310 FF, A1330 FF, A1350 FF | 5d | 0d |  | 0 | 0 |  |  |  |  |  |  |  |  |
|  | 1 | **EXCAVACIONES** |  |  | 2024-08-01 | 2024-09-28 |  |  |  |  |  |  |  |  |  |  |  |  |  |  |
| A1040 |  | Desbroce |  | 40d | 2024-08-01 | 2024-09-18 | A1370 SS | 5d | 0d | Peon [43.8 h]; Operador equipo Pesado [32.85 h]; Excavadora Cat 336 [10.95 h]; Tractor D6 [21.9 h]; Capataz [0.22 h]; Petroleo [246.38 gln]; Cost [320] | 1 | 49 | 1 | 0.8 | 2.19 | ha | 1 | 2.19 | 2.7375 | Excavacion |
| A1100 |  | Conformacion de Material Excedente en DMO |  | 40d | 2024-08-01 | 2024-09-18 | A1040 SS | 64d | 59d | Peon [52.28 h]; Operador equipo Pesado [57.78 h]; Excavadora Cat 336 [5.5 h]; Tractor D6 [52.28 h]; Capataz [5.5 h]; Petroleo [412.75 gln]; Cost [320] | 1 | 49 | 1 | 1050 | 6879.09 | m3 | 1 | 6879.09 | 6.55151428571429 | Excavacion |
| A1050 |  | Remocion de Dique Existente |  | 46d | 2024-08-03 | 2024-09-27 | A1040 SS+2d | 5d | 0d | Peon [67.2 h]; Operador equipo Pesado [100.8 h]; Excavadora Cat 336 [67.2 h]; Tractor D8 [33.6 h]; Capataz [13.44 h]; Petroleo [890.39 gln]; Cost [368] | 0.5 | 56 | 0.5 | 800 | 6719.93 | m3 | 1 | 13439.86 | 16.799825 | Excavacion |
| A1060 |  | Excavacion de Cimentacion |  | 46d | 2024-08-03 | 2024-09-27 | A1050 SS | 5d | 0d | Peon [600 h]; Operador equipo Pesado [400 h]; Operador equipo Liviano [333.33 h]; Excavadora Cat 336 [266.67 h]; Retroexcavadora sobre llantas 94 hp [333.33 h]; Tractor D8 [133.33 h]; Capataz [60 h]; Petroleo [4359.99 gln]; Cost [368] | 0.5 | 56 | 0.5 | 880 | 33333.22 | m3 | 1 | 66666.44 | 75.7573181818182 | Excavacion |
| A1080 |  | Excavacion de Uña |  | 46d | 2024-08-03 | 2024-09-27 | A1060 SS | 5d | 0d | Peon [174.23 h]; Operador equipo Pesado [174.23 h]; Excavadora Cat 336 [174.23 h]; Capataz [34.85 h]; Petroleo [1968.85 gln]; Cost [368] | 0.5 | 56 | 0.5 | 500 | 10889.68 | m3 | 1 | 21779.36 | 43.55872 | Excavacion |
| A1090 |  | Conformacion de Material Excedente en DME |  | 46d | 2024-08-03 | 2024-09-27 | A1050 SS | 56d | 51d | Peon [326.84 h]; Operador equipo Pesado [361.24 h]; Excavadora Cat 336 [34.4 h]; Tractor D6 [326.84 h]; Capataz [34.4 h]; Petroleo [2580.32 gln]; Cost [368] | 1 | 56 | 1 | 1050 | 43005.26 | m3 | 1 | 43005.26 | 40.9573904761905 | Excavacion |
| A1110 |  | Excavacion Localizada - Sobreexcavacion |  | 46d | 2024-08-03 | 2024-09-27 | A1080 SS | 56d | 51d | Peon [81.34 h]; Operador equipo Pesado [81.34 h]; Excavadora Cat 336 [81.34 h]; Capataz [16.37 h]; Petroleo [691.53 gln]; Cost [368] | 0.5 | 56 | 0.5 | 240 | 2442.7 | m3 | 1 | 4885.4 | 20.3558333333333 | Excavacion |
| A1070 |  | Perfilado y Conformacion de Plataforma de Fundacion |  | 38d | 2024-08-15 | 2024-09-28 | A1060 SS+9d | 35d | 0d | Peon [96.95 h]; Operador equipo Pesado [172.94 h]; Operador equipo Liviano [36.69 h]; Cisterna 5000 gln [36.69 h]; Motoniveladora 140K [86.47 h]; Rodillo liso vibratorio 10 - 12 ton [86.47 h]; Capataz [7.86 h]; Petroleo [744.19 gln]; Cost [304] | 0.3 | 45 | 0.3 | 2400 | 26203.77 | m2 | 1 | 87345.9 | 36.394125 | Excavacion |
|  | 2 | **RELLENOS** |  |  | 2024-08-23 | 2024-11-28 |  |  |  |  |  |  |  |  |  |  |  |  |  |  |
| A1120 |  | Relleno con Material Granular (incluye extraccion de material, zarandeo y combinado) |  | 46d | 2024-08-23 | 2024-10-17 | A1070 SS+7d | 35d | 0d | Oficial [344.31 h]; Peon [1504.85 h]; Peon - Vigia [86.68 h]; Operador equipo Pesado [2287.37 h]; Operador equipo Liviano [936.62 h]; Cisterna 5000 gln [508.04 h]; Volquete 15 m3 [428.58 h]; Cargador Frontal 966 [695.84 h]; Chancadora Primaria [322.64 h]; Excavadora Cat 336 [496 h]; Rodillo liso vibratorio 10 - 12 ton [344.31 h]; Tractor D6 [433.4 h]; Capataz [585.09 h]; Petroleo [18467.5 gln]; Cost [368] | 1 | 56 | 1 | 560 | 24077.6 | m3 | 1 | 24077.6 | 42.9957142857143 | Relleno |
| A1160 |  | Relleno con Material Seleccionado (incluye extraccion de material, zarandeo y combinado) |  | 46d | 2024-08-23 | 2024-10-17 | A1120 SS | 51d | 0d | Oficial [81.34 h]; Peon [167.08 h]; Operador equipo Pesado [244.03 h]; Operador equipo Liviano [17.1 h]; Cisterna 5000 gln [17.1 h]; Excavadora Cat 336 [162.68 h]; Rodillo liso vibratorio 10 - 12 ton [81.34 h]; Capataz [16.37 h]; Petroleo [2487.65 gln]; Cost [368] | 1 | 56 | 1 | 240 | 2442.7 | m3 | 1 | 2442.7 | 10.1779166666667 | Relleno |
| A1150 |  | Perfilado de Talud Dique |  | 46d | 2024-08-29 | 2024-10-23 | A1120 SS+5d | 35d | 30d | Peon [142.46 h]; Operador equipo Pesado [42.49 h]; Excavadora Cat 336 [42.49 h]; Capataz [28.74 h]; Petroleo [361.14 gln]; Cost [368] | 1 | 56 | 1 | 700 | 12496.36 | m2 | 1 | 12496.36 | 17.8519428571429 | Relleno |
| A1170 |  | Grava para Drenaje |  | 28d | 2024-09-02 | 2024-10-03 | A1160 SS+7d | 51d | 46d | Peon [141.71 h]; Peon - Vigia [4.45 h]; Operador equipo Pesado [58.12 h]; Operador equipo Liviano [130.65 h]; Volquete 15 m3 [22.23 h]; Cargador Frontal 966 [24.94 h]; Chancadora Primaria [16.59 h]; Excavadora Cat 336 [16.59 h]; Retroexcavadora sobre llantas 94 hp [108.42 h]; Tractor D6; Capataz [43.69 h]; Petroleo [741.51 gln]; Cost [224] | 1 | 32 | 1 | 80 | 1084.24 | m3 | 1 | 1084.24 | 13.553 | Relleno |
| A1130 |  | Relleno sin Compactar |  | 28d | 2024-10-23 | 2024-11-25 | A1220 FF | 8d | 3d | Oficial [55.78 h]; Peon [55.78 h]; Operador equipo Pesado [55.78 h]; Tractor D6 [55.78 h]; Capataz [11.28 h]; Petroleo [390.45 gln]; Cost [224] | 1 | 34 | 1 | 900 | 6267.19 | m3 | 1 | 6267.19 | 6.96354444444444 | Relleno |
| A1140 |  | Relleno Afirmado |  | 3d | 2024-11-26 | 2024-11-28 | A1220, A4160 | 5d | 0d | Oficial [25.23 h]; Peon [79.36 h]; Peon - Vigia [8.48 h]; Operador equipo Pesado [145.45 h]; Operador equipo Liviano [53.62 h]; Cisterna 5000 gln [11.54 h]; Volquete 15 m3 [42.08 h]; Cargador Frontal 966 [17.87 h]; Chancadora LT200 [17.87 h]; Excavadora Cat 336 [33.5 h]; Motoniveladora 140K [25.23 h]; Rodillo liso vibratorio 10 - 12 ton [25.23 h]; Tractor D6 [7.86 h]; Zaranda Metso ST 4.8 168 HP [17.87 h]; Capataz [30.74 h]; Petroleo [1024.47 gln]; CANON POR EXTRACCION CANTERA [1072.48]; Cost [24] | 1 | 3 | 1 | 324 | 1021.41 | m3 | 1 | 1021.41 | 3.1525 | Relleno |
|  | 3 | **GEOTEXTIL** |  |  | 2024-08-13 | 2024-10-23 |  |  |  |  |  |  |  |  |  |  |  |  |  |  |
| A1180 |  | Instalacion de Geotextil 400gr/m2 |  | 60d | 2024-08-13 | 2024-10-23 | A1080 SS+7d | 5d | 0d | Oficial [733.86 h]; Peon [1099.42 h]; Operador equipo Liviano [90.7 h]; Camion grua 20 ton [90.7 h]; Capataz [74.21 h]; Petroleo [362.81 gln]; Geotextil no tejido 200gr/m2 [31608.3]; Cost [480] | 1 | 72 | 1 | 600 | 27485.48 | m2 | 1 | 27485.48 | 45.8091333333333 | Geotextil |
| A1190 |  | Zanja de Anclaje |  | 30d | 2024-09-18 | 2024-10-23 | A1180 FF | 35d | 0d | Oficial [47.69 h]; Peon [143.41 h]; Operador equipo Pesado [47.69 h]; Operador equipo Liviano [1.34 h]; Cisterna 5000 gln [1.34 h]; Retroexcavadora sobre llantas 58 hp [47.69 h]; Capataz [9.54 h]; Petroleo [169.9 gln]; Cost [240] | 1 | 36 | 1 | 32 | 190.75 | m3 | 1 | 190.75 | 5.9609375 | Geotextil |
|  | 4 | **COLOCACION DE ROCA** |  |  | 2024-08-03 | 2024-11-25 |  |  |  |  |  |  |  |  |  |  |  |  |  |  |
| A1230 |  | Extraccion de Rocas Reutilizables |  | 60d | 2024-08-03 | 2024-10-15 | A1050 SS | 42d | 37d | Peon [421.99 h]; Operador equipo Pesado [421.99 h]; Excavadora Cat 336 [421.99 h]; Capataz [211.18 h]; Petroleo [3587.08 gln]; Cost [480] | 1 | 74 | 1 | 144 | 3751 | m3 | 1 | 3751 | 26.0486111111111 | Roca |
| A1200 |  | Suministro de roca |  | 86d | 2024-08-14 | 2024-11-25 | A1210 SS | 32d | 0d | Cost [688] | 1 | 104 | 1 |  |  | ton | 1 | 0 |  | Roca |
| A1210 |  | Colocacion de Roca en Uña |  | 39d | 2024-08-14 | 2024-09-28 | A1080 SS+7d, A1180 SS+1d | 5d | 0d | Oficial [311.44 h]; Peon [311.44 h]; Operador equipo Pesado [343.02 h]; Excavadora Cat 336 [311.44 h]; Tractor D6 [31.58 h]; Capataz [155.72 h]; Petroleo [2868.34 gln]; Roca [10889.7 m3]; Cost [312] | 1 | 46 | 1 | 280 | 10889.68 | m3 | 1 | 10889.68 | 38.8917142857143 | Roca |
| A1220 |  | Colocacion de Roca en Talud |  | 47d | 2024-09-30 | 2024-11-25 | A1210, A1180 SS | 5d | 0d | Oficial [373.39 h]; Peon [373.39 h]; Operador equipo Pesado [783.49 h]; Excavadora Cat 336 [745.88 h]; Tractor D6 [37.61 h]; Capataz [186.25 h]; Petroleo [6603.72 gln]; Roca [8954.2 m3]; Cost [376] | 1 | 57 | 1 | 192 | 8954.2 | m3 | 1 | 8954.2 | 46.6364583333333 | Roca |

| ID | WBS | Activity | Duration | Start | Finish | Predecessors | Total float | Free float | Resources | Cuadrilla | Metrado | Unidad | Turno | RCuad | DurCal | AGrupo | Duracion |
| --- | --- | --- | --- | --- | --- | --- | --- | --- | --- | --- | --- | --- | --- | --- | --- | --- | --- |
|  | 5 | **TRANSPORTES** |  | 2024-08-01 | 2024-11-28 |  |  |  |  |  |  |  |  |  |  |  |  |
| A1240 |  | Transporte de Material Organico (a DMO) D<=1km | 40d | 2024-08-01 | 2024-09-18 | A1040 SS | 64d | 0d | Peon - Vigia [38.52 h]; Operador equipo Liviano [191.24 h]; Volquete 15 m3 [191.24 h]; Petroleo [535.19 gln]; Cost [320] | 1 | 6879.09 | m3k | 1 | 1 | 6879.09 | Transportes | 49 |
| A1250 |  | Transporte de Material Organico (a DMO) D>1km | 40d | 2024-08-01 | 2024-09-18 | A1240 SS | 64d | 59d | Operador equipo Liviano [1118.7 h]; Volquete 15 m3 [1118.7 h]; Petroleo [3132.36 gln]; Cost [320] | 1 | 101699.91 | m3k | 1 | 1 | 101699.91 | Transportes | 49 |
| A1260 |  | Transporte de Material Excedente D<=1km | 46d | 2024-08-03 | 2024-09-27 | A1050 SS | 56d | 0d | Peon - Vigia [219.33 h]; Operador equipo Liviano [1092.33 h]; Volquete 22 m3 [468.76 h]; Volquete 15 m3 [623.58 h]; Petroleo [3659.75 gln]; Cost [368] | 1 | 43005.26 | m3k | 1 | 1 | 43005.26 | Transportes | 56 |
| A1270 |  | Transporte de Material Excedente D>1km | 46d | 2024-08-03 | 2024-09-27 | A1260 SS | 56d | 51d | Operador equipo Liviano [6411.78 h]; Volquete 22 m3 [2729.77 h]; Volquete 15 m3 [3682.01 h]; Petroleo [21457.2 gln]; Cost [368] | 1 | 634829.43 | m3k | 1 | 1 | 634829.43 | Transportes | 56 |
| A1300 |  | Transporte de Roca D<=1km | 62d | 2024-08-14 | 2024-10-26 | A1200 SS | 32d | 0d | Peon [250.16 h]; Peon - Vigia [120.08 h]; Operador equipo Pesado [250.16 h]; Operador equipo Liviano [600.39 h]; Volquete 22 m3 [600.39 h]; Excavadora Cat 336 [250.16 h]; Petroleo [4506.96 gln]; Peaje local [910.6]; Cost [496] | 1 | 20013.14 | m3k | 1 | 1 | 20013.14 | Transportes | 74 |
| A1310 |  | Transporte de Roca D>1km | 62d | 2024-08-14 | 2024-10-26 | A1300 SS | 32d | 27d | Operador equipo Liviano [3542.35 h]; Volquete 22 m3 [3542.35 h]; Petroleo [14103.2 gln]; Cost [496] | 1 | 331060.87 | m3k | 1 | 1 | 331060.87 | Transportes | 74 |
| A1320 |  | Transporte de Material de Prestamo Cantera de Rio (Cuerpo de Terraplen) D<=1km | 46d | 2024-08-23 | 2024-10-17 | A1120 SS | 40d | 0d | Peon - Vigia [122.61 h]; Operador equipo Liviano [610.12 h]; Volquete 22 m3 [610.12 h]; Petroleo [2501.78 gln]; Cost [368] | 1 | 29192.34 | m3k | 1 | 1 | 29192.34 | Transportes | 56 |
| A1330 |  | Transporte de Material de Prestamo Cantera de Rio (Cuerpo de Terraplen) D>1km | 46d | 2024-08-23 | 2024-10-17 | A1320 SS | 40d | 35d | Operador equipo Liviano [452.2 h]; Volquete 22 m3 [452.2 h]; Petroleo [1852.39 gln]; Cost [368] | 1 | 54482.18 | m3k | 1 | 1 | 54482.18 | Transportes | 56 |
| A1340 |  | Transporte de Material Seleccionado para Zanja D<=1km | 30d | 2024-09-18 | 2024-10-23 | A1190 SS | 35d | 0d | Peon - Vigia [1.07 h]; Operador equipo Liviano [5.3 h]; Volquete 15 m3 [5.3 h]; Petroleo [14.84 gln]; Cost [240] | 1 | 190.75 | m3k | 1 | 1 | 190.75 | Transportes | 36 |
| A1350 |  | Transporte de Material Seleccionado para Zanja D>1km | 30d | 2024-09-18 | 2024-10-23 | A1340 SS | 35d | 30d | Operador equipo Liviano [3.84 h]; Volquete 15 m3 [3.84 h]; Petroleo [10.76 gln]; Cost [240] | 1 | 349.36 | m3k | 1 | 1 | 349.36 | Transportes | 36 |
| A1280 |  | Transporte de Material de Prestamo (Afirmado) D<=1km | 29d | 2024-10-25 | 2024-11-28 | A1140 FF | 5d | 0d | Peon - Vigia [67.92 h]; Operador equipo Liviano [337.98 h]; Volquete 22 m3 [337.98 h]; Petroleo [1385.87 gln]; Cost [232] | 1 | 16171.18 | m3k | 1 | 1 | 16171.18 | Transportes | 35 |
| A1290 |  | Transporte de Material de Prestamo (Afirmado) D>1km | 29d | 2024-10-25 | 2024-11-28 | A1280 SS | 5d | 0d | Operador equipo Liviano [2502.09 h]; Volquete 22 m3 [2502.09 h]; Petroleo [10249.5 gln]; Cost [232] | 1 | 301456.83 | m3k | 1 | 1 | 301456.83 | Transportes | 35 |
|  | 6 | **INTERFERENCIAS** |  | 2024-08-20 | 2024-10-18 |  |  |  |  |  |  |  |  |  |  |  |  |
| A3850 |  | Trazo y replanteo de interferencia | 50d | 2024-08-20 | 2024-10-18 | A1040 SS+15d | 21d | 0d | Peon [70.3 h]; Topografo [35.15 h]; GPS [35.15 h]; Capataz [3.51 h]; MADERA TORNILLO [35.15]; PINTURA ESMALTE [3.51]; Cost [400] |  | 1757.47 | m2 |  | 0 |  | Interferencias | 60 |
| A3860 |  | Desvío provisional con tubería | 50d | 2024-08-20 | 2024-10-18 | A3850 SS | 21d | 0d | Operario [29.36 h]; Oficial [29.36 h]; Peon [187.9 h]; Operador equipo Pesado [11.74 h]; Operador equipo Liviano [7.34 h]; Camion grua 20 ton [7.34 h]; Excavadora Cat 336 [11.74 h]; Capataz [17.03 h]; Petroleo [129.15 gln]; TUBERIA CORRUGADA HDPE D=630 mm [92.48]; Cost [400] |  | 88.08 | m |  | 0 |  | Interferencias | 60 |
| A3870 |  | Desvío provisional en tierras | 50d | 2024-08-20 | 2024-10-18 | A3860 SS | 21d | 0d | Peon [52.65 h]; Operador equipo Pesado [52.65 h]; Excavadora Cat 336 [52.65 h]; Capataz [10.55 h]; Petroleo [447.57 gln]; Cost [400] |  | 395 | m |  | 0 |  | Interferencias | 60 |
| A3880 |  | Limpieza de terreno manual | 50d | 2024-08-20 | 2024-10-18 | A3870 SS | 21d | 0d | Oficial [14.06 h]; Peon [28.12 h]; Operador equipo Pesado [5.27 h]; Excavadora Cat 336 [1.76 h]; Tractor D6 [3.51 h]; Capataz [0.7 h]; Petroleo [39.54 gln]; Cost [400] |  | 1757.47 | m2 |  | 0 |  | Interferencias | 60 |
| A3890 |  | Excavaciones no clasificada para estructuras | 50d | 2024-08-20 | 2024-10-18 | A3880 SS | 21d | 0d | Peon [2.2 h]; Operador equipo Pesado [2.2 h]; Excavadora Cat 336 [2.2 h]; Capataz [0.44 h]; Petroleo [18.69 gln]; Cost [400] |  | 68.71 | m3 |  | 0 |  | Interferencias | 60 |
| A3900 |  | Excavacion no clasificada de zanja | 50d | 2024-08-20 | 2024-10-18 | A3890 SS | 21d | 0d | Peon [63.93 h]; Operador equipo Pesado [63.93 h]; Excavadora Cat 336 [63.93 h]; Capataz [6.39 h]; Petroleo [543.4 gln]; Cost [400] |  | 1278.58 | m3 |  | 0 |  | Interferencias | 60 |
| A3910 |  | Relleno estructural | 50d | 2024-08-20 | 2024-10-18 | A3900 SS | 21d | 0d | Operario [67.64 h]; Oficial [67.64 h]; Peon [162.26 h]; Peon - Vigia [1.94 h]; Operador equipo Pesado [71.95 h]; Operador equipo Liviano [84.02 h]; Cisterna 5000 gln [6.67 h]; Volquete 15 m3 [9.7 h]; Cargador Frontal 966 [9.09 h]; Excavadora Cat 336 [16.33 h]; Retroexcavadora sobre llantas 58 hp [33.8 h]; Rodillo liso vibratorio 0.80 - 1.10 ton [67.64 h]; Tractor D6 [3.64 h]; Zaranda Metso ST 4.8 168 HP [9.09 h]; Capataz [19.5 h]; Petroleo [504.11 gln]; Cost [400] |  | 473.34 | m3 |  | 0 |  | Interferencias | 60 |
| A3920 |  | Suministro de roca (Alcantarillas) | 50d | 2024-08-20 | 2024-10-18 | A3910 SS | 21d | 0d | Peon [12.69 h]; Peon - Vigia [1.02 h]; Operador equipo Pesado [12.69 h]; Operador equipo Liviano [20.24 h]; Volquete 22 m3 [20.24 h]; Excavadora Cat 336 [12.69 h]; Capataz [5.3 h]; Petroleo [188.4 gln]; Peaje local [7.7]; Cost [400] |  | 169.26 | m3 |  | 0 |  | Interferencias | 60 |
| A3930 |  | Colocación de roca en uña (Alcantarillas) | 50d | 2024-08-20 | 2024-10-18 | A3920 SS | 21d | 0d | Oficial [7.06 h]; Peon [7.06 h]; Operador equipo Pesado [8.46 h]; Excavadora Cat 336 [7.06 h]; Tractor D6 [1.4 h]; Capataz [3.52 h]; Petroleo [69.84 gln]; Cost [400] |  | 169.26 | m3 |  | 0 |  | Interferencias | 60 |
| A3940 |  | Concreto de Nivelacion (f'c=100 kg/cm2) | 50d | 2024-08-20 | 2024-10-18 | A3930 SS | 21d | 0d | Operario [0.75 h]; Oficial [4.77 h]; Peon [20.62 h]; Operador equipo Liviano [0.94 h]; Cisterna 5000 gln [0.19 h]; Carmix 4.0 m3 [0.75 h]; Capataz [1.57 h]; Petroleo [4.52 gln]; PIEDRA CHANCADA [4.88]; ARENA GRUESA [4.13]; CEMENTO PORTLAND TIPO I (42.5 kg) [45.05]; Cost [400] |  | 7.15 | m3 |  | 0 |  | Interferencias | 60 |
| A3950 |  | Concreto Clase F (f'c=140 kg/cm2) | 50d | 2024-08-20 | 2024-10-18 | A3940 SS | 21d | 0d | Operario [14.37 h]; Oficial [37.19 h]; Peon [148.74 h]; Operador equipo Liviano [14.37 h]; Carmix 4.0 m3 [14.37 h]; Capataz [9.3 h]; Petroleo [71.86 gln]; PIEDRA CHANCADA [23.36]; ARENA GRUESA [19.76]; CEMENTO PORTLAND TIPO I (42.5 kg) [251.52]; PLASTIMENT TM-40 - PLASTIFICANTE [77.25]; Cost [400] |  | 34.22 | m3 |  | 0 |  | Interferencias | 60 |
| A3960 |  | Concreto Clase C (f'c=280 kg/cm2) Premezclado - Cimientos reforzados | 50d | 2024-08-20 | 2024-10-18 | A3950 SS | 21d | 0d | Operario [14.83 h]; Oficial [20.59 h]; Peon [47.81 h]; Operador equipo Liviano [9.07 h]; Carmix 4.0 m3 [9.07 h]; Capataz [5.15 h]; Petroleo [48.24 gln]; PIEDRA CHANCADA [14.74]; ARENA GRUESA [12.47]; CEMENTO PORTLAND TIPO I (42.5 kg) [238.14]; PLASTIMENT TM-40 - PLASTIFICANTE [48.76]; ADITIVO CURADOR DE CONCRETO [3.24]; Cost [400] |  | 21.6 | m3 |  | 0 |  | Interferencias | 60 |
| A3970 |  | Concreto Clase C (f'c=280 kg/cm2) Premezclado - Muros de contencion | 50d | 2024-08-20 | 2024-10-18 | A3960 SS | 21d | 0d | Operario [41.72 h]; Oficial [57.91 h]; Peon [150.66 h]; Operador equipo Liviano [25.52 h]; Carmix 4.0 m3 [25.52 h]; Capataz [14.48 h]; Petroleo [135.67 gln]; PIEDRA CHANCADA [41.46]; ARENA GRUESA [35.08]; CEMENTO PORTLAND TIPO I (42.5 kg) [669.77]; PLASTIMENT TM-40 - PLASTIFICANTE [137.14]; ADITIVO CURADOR DE CONCRETO [9.11]; Cost [400] |  | 60.75 | m3 |  | 0 |  | Interferencias | 60 |
| A3980 |  | Encofrado y Desencofrado Caravista | 50d | 2024-08-20 | 2024-10-18 | A3970 SS | 21d | 0d | Operario [58.8 h]; Oficial [58.8 h]; Peon [117.61 h]; Capataz [11.76 h]; ALAMBRE NEGRO #8 [23.52]; CLAVOS PARA MADERA CON CABEZA DE 3" [23.52]; LACA DESMOLDEADORA [3.53]; MADERA TORNILLO INCLUYE CORTE PARA ENCOFRADO [352.83]; TRIPLAY DE 18 mm FENOLICO P/ENCOFRADO [10.23]; Cost [400] |  | 117.61 | m2 |  | 0 |  | Interferencias | 60 |
| A3990 |  | Encofrado y Desencofrado Cara Oculta | 50d | 2024-08-20 | 2024-10-18 | A3980 SS | 21d | 0d | Operario [148.43 h]; Oficial [148.43 h]; Capataz [14.85 h]; ALAMBRE NEGRO #8 [66.79]; CLAVOS PARA MADERA CON CABEZA DE 3" [46.75]; MADERA TORNILLO INCLUYE CORTE PARA ENCOFRADO [1113.2]; Cost [400] |  | 222.64 | m2 |  | 0 |  | Interferencias | 60 |
| A4000 |  | Acero de refuerzo f'y=4200kg/cm2 | 50d | 2024-08-20 | 2024-10-18 | A3990 SS | 21d | 0d | Operario [108.93 h]; Oficial [108.93 h]; Peon [54.47 h]; Capataz [10.8 h]; ALAMBRE NEGRO #16 [225.07]; ACERO CORRUGADO fy = 4200 kg/cm2 GRADO 60 [4726.5]; Cost [400] |  | 4501.43 | kg |  | 0 |  | Interferencias | 60 |
| A4010 |  | Emboquillado de piedra e=0.20m | 50d | 2024-08-20 | 2024-10-18 | A4000 SS | 21d | 0d | Operario [94.47 h]; Oficial [188.91 h]; Peon [308.91 h]; Peon - Vigia [0.31 h]; Operador equipo Pesado [0.44 h]; Operador equipo Liviano [66.64 h]; Cisterna 5000 gln [0.85 h]; Volquete 15 m3 [2.95 h]; Excavadora Cat 336 [0.44 h]; Retroexcavadora sobre llantas 94 hp [62.85 h]; Zaranda estatica [6.34 h]; Capataz [32.71 h]; Petroleo [172.44 gln]; ARENA GRUESA [27.29]; CEMENTO PORTLAND TIPO I (42.5 kg) [265.76]; Cost [400] |  | 338.98 | m2 |  | 0 |  | Interferencias | 60 |
| A4020 |  | Emboquillado de piedra e=0.30m | 50d | 2024-08-20 | 2024-10-18 | A4010 SS | 21d | 0d | Operario [198.63 h]; Oficial [397.27 h]; Peon [649.5 h]; Peon - Vigia [0.62 h]; Operador equipo Pesado [0.95 h]; Operador equipo Liviano [140.04 h]; Cisterna 5000 gln [1.76 h]; Volquete 15 m3 [6.18 h]; Excavadora Cat 336 [0.95 h]; Retroexcavadora sobre llantas 94 hp [132.11 h]; Zaranda estatica [13.31 h]; Capataz [68.81 h]; Petroleo [362.53 gln]; ARENA GRUESA [57.36]; CEMENTO PORTLAND TIPO I (42.5 kg) [558.84]; Cost [400] |  | 475.2 | m2 |  | 0 |  | Interferencias | 60 |
| A4030 |  | Emboquillado de piedra e=0.50m | 50d | 2024-08-20 | 2024-10-18 | A4020 SS | 21d | 0d | Operario [19.87 h]; Oficial [39.75 h]; Peon [62.91 h]; Peon - Vigia [0.07 h]; Operador equipo Pesado [0.11 h]; Operador equipo Liviano [13.12 h]; Cisterna 5000 gln [0.2 h]; Volquete 15 m3 [0.7 h]; Excavadora Cat 336 [0.11 h]; Retroexcavadora sobre llantas 94 hp [12.22 h]; Capataz [6.46 h]; Petroleo [34.21 gln]; ARENA GRUESA [6.52]; CEMENTO PORTLAND TIPO I (42.5 kg) [63.5]; Cost [400] |  | 32.4 | m2 |  | 0 |  | Interferencias | 60 |
| A4040 |  | Cama de arena e=0.20m | 50d | 2024-08-20 | 2024-10-18 | A4030 SS | 21d | 0d | Operario [2.51 h]; Oficial [5.02 h]; Peon [10.08 h]; Peon - Vigia [0.05 h]; Operador equipo Liviano [0.44 h]; Cisterna 5000 gln [0.18 h]; Volquete 22 m3 [0.26 h]; Capataz [0.5 h]; Petroleo [4.04 gln]; ARENA GRUESA [13.8]; Cost [400] |  | 62.71 | m2 |  | 0 |  | Interferencias | 60 |
| A4050 |  | Tubería HDPE Corrugada Ø=900mm (Suministro e instalación) | 50d | 2024-08-20 | 2024-10-18 | A4040 SS | 21d | 0d | Operario [4.82 h]; Oficial [9.64 h]; Peon [9.64 h]; Operador equipo Pesado [2.41 h]; Operador equipo Liviano [1.2 h]; Camion grua 20 ton [1.2 h]; Excavadora Cat 336 [2.41 h]; Capataz [4.82 h]; Petroleo [25.31 gln]; Tubería HDPE Corrugado de 900 mm [15.91]; Cost [400] |  | 14.46 | m |  | 0 |  | Interferencias | 60 |
| A4060 |  | Tubería HDPE Corrugada Ø=1200mm (Suministro e instalación) | 50d | 2024-08-20 | 2024-10-18 | A4050 SS | 21d | 0d | Operario [4.54 h]; Oficial [9.08 h]; Peon [9.08 h]; Operador equipo Pesado [2.27 h]; Operador equipo Liviano [1.13 h]; Camion grua 20 ton [1.13 h]; Excavadora Cat 336 [2.27 h]; Capataz [4.54 h]; Petroleo [23.84 gln]; TUBERIA CORRUGADA HDPE D=1200 mm [14.98]; Cost [400] |  | 13.62 | m |  | 0 |  | Interferencias | 60 |
| A4070 |  | Compuertas Charnela Ø900 (Suministro e instalacion) | 50d | 2024-08-20 | 2024-10-18 | A4060 SS | 21d | 0d | Operario [8 h]; Oficial [16 h]; Peon [32 h]; Operador equipo Liviano [6 h]; Camion grua 20 ton [6 h]; Capataz [4 h]; Petroleo [24 gln]; ANCLAJES [4]; Suministro de Compuerta tipo CHARNELA, D=900mm [1]; Cost [400] |  | 1 | und |  | 0 |  | Interferencias | 60 |
| A4080 |  | Compuertas Charnela Ø1200 (Suministro e instalacion) | 50d | 2024-08-20 | 2024-10-18 | A4070 SS | 21d | 0d | Operario [8 h]; Oficial [16 h]; Peon [32 h]; Operador equipo Liviano [6 h]; Camion grua 20 ton [6 h]; Capataz [4 h]; Petroleo [24 gln]; ANCLAJES [4]; Suministro de Compuerta tipo CHARNELA, D=1200mm [1]; Cost [400] |  | 1 | und |  | 0 |  | Interferencias | 60 |
| A4090 |  | Sello en juntas | 50d | 2024-08-20 | 2024-10-18 | A4080 SS | 21d | 0d | Operario [107.41 h]; Peon [26.84 h]; Capataz [26.84 h]; TECNOPOR DE 1/2"X4X8' [18.37]; SELLADOR ELASTICO POLIURETANO SIKAFLEX 1A [92.16]; Cost [400] |  | 322.25 | m |  | 0 |  | Interferencias | 60 |
| A4100 |  | Waterstop (anillos de estanqueidad) | 50d | 2024-08-20 | 2024-10-18 | A4090 SS | 21d | 0d | Operario [4 h]; Peon [8 h]; Capataz [0.4 h]; WATER STOP (anillos de estanqueidad); DN=900mm [3.64]; WATER STOP (anillos de estanqueidad); DN=1200mm [0.36]; Cost [400] |  | 4 | und |  | 0 |  | Interferencias | 60 |
| A4110 |  | Pintura bituminosa | 50d | 2024-08-20 | 2024-10-18 | A4100 SS | 21d | 0d | Operario [44.53 h]; Peon [89.06 h]; Capataz [4.45 h]; PINTURA ASFALTICA [89.06]; IMPRIMANTE ASFALTICO [38.96]; Cost [400] |  | 222.64 | m2 |  | 0 |  | Interferencias | 60 |
| A4120 |  | Suministro e Instalación de geotextil | 50d | 2024-08-20 | 2024-10-18 | A4110 SS | 21d | 0d | Oficial [1.17 h]; Peon [1.76 h]; Operador equipo Liviano [0.15 h]; Camion grua 20 ton [0.15 h]; Capataz [0.12 h]; Petroleo [0.58 gln]; Geotextil no tejido 200gr/m2 [52.8]; Cost [400] |  | 44 | m2 |  | 0 |  | Interferencias | 60 |

| ID | WBS | Activity | Type | Duration | Start | Finish | Predecessors | Total float | Free float | Resources | Metrado | Unidad | RCuad | AGrupo | Duracion | Cuadrilla | Rendimiento | Turno | DurCal | Dur. Cal. |
| --- | --- | --- | --- | --- | --- | --- | --- | --- | --- | --- | --- | --- | --- | --- | --- | --- | --- | --- | --- | --- |
|  | 7 | **ACCESOS** |  |  | 2024-10-19 | 2024-11-06 |  |  |  |  |  |  |  |  |  |  |  |  |  |  |
| A4130 |  | Concreto clase C (f'c=280 kg/cm2) en losa |  | 15d | 2024-10-19 | 2024-11-06 | A1210, A4120 | 21d | 0d | Operario [51.66 h]; Oficial [76.86 h]; Peon [206.64 h]; Operador equipo Liviano [26.46 h]; Carmix 4.0 m3 [26.46 h]; Capataz [19.21 h]; Petroleo [144.9 gln]; PIEDRA CHANCADA [43]; ARENA GRUESA [36.38]; CEMENTO PORTLAND TIPO I (42.5 kg) [694.58]; PLASTIMENT TM-40 - PLASTIFICANTE [142.22]; ADITIVO CURADOR DE CONCRETO [9.45]; Cost [120] | 63 | m3 | 0 | Accesos | 19 |  |  |  |  |  |
| A4140 |  | Encofrado y desencofrado pavimento rígido e=0.15m |  | 15d | 2024-10-19 | 2024-11-06 | A4130 SS | 21d | 0d | Operario [22.8 h]; Oficial [22.8 h]; Peon [45.6 h]; Capataz [22.8 h]; ALAMBRE NEGRO #8 [11.4]; CLAVOS PARA MADERA CON CABEZA [22.8]; DESMOLDANTE PARA MADERA [1.82]; MADERA TORNILLO INCLUYE CORTE PARA ENCOFRADO [114]; TRIPLAY DE 19 mm PARA ENCOFRADO [5.7]; Cost [120] | 228 | m | 0 | Accesos | 19 |  |  |  |  |  |
| A4150 |  | Junta en Pavimentos con Pasadores |  | 15d | 2024-10-19 | 2024-11-06 | A4140 SS | 21d | 0d | Operario [24.34 h]; Oficial [11.14 h]; Peon [37.54 h]; Capataz [4.86 h]; DOWELL LISO Ø 3/4", L=500, c/0.50m [408.87]; MATERIAL DE RESPALDO 1" PARA JUNTAS 20 mm [138.6]; SELLO ELASTOMETRICO A BASE DE SILICONA [6.34]; Cost [120] | 132 | m | 0 | Accesos | 19 |  |  |  |  |  |
| A4160 |  | Concreto Ciclopeo f'c=210 kg/cm2 + 30% PM |  | 15d | 2024-10-19 | 2024-11-06 | A4150 SS | 21d | 16d | Operario [4.18 h]; Oficial [4.96 h]; Peon [26.85 h]; Peon - Vigia [0 h]; Operador equipo Pesado [0 h]; Operador equipo Liviano [1.91 h]; Volquete 15 m3 [0.02 h]; Carmix 4.0 m3 [1.86 h]; Excavadora Cat 336 [0 h]; Retroexcavadora sobre llantas 94 hp [0.03 h]; Zaranda estatica [0.03 h]; Capataz [2.41 h]; Petroleo [9.45 gln]; PIEDRA CHANCADA [3.02]; ARENA GRUESA [2.56]; CEMENTO PORTLAND TIPO I (42.5 kg) [41.85]; PLASTIMENT TM-40 - PLASTIFICANTE [10]; Cost [120] | 6.2 | m3 | 0 | Accesos | 19 |  |  |  |  |  |
|  | 5 | **DE-PR-11-D** |  |  | 2024-08-01 | 2024-12-16 |  |  |  |  |  |  |  |  |  |  |  |  |  |  |
| A2390 |  | Inicio - DE-PR-11-D | milestone | 0d | 2024-08-01 | 2024-08-01 | A5630 SS | 0d |  |  |  |  | 0 |  | 0 |  |  |  |  |  |
| A2400 |  | Fin - DE-PR-11-D | milestone | 0d | 2024-12-16 | 2024-12-16 | A2120 FF, A2130 FF, A2160 FF, A2180 FF, A2200 FF, A2260 FF, A2280 FF, A2300 FF, A2320 FF, A2340 FF, A2360 FF, A2380 FF, A5000 FF | 247d |  |  |  |  | 0 |  | 0 |  |  |  |  |  |
|  | 1 | **EXCAVACIONES** |  |  | 2024-08-01 | 2024-10-30 |  |  |  |  |  |  |  |  |  |  |  |  |  |  |
| A2070 |  | Desbroce |  | 50d | 2024-08-01 | 2024-09-30 | A2390 SS | 0d |  | Peon [66.4 h]; Operador equipo Pesado [49.8 h]; Excavadora Cat 336 [16.6 h]; Tractor D6 [33.2 h]; Capataz [0.33 h]; Petroleo [373.5 gln]; Cost [400] | 3.32 | ha | 1 | Excavacion | 61 | 1 | 0.8 | 1 | 3.32 | 4.15 |
| A2130 |  | Conformacion de Material Excedente en DMO |  | 50d | 2024-08-01 | 2024-09-30 | A2070 SS | 310d | 63d | Peon [79.87 h]; Operador equipo Pesado [88.28 h]; Excavadora Cat 336 [8.41 h]; Tractor D6 [79.87 h]; Capataz [8.41 h]; Petroleo [630.59 gln]; Cost [400] | 10509.82 | m3 | 1 | Excavacion | 61 | 1 | 1050 | 1 | 10509.82 | 10.0093523809524 |
| A2080 |  | Remocion de Dique Existente |  | 66d | 2024-08-03 | 2024-10-22 | A2070 SS+2d | 0d |  | Peon [91.05 h]; Operador equipo Pesado [136.58 h]; Excavadora Cat 336 [91.05 h]; Tractor D8 [45.53 h]; Capataz [18.21 h]; Petroleo [1206.46 gln]; Cost [528] | 9105.35 | m3 | 0.5 | Excavacion | 81 | 0.5 | 800 | 1 | 18210.7 | 22.763375 |
| A2090 |  | Excavacion de Cimentacion |  | 66d | 2024-08-03 | 2024-10-22 | A2080 SS | 0d |  | Peon [799.33 h]; Operador equipo Pesado [532.89 h]; Operador equipo Liviano [444.07 h]; Excavadora Cat 336 [355.26 h]; Retroexcavadora sobre llantas 94 hp [444.07 h]; Tractor D8 [177.63 h]; Capataz [79.93 h]; Petroleo [5808.48 gln]; Cost [528] | 44407.31 | m3 | 0.5 | Excavacion | 81 | 0.5 | 880 | 1 | 88814.62 | 100.925704545455 |
| A2110 |  | Excavacion de Uña |  | 66d | 2024-08-03 | 2024-10-22 | A2090 SS | 247d | 0d | Peon [272.58 h]; Operador equipo Pesado [272.58 h]; Excavadora Cat 336 [272.58 h]; Capataz [54.52 h]; Petroleo [3080.1 gln]; Cost [528] | 17035.97 | m3 | 0.5 | Excavacion | 81 | 0.5 | 500 | 1 | 34071.94 | 68.14388 |
| A2120 |  | Conformacion de Material Excedente en DME |  | 66d | 2024-08-03 | 2024-10-22 | A2080 SS | 292d | 45d | Peon [473.85 h]; Operador equipo Pesado [523.73 h]; Excavadora Cat 336 [49.88 h]; Tractor D6 [473.85 h]; Capataz [49.88 h]; Petroleo [3740.95 gln]; Cost [528] | 62349.15 | m3 | 1 | Excavacion | 81 | 1 | 1050 | 1 | 62349.15 | 59.3801428571429 |
| A2140 |  | Excavacion Localizada - Sobreexcavacion |  | 65d | 2024-08-03 | 2024-10-21 | A2110 SS | 273d | 21d | Peon [272.62 h]; Operador equipo Pesado [272.62 h]; Excavadora Cat 336 [272.62 h]; Capataz [54.85 h]; Petroleo [2317.64 gln]; Cost [520] | 8186.66 | m3 | 0.5 | Excavacion | 80 | 0.5 | 240 | 1 | 16373.32 | 68.2221666666667 |
| A2100 |  | Perfilado y Conformacion de Plataforma de Fundacion |  | 53d | 2024-08-28 | 2024-10-30 | A2090 SS+20d | 269d | 0d | Peon [139.61 h]; Operador equipo Pesado [249.04 h]; Operador equipo Liviano [52.83 h]; Cisterna 5000 gln [52.83 h]; Motoniveladora 140K [124.52 h]; Rodillo liso vibratorio 10 - 12 ton [124.52 h]; Capataz [11.32 h]; Petroleo [1071.64 gln]; Cost [424] | 37733.71 | m2 | 0.3 | Excavacion | 64 | 0.3 | 2400 | 1 | 125779.033333333 | 52.4079305555554 |
|  | 2 | **RELLENOS** |  |  | 2024-09-09 | 2024-12-16 |  |  |  |  |  |  |  |  |  |  |  |  |  |  |
| A2150 |  | Relleno con Material Granular (incluye extraccion de material, zarandeo y combinado) |  | 57d | 2024-09-09 | 2024-11-15 | A2100 SS+9d | 269d | 0d | Operario [192.65 h]; Oficial [561.68 h]; Peon [1853.28 h]; Peon - Vigia [97.68 h]; Operador equipo Pesado [2621.18 h]; Operador equipo Liviano [1245.47 h]; Cisterna 5000 gln [561.68 h]; Volquete 15 m3 [485.7 h]; Cargador Frontal 966 [778.76 h]; Chancadora Primaria [366.31 h]; Excavadora Cat 336 [553.54 h]; Retroexcavadora sobre llantas 58 hp [97.68 h]; Rodillo liso vibratorio 10 - 12 ton [369.03 h]; Rodillo liso vibratorio 0.80 - 1.10 ton [192.65 h]; Tractor D6 [464 h]; Capataz [667.51 h]; Petroleo [21010.1 gln]; Cost [456] | 27134.36 | m3 | 1 | Relleno | 68 | 1 | 560 | 1 | 27134.36 | 48.4542142857143 |
| A2190 |  | Relleno con Material Seleccionado (incluye extraccion de material, zarandeo y combinado) |  | 57d | 2024-09-09 | 2024-11-15 | A2150 SS | 273d | 0d | Oficial [274.46 h]; Peon [563.77 h]; Operador equipo Pesado [823.39 h]; Operador equipo Liviano [57.7 h]; Cisterna 5000 gln [57.7 h]; Excavadora Cat 336 [548.93 h]; Rodillo liso vibratorio 10 - 12 ton [274.46 h]; Capataz [55.22 h]; Petroleo [8393.84 gln]; Cost [456] | 8242.18 | m3 | 1 | Relleno | 68 | 1 | 240 | 1 | 8242.18 | 34.3424166666667 |
| A2200 |  | Grava para Drenaje |  | 40d | 2024-09-17 | 2024-11-04 | A2190 SS+7d | 282d | 35d | Peon [208 h]; Peon - Vigia [6.52 h]; Operador equipo Pesado [85.3 h]; Operador equipo Liviano [191.76 h]; Volquete 15 m3 [32.62 h]; Cargador Frontal 966 [36.6 h]; Chancadora Primaria [24.35 h]; Excavadora Cat 336 [24.35 h]; Retroexcavadora sobre llantas 94 hp [159.14 h]; Tractor D6; Capataz [64.13 h]; Petroleo [1088.37 gln]; Cost [320] | 1591.41 | m3 | 1 | Relleno | 49 | 1 | 80 | 1 | 1591.41 | 19.892625 |
| A2180 |  | Perfilado de Talud Dique |  | 50d | 2024-09-20 | 2024-11-19 | A2150 SS+10d | 269d | 22d | Peon [82.42 h]; Operador equipo Pesado [24.58 h]; Excavadora Cat 336 [24.58 h]; Capataz [16.63 h]; Petroleo [208.94 gln]; Cost [400] | 7229.75 | m2 | 1 | Relleno | 61 | 1 | 700 | 1 | 7229.75 | 10.3282142857143 |
| A2160 |  | Relleno sin Compactar |  | 20d | 2024-11-16 | 2024-12-10 | A2250 FF, A2140 | 252d | 5d | Oficial [90.76 h]; Peon [90.76 h]; Operador equipo Pesado [90.76 h]; Tractor D6 [90.76 h]; Capataz [18.36 h]; Petroleo [635.31 gln]; Cost [160] | 10197.58 | m3 | 1 | Relleno | 25 | 1 | 900 | 1 | 10197.58 | 11.3306444444444 |
| A2170 |  | Relleno Afirmado |  | 5d | 2024-12-11 | 2024-12-16 | A2250 | 247d | 0d | Oficial [37.9 h]; Peon [119.23 h]; Peon - Vigia [12.74 h]; Operador equipo Pesado [218.51 h]; Operador equipo Liviano [80.56 h]; Cisterna 5000 gln [17.34 h]; Volquete 15 m3 [63.22 h]; Cargador Frontal 966 [26.85 h]; Chancadora LT200 [26.85 h]; Excavadora Cat 336 [50.33 h]; Motoniveladora 140K [37.9 h]; Rodillo liso vibratorio 10 - 12 ton [37.9 h]; Tractor D6 [11.82 h]; Zaranda Metso ST 4.8 168 HP [26.85 h]; Capataz [46.19 h]; Petroleo [1539.09 gln]; CANON POR EXTRACCION CANTERA [1611.21]; Cost [40] | 1534.49 | m3 | 1 | Relleno | 6 | 1 | 324 | 1 | 1534.49 | 4.73608024691358 |

| ID | WBS | Activity | Duration | Start | Finish | Predecessors | Total float | Free float | Resources | Cuadrilla | Rendimiento | Metrado | Unidad | Turno | RCuad | DurCal | Dur. Cal. | AGrupo | Duracion |
| --- | --- | --- | --- | --- | --- | --- | --- | --- | --- | --- | --- | --- | --- | --- | --- | --- | --- | --- | --- |
|  | 3 | **GEOTEXTIL** |  | 2024-08-13 | 2024-11-23 |  |  |  |  |  |  |  |  |  |  |  |  |  |  |
| A2210 |  | Instalacion de Geotextil 400gr/m2 | 86d | 2024-08-13 | 2024-11-23 | A2110 SS+7d | 247d | 0d | Oficial [1049 h]; Peon [1571.54 h]; Operador equipo Liviano [129.65 h]; Camion grua 20 ton [129.65 h]; Capataz [106.08 h]; Petroleo [518.61 gln]; Geotextil no tejido 200gr/m2 [45181.8]; Cost [688] | 1 | 600 | 39288.48 | m2 | 1 | 1 | 39288.48 | 65.4808 | Geotextil | 103 |
| A2220 |  | Zanja de Anclaje | 30d | 2024-10-19 | 2024-11-23 | A2210 FF | 265d | 0d | Oficial [69.01 h]; Peon [207.53 h]; Operador equipo Pesado [69.01 h]; Operador equipo Liviano [1.93 h]; Cisterna 5000 gln [1.93 h]; Retroexcavadora sobre llantas 58 hp [69.01 h]; Capataz [13.8 h]; Petroleo [245.87 gln]; Cost [240] | 1 | 32 | 276.04 | m3 | 1 | 1 | 276.04 | 8.62625 | Geotextil | 36 |
|  | 4 | **COLOCACION DE ROCA** |  | 2024-08-03 | 2024-12-10 |  |  |  |  |  |  |  |  |  |  |  |  |  |  |
| A2260 |  | Extraccion de Rocas Reutilizables | 65d | 2024-08-03 | 2024-10-21 | A2080 SS | 293d | 46d | Peon [391.05 h]; Operador equipo Pesado [391.05 h]; Excavadora Cat 336 [391.05 h]; Capataz [195.7 h]; Petroleo [3324.1 gln]; Cost [520] | 1 | 144 | 3476 | m3 | 1 | 1 | 3476 | 24.1388888888889 | Roca | 80 |
| A2230 |  | Suministro de roca | 98d | 2024-08-14 | 2024-12-10 | A2240 SS | 252d | 0d | Cost [784] | 1 |  |  | ton | 1 | 1 | 0 |  | Roca | 119 |
| A2240 |  | Colocacion de Roca en Uña | 61d | 2024-08-14 | 2024-10-25 | A2110 SS+7d, A2210 SS+1d | 247d | 0d | Oficial [487.23 h]; Peon [487.23 h]; Operador equipo Pesado [536.63 h]; Excavadora Cat 336 [487.23 h]; Tractor D6 [49.4 h]; Capataz [243.61 h]; Petroleo [4487.27 gln]; Roca [17036 m3]; Cost [488] | 1 | 280 | 17035.97 | m3 | 1 | 1 | 17035.97 | 60.84275 | Roca | 73 |
| A2250 |  | Colocacion de Roca en Talud | 37d | 2024-10-26 | 2024-12-10 | A2240, A2210 SS, A2150 SS+15d | 247d | 0d | Oficial [581.31 h]; Peon [581.31 h]; Operador equipo Pesado [1219.77 h]; Excavadora Cat 336 [1161.22 h]; Tractor D6 [58.55 h]; Capataz [289.96 h]; Petroleo [10280.9 gln]; Roca [13940.2 m3]; Cost [296] | 2 | 192 | 13940.18 | m3 | 1 | 1 | 13940.18 | 72.6051041666667 | Roca | 46 |
|  | 5 | **TRANSPORTES** |  | 2024-08-01 | 2024-12-16 |  |  |  |  |  |  |  |  |  |  |  |  |  |  |
| A2270 |  | Transporte de Material Organico (a DMO) D<=1km | 50d | 2024-08-01 | 2024-09-30 | A2070 SS | 310d | 0d | Peon - Vigia [58.85 h]; Operador equipo Liviano [292.17 h]; Volquete 15 m3 [292.17 h]; Petroleo [817.66 gln]; Cost [400] | 1 |  | 10509.82 | m3k | 1 | 1 | 10509.82 |  | Transportes | 61 |
| A2280 |  | Transporte de Material Organico (a DMO) D>1km | 50d | 2024-08-01 | 2024-09-30 | A2270 SS | 310d | 63d | Operador equipo Liviano [1665.61 h]; Volquete 15 m3 [1665.61 h]; Petroleo [4663.72 gln]; Cost [400] | 1 |  | 151419.39 | m3k | 1 | 1 | 151419.39 |  | Transportes | 61 |
| A2290 |  | Transporte de Material Excedente D<=1km | 66d | 2024-08-03 | 2024-10-22 | A2080 SS | 292d | 0d | Peon - Vigia [317.98 h]; Operador equipo Liviano [1583.67 h]; Volquete 22 m3 [679.61 h]; Volquete 15 m3 [904.06 h]; Petroleo [5305.91 gln]; Cost [528] | 1 |  | 62349.15 | m3k | 1 | 1 | 62349.15 |  | Transportes | 81 |
| A2300 |  | Transporte de Material Excedente D>1km | 66d | 2024-08-03 | 2024-10-22 | A2290 SS | 292d | 45d | Operador equipo Liviano [9046.57 h]; Volquete 22 m3 [3851.51 h]; Volquete 15 m3 [5195.06 h]; Petroleo [30274.6 gln]; Cost [528] | 1 |  | 895699.53 | m3k | 1 | 1 | 895699.53 |  | Transportes | 81 |
| A2330 |  | Transporte de Roca D<=1km | 98d | 2024-08-14 | 2024-12-10 | A2230 SS | 252d | 0d | Peon [401.52 h]; Peon - Vigia [192.73 h]; Operador equipo Pesado [401.52 h]; Operador equipo Liviano [963.65 h]; Volquete 22 m3 [963.65 h]; Excavadora Cat 336 [401.52 h]; Petroleo [7233.8 gln]; Peaje local [1461.54]; Cost [784] | 1 |  | 32121.68 | m3k | 1 | 1 | 32121.68 |  | Transportes | 119 |
| A2340 |  | Transporte de Roca D>1km | 98d | 2024-08-14 | 2024-12-10 | A2330 SS | 252d | 5d | Operador equipo Liviano [6109.12 h]; Volquete 22 m3 [6109.12 h]; Petroleo [24322.3 gln]; Cost [784] | 1 |  | 570945.49 | m3k | 1 | 1 | 570945.49 |  | Transportes | 119 |
| A2350 |  | Transporte de Material de Prestamo Cantera de Rio (Cuerpo de Terraplen) D<=1km | 57d | 2024-09-09 | 2024-11-15 | A2150 SS | 272d | 0d | Peon - Vigia [169.86 h]; Operador equipo Liviano [845.26 h]; Volquete 22 m3 [845.26 h]; Petroleo [3465.96 gln]; Cost [456] | 1 |  | 40442.95 | m3k | 1 | 1 | 40442.95 |  | Transportes | 68 |
| A2360 |  | Transporte de Material de Prestamo Cantera de Rio (Cuerpo de Terraplen) D>1km | 57d | 2024-09-09 | 2024-11-15 | A2350 SS | 272d | 25d | Operador equipo Liviano [4993.48 h]; Volquete 22 m3 [4993.48 h]; Petroleo [20455.2 gln]; Cost [456] | 1 |  | 601623.96 | m3k | 1 | 1 | 601623.96 |  | Transportes | 68 |
| A2370 |  | Transporte de Material Seleccionado para Zanja D<=1km | 30d | 2024-10-19 | 2024-11-23 | A2220 SS | 265d | 0d | Peon - Vigia [1.55 h]; Operador equipo Liviano [7.67 h]; Volquete 15 m3 [7.67 h]; Petroleo [21.48 gln]; Cost [240] | 1 |  | 276.04 | m3k | 1 | 1 | 276.04 |  | Transportes | 36 |
| A2380 |  | Transporte de Material Seleccionado para Zanja D>1km | 30d | 2024-10-19 | 2024-11-23 | A2370 SS | 265d | 18d | Operador equipo Liviano [45.1 h]; Volquete 15 m3 [45.1 h]; Petroleo [126.28 gln]; Cost [240] | 1 |  | 4099.99 | m3k | 1 | 1 | 4099.99 |  | Transportes | 36 |
| A2310 |  | Transporte de Material de Prestamo (Afirmado) D<=1km | 12d | 2024-12-02 | 2024-12-16 | A2170 FF | 247d | 0d | Peon - Vigia [90.84 h]; Operador equipo Liviano [452.02 h]; Volquete 22 m3 [452.02 h]; Petroleo [1853.49 gln]; Cost [96] | 1 |  | 21627.64 | m3k | 1 | 1 | 21627.64 |  | Transportes | 15 |
| A2320 |  | Transporte de Material de Prestamo (Afirmado) D>1km | 12d | 2024-12-02 | 2024-12-16 | A2310 SS | 247d | 0d | Operador equipo Liviano [3584.67 h]; Volquete 22 m3 [3584.67 h]; Petroleo [14684.2 gln]; Cost [96] | 1 |  | 431888.31 | m3k | 1 | 1 | 431888.31 |  | Transportes | 15 |
|  | 6 | **INTERFERENCIAS** |  | 2024-08-26 | 2024-10-24 |  |  |  |  |  |  |  |  |  |  |  |  |  |  |
| A4680 |  | Trazo y replanteo de interferencia | 50d | 2024-08-26 | 2024-10-24 | A2070 SS+20d | 265d | 0d | Peon [52.05 h]; Topografo [26.02 h]; GPS [26.02 h]; Capataz [2.6 h]; MADERA TORNILLO [26.02]; PINTURA ESMALTE [2.6]; Cost [400] |  |  | 1301.17 | m2 |  | 0 |  |  | Interferencias | 60 |
| A4690 |  | Desvío provisional con tubería | 50d | 2024-08-26 | 2024-10-24 | A4680 SS | 265d | 0d | Operario [24.53 h]; Oficial [24.53 h]; Peon [157.03 h]; Operador equipo Pesado [9.81 h]; Operador equipo Liviano [6.13 h]; Camion grua 20 ton [6.13 h]; Excavadora Cat 336 [9.81 h]; Capataz [14.24 h]; Petroleo [107.93 gln]; TUBERIA CORRUGADA HDPE D=630 mm [77.29]; Cost [400] |  |  | 73.61 | m |  | 0 |  |  | Interferencias | 60 |
| A4700 |  | Desvío provisional en tierras | 50d | 2024-08-26 | 2024-10-24 | A4690 SS | 265d | 0d | Peon [48.25 h]; Operador equipo Pesado [48.25 h]; Excavadora Cat 336 [48.25 h]; Capataz [9.67 h]; Petroleo [410.18 gln]; Cost [400] |  |  | 362 | m |  | 0 |  |  | Interferencias | 60 |
| A4710 |  | Limpieza de terreno manual | 50d | 2024-08-26 | 2024-10-24 | A4700 SS | 265d | 0d | Oficial [10.41 h]; Peon [20.82 h]; Operador equipo Pesado [3.9 h]; Excavadora Cat 336 [1.3 h]; Tractor D6 [2.6 h]; Capataz [0.52 h]; Petroleo [29.28 gln]; Cost [400] |  |  | 1301.17 | m2 |  | 0 |  |  | Interferencias | 60 |
| A4720 |  | Excavaciones no clasificada para estructuras | 50d | 2024-08-26 | 2024-10-24 | A4710 SS | 265d | 0d | Peon [5.65 h]; Operador equipo Pesado [5.65 h]; Excavadora Cat 336 [5.65 h]; Capataz [1.13 h]; Petroleo [48 gln]; Cost [400] |  |  | 176.47 | m3 |  | 0 |  |  | Interferencias | 60 |
| A4730 |  | Excavacion no clasificada de zanja | 50d | 2024-08-26 | 2024-10-24 | A4720 SS | 265d | 0d | Peon [21.9 h]; Operador equipo Pesado [21.9 h]; Excavadora Cat 336 [21.9 h]; Capataz [2.19 h]; Petroleo [186.12 gln]; Cost [400] |  |  | 437.93 | m3 |  | 0 |  |  | Interferencias | 60 |
| A4740 |  | Relleno estructural | 50d | 2024-08-26 | 2024-10-24 | A4730 SS | 265d | 0d | Operario [46.29 h]; Oficial [46.29 h]; Peon [111.04 h]; Peon - Vigia [1.33 h]; Operador equipo Pesado [49.24 h]; Operador equipo Liviano [57.5 h]; Cisterna 5000 gln [4.57 h]; Volquete 15 m3 [6.64 h]; Cargador Frontal 966 [6.22 h]; Excavadora Cat 336 [11.18 h]; Retroexcavadora sobre llantas 58 hp [23.13 h]; Rodillo liso vibratorio 0.80 - 1.10 ton [46.29 h]; Tractor D6 [2.49 h]; Zaranda Metso ST 4.8 168 HP [6.22 h]; Capataz [13.35 h]; Petroleo [344.99 gln]; Cost [400] |  |  | 323.93 | m3 |  | 0 |  |  | Interferencias | 60 |
| A4750 |  | Suministro de roca (Alcantarillas) | 50d | 2024-08-26 | 2024-10-24 | A4740 SS | 265d | 0d | Peon [21.11 h]; Peon - Vigia [1.69 h]; Operador equipo Pesado [21.11 h]; Operador equipo Liviano [33.67 h]; Volquete 22 m3 [33.67 h]; Excavadora Cat 336 [21.11 h]; Capataz [8.81 h]; Petroleo [313.37 gln]; Peaje local [12.81]; Cost [400] |  |  | 281.53 | m3 |  | 0 |  |  | Interferencias | 60 |
| A4760 |  | Colocación de roca en uña (Alcantarillas) | 50d | 2024-08-26 | 2024-10-24 | A4750 SS | 265d | 0d | Oficial [11.74 h]; Peon [11.74 h]; Operador equipo Pesado [14.08 h]; Excavadora Cat 336 [11.74 h]; Tractor D6 [2.34 h]; Capataz [5.86 h]; Petroleo [116.16 gln]; Cost [400] |  |  | 281.53 | m3 |  | 0 |  |  | Interferencias | 60 |
| A4770 |  | Concreto de Nivelacion (f'c=100 kg/cm2) | 50d | 2024-08-26 | 2024-10-24 | A4760 SS | 265d | 0d | Operario [2.53 h]; Oficial [16.04 h]; Peon [69.37 h]; Operador equipo Liviano [3.17 h]; Cisterna 5000 gln [0.64 h]; Carmix 4.0 m3 [2.53 h]; Capataz [5.27 h]; Petroleo [15.19 gln]; PIEDRA CHANCADA [16.42]; ARENA GRUESA [13.89]; CEMENTO PORTLAND TIPO I (42.5 kg) [151.58]; Cost [400] |  |  | 24.06 | m3 |  | 0 |  |  | Interferencias | 60 |
| A4780 |  | Concreto Clase F (f'c=140 kg/cm2) | 50d | 2024-08-26 | 2024-10-24 | A4770 SS | 265d | 0d | Operario [7.08 h]; Oficial [18.31 h]; Peon [73.24 h]; Operador equipo Liviano [7.08 h]; Carmix 4.0 m3 [7.08 h]; Capataz [4.58 h]; Petroleo [35.38 gln]; PIEDRA CHANCADA [11.5]; ARENA GRUESA [9.73]; CEMENTO PORTLAND TIPO I (42.5 kg) [123.85]; PLASTIMENT TM-40 - PLASTIFICANTE [38.04]; Cost [400] |  |  | 16.85 | m3 |  | 0 |  |  | Interferencias | 60 |
| A4790 |  | Concreto Clase C (f'c=280 kg/cm2) Premezclado - Cimientos reforzados | 50d | 2024-08-26 | 2024-10-24 | A4780 SS | 265d | 0d | Operario [15.59 h]; Oficial [21.64 h]; Peon [50.24 h]; Operador equipo Liviano [9.53 h]; Carmix 4.0 m3 [9.53 h]; Capataz [5.41 h]; Petroleo [50.7 gln]; PIEDRA CHANCADA [15.49]; ARENA GRUESA [13.11]; CEMENTO PORTLAND TIPO I (42.5 kg) [250.27]; PLASTIMENT TM-40 - PLASTIFICANTE [51.25]; ADITIVO CURADOR DE CONCRETO [3.4]; Cost [400] |  |  | 22.7 | m3 |  | 0 |  |  | Interferencias | 60 |
| A4800 |  | Concreto Clase C (f'c=280 kg/cm2) Premezclado - Muros de contencion | 50d | 2024-08-26 | 2024-10-24 | A4790 SS | 265d | 0d | Operario [26.31 h]; Oficial [36.53 h]; Peon [95.03 h]; Operador equipo Liviano [16.09 h]; Carmix 4.0 m3 [16.09 h]; Capataz [9.13 h]; Petroleo [85.58 gln]; PIEDRA CHANCADA [26.15]; ARENA GRUESA [22.13]; CEMENTO PORTLAND TIPO I (42.5 kg) [422.48]; PLASTIMENT TM-40 - PLASTIFICANTE [86.51]; ADITIVO CURADOR DE CONCRETO [5.75]; Cost [400] |  |  | 38.32 | m3 |  | 0 |  |  | Interferencias | 60 |
| A4810 |  | Encofrado y Desencofrado Caravista | 50d | 2024-08-26 | 2024-10-24 | A4800 SS | 265d | 0d | Operario [30.89 h]; Oficial [30.89 h]; Peon [61.79 h]; Capataz [6.18 h]; ALAMBRE NEGRO #8 [12.36]; CLAVOS PARA MADERA CON CABEZA DE 3" [12.36]; LACA DESMOLDEADORA [1.85]; MADERA TORNILLO INCLUYE CORTE PARA ENCOFRADO [185.37]; TRIPLAY DE 18 mm FENOLICO P/ENCOFRADO [5.38]; Cost [400] |  |  | 61.79 | m2 |  | 0 |  |  | Interferencias | 60 |
| A4820 |  | Encofrado y Desencofrado Cara Oculta | 50d | 2024-08-26 | 2024-10-24 | A4810 SS | 265d | 0d | Operario [75.48 h]; Oficial [75.48 h]; Capataz [7.55 h]; ALAMBRE NEGRO #8 [33.96]; CLAVOS PARA MADERA CON CABEZA DE 3" [23.77]; MADERA TORNILLO INCLUYE CORTE PARA ENCOFRADO [566.05]; Cost [400] |  |  | 113.21 | m2 |  | 0 |  |  | Interferencias | 60 |
| A4830 |  | Acero de refuerzo f'y=4200kg/cm2 | 50d | 2024-08-26 | 2024-10-24 | A4820 SS | 265d | 0d | Operario [74.42 h]; Oficial [74.42 h]; Peon [37.21 h]; Capataz [7.38 h]; ALAMBRE NEGRO #16 [153.76]; ACERO CORRUGADO fy = 4200 kg/cm2 GRADO 60 [3228.97]; Cost [400] |  |  | 3075.21 | kg |  | 0 |  |  | Interferencias | 60 |
| A4840 |  | Emboquillado de piedra e=0.20m | 50d | 2024-08-26 | 2024-10-24 | A4830 SS | 265d | 0d | Operario [8.63 h]; Oficial [17.25 h]; Peon [28.2 h]; Peon - Vigia [0.03 h]; Operador equipo Pesado [0.04 h]; Operador equipo Liviano [6.08 h]; Cisterna 5000 gln [0.08 h]; Volquete 15 m3 [0.27 h]; Excavadora Cat 336 [0.04 h]; Retroexcavadora sobre llantas 94 hp [5.74 h]; Zaranda estatica [0.58 h]; Capataz [2.99 h]; Petroleo [15.74 gln]; ARENA GRUESA [2.49]; CEMENTO PORTLAND TIPO I (42.5 kg) [24.26]; Cost [400] |  |  | 30.95 | m2 |  | 0 |  |  | Interferencias | 60 |
| A4850 |  | Emboquillado de piedra e=0.30m | 50d | 2024-08-26 | 2024-10-24 | A4840 SS | 265d | 0d | Operario [10.72 h]; Oficial [21.44 h]; Peon [35.06 h]; Peon - Vigia [0.03 h]; Operador equipo Pesado [0.05 h]; Operador equipo Liviano [7.56 h]; Cisterna 5000 gln [0.09 h]; Volquete 15 m3 [0.33 h]; Excavadora Cat 336 [0.05 h]; Retroexcavadora sobre llantas 94 hp [7.13 h]; Zaranda estatica [0.72 h]; Capataz [3.71 h]; Petroleo [19.57 gln]; ARENA GRUESA [3.1]; CEMENTO PORTLAND TIPO I (42.5 kg) [30.16]; Cost [400] |  |  | 25.65 | m2 |  | 0 |  |  | Interferencias | 60 |
| A4860 |  | Cama de arena e=0.20m | 50d | 2024-08-26 | 2024-10-24 | A4850 SS | 265d | 0d | Operario [2.36 h]; Oficial [4.71 h]; Peon [9.47 h]; Peon - Vigia [0.05 h]; Operador equipo Liviano [0.41 h]; Cisterna 5000 gln [0.17 h]; Volquete 22 m3 [0.25 h]; Capataz [0.47 h]; Petroleo [3.8 gln]; ARENA GRUESA [12.96]; Cost [400] |  |  | 58.93 | m2 |  | 0 |  |  | Interferencias | 60 |
| A4870 |  | Tubería HDPE Corrugada Ø=900mm (Suministro e instalación) | 50d | 2024-08-26 | 2024-10-24 | A4860 SS | 265d | 0d | Operario [8.54 h]; Oficial [17.07 h]; Peon [17.07 h]; Operador equipo Pesado [4.27 h]; Operador equipo Liviano [2.13 h]; Camion grua 20 ton [2.13 h]; Excavadora Cat 336 [4.27 h]; Capataz [8.54 h]; Petroleo [44.82 gln]; Tubería HDPE Corrugado de 900 mm [28.17]; Cost [400] |  |  | 25.61 | m |  | 0 |  |  | Interferencias | 60 |
| A4880 |  | Compuertas Charnela Ø900 (Suministro e instalacion) | 50d | 2024-08-26 | 2024-10-24 | A4870 SS | 265d | 0d | Operario [8 h]; Oficial [16 h]; Peon [32 h]; Operador equipo Liviano [6 h]; Camion grua 20 ton [6 h]; Capataz [4 h]; Petroleo [24 gln]; ANCLAJES [4]; Suministro de Compuerta tipo CHARNELA, D=900mm [1]; Cost [400] |  |  | 1 | und |  | 0 |  |  | Interferencias | 60 |
| A4890 |  | Compuerta metálica tipo tarjeta 1.00x1.00m (Suministro e instalacion) | 50d | 2024-08-26 | 2024-10-24 | A4880 SS | 265d | 0d | Operario [8 h]; Oficial [8 h]; Peon [8 h]; Operador equipo Liviano [1 h]; Camion grua 20 ton [1 h]; Capataz [2 h]; Petroleo [4 gln]; Suministro de Compuerta plana tipo tarjeta 1.00 x 1.00m [1]; Cost [400] |  |  | 1 | und |  | 0 |  |  | Interferencias | 60 |
| A4900 |  | Sello en juntas | 50d | 2024-08-26 | 2024-10-24 | A4890 SS | 265d | 0d | Operario [6.58 h]; Peon [1.65 h]; Capataz [1.65 h]; TECNOPOR DE 1/2"X4X8' [1.13]; SELLADOR ELASTICO POLIURETANO SIKAFLEX 1A [5.65]; Cost [400] |  |  | 19.75 | m |  | 0 |  |  | Interferencias | 60 |
| A4910 |  | Waterstop (anillos de estanqueidad) | 50d | 2024-08-26 | 2024-10-24 | A4900 SS | 265d | 0d | Operario [4 h]; Peon [8 h]; Capataz [0.4 h]; WATER STOP (anillos de estanqueidad); DN=900mm [3.64]; WATER STOP (anillos de estanqueidad); DN=1200mm [0.36]; Cost [400] |  |  | 4 | und |  | 0 |  |  | Interferencias | 60 |
| A4920 |  | Pintura bituminosa | 50d | 2024-08-26 | 2024-10-24 | A4910 SS | 265d | 0d | Operario [22.64 h]; Peon [45.28 h]; Capataz [2.26 h]; PINTURA ASFALTICA [45.28]; IMPRIMANTE ASFALTICO [19.81]; Cost [400] |  |  | 113.21 | m2 |  | 0 |  |  | Interferencias | 60 |
| A4930 |  | Relleno con material granular (incluye extracción de material, zarandeo y combinación de material) | 50d | 2024-08-26 | 2024-10-24 | A4920 SS | 265d | 0d | Peon [17 h]; Peon - Vigia [0.52 h]; Operador equipo Pesado [13.12 h]; Operador equipo Liviano [10.71 h]; Cisterna 5000 gln [1.79 h]; Volquete 15 m3 [2.6 h]; Cargador Frontal 966 [2.91 h]; Chancadora Primaria [1.94 h]; Excavadora Cat 336 [8.27 h]; Rodillo liso vibratorio 0.80 - 1.10 ton [6.33 h]; Tractor D6; Capataz [3.2 h]; Petroleo [122.25 gln]; Cost [400] |  |  | 126.64 | m3 |  | 0 |  |  | Interferencias | 60 |
| A4940 |  | Suministro e Instalación de geotextil | 50d | 2024-08-26 | 2024-10-24 | A4930 SS | 265d | 0d | Oficial [1.31 h]; Peon [1.96 h]; Operador equipo Liviano [0.16 h]; Camion grua 20 ton [0.16 h]; Capataz [0.13 h]; Petroleo [0.65 gln]; Geotextil no tejido 200gr/m2 [58.8]; Cost [400] |  |  | 49 | m2 |  | 0 |  |  | Interferencias | 60 |
| A4950 |  | Baranda metálica (suministro e instalación) | 50d | 2024-08-26 | 2024-10-24 | A4940 SS | 265d | 0d | Cost [400] |  |  | 1 | und |  | 0 |  |  | Interferencias | 60 |
| A4960 |  | Rejilla metálica de 2.2mx1.50m (Suministro e instalación) | 50d | 2024-08-26 | 2024-10-24 | A4950 SS | 265d | 0d | Operario [4 h]; Peon [16 h]; Operador equipo Liviano [2 h]; Camion grua 20 ton [2 h]; Capataz [0.4 h]; Petroleo [8 gln]; REJILLA METALICA 2.20x1.50m [1]; Cost [400] |  |  | 1 | und |  | 0 |  |  | Interferencias | 60 |

| ID | WBS | Activity | Type | Duration | Start | Finish | Predecessors | Total float | Free float | Resources | Metrado | Unidad | RCuad | AGrupo | Duracion | Cuadrilla | Rendimiento | Turno | DurCal | Dur. Cal. |
| --- | --- | --- | --- | --- | --- | --- | --- | --- | --- | --- | --- | --- | --- | --- | --- | --- | --- | --- | --- | --- |
|  | 7 | **ACCESOS** |  |  | 2024-10-25 | 2024-11-23 |  |  |  |  |  |  |  |  |  |  |  |  |  |  |
| A4970 |  | Concreto clase C (f'c=280 kg/cm2) en losa |  | 25d | 2024-10-25 | 2024-11-23 | A4960 | 265d | 0d | Operario [44.02 h]; Oficial [65.49 h]; Peon [176.07 h]; Operador equipo Liviano [22.55 h]; Carmix 4.0 m3 [22.55 h]; Capataz [16.37 h]; Petroleo [123.46 gln]; PIEDRA CHANCADA [36.64]; ARENA GRUESA [31]; CEMENTO PORTLAND TIPO I (42.5 kg) [591.82]; PLASTIMENT TM-40 - PLASTIFICANTE [121.18]; ADITIVO CURADOR DE CONCRETO [8.05]; Cost [200] | 53.68 | m3 | 0 | Accesos | 30 |  |  |  |  |  |
| A4980 |  | Encofrado y desencofrado pavimento rígido e=0.15m |  | 25d | 2024-10-25 | 2024-11-23 | A4970 SS | 265d | 0d | Operario [20 h]; Oficial [20 h]; Peon [40 h]; Capataz [20 h]; ALAMBRE NEGRO #8 [10]; CLAVOS PARA MADERA CON CABEZA [20]; DESMOLDANTE PARA MADERA [1.6]; MADERA TORNILLO INCLUYE CORTE PARA ENCOFRADO [100]; TRIPLAY DE 19 mm PARA ENCOFRADO [5]; Cost [200] | 200 | m | 0 | Accesos | 30 |  |  |  |  |  |
| A4990 |  | Junta en Pavimentos con Pasadores |  | 25d | 2024-10-25 | 2024-11-23 | A4980 SS | 265d | 0d | Operario [20.84 h]; Oficial [9.54 h]; Peon [32.14 h]; Capataz [4.16 h]; DOWELL LISO Ø 3/4", L=500, c/0.50m [350.02]; MATERIAL DE RESPALDO 1" PARA JUNTAS 20 mm [118.65]; SELLO ELASTOMETRICO A BASE DE SILICONA [5.42]; Cost [200] | 113 | m | 0 | Accesos | 30 |  |  |  |  |  |
| A5000 |  | Concreto Ciclopeo f'c=210 kg/cm2 + 30% PM |  | 25d | 2024-10-25 | 2024-11-23 | A4990 SS | 265d | 18d | Operario [3.1 h]; Oficial [3.68 h]; Peon [19.92 h]; Peon - Vigia [0 h]; Operador equipo Pesado [0 h]; Operador equipo Liviano [1.42 h]; Volquete 15 m3 [0.01 h]; Carmix 4.0 m3 [1.38 h]; Excavadora Cat 336 [0 h]; Retroexcavadora sobre llantas 94 hp [0.03 h]; Zaranda estatica [0.03 h]; Capataz [1.79 h]; Petroleo [7.01 gln]; PIEDRA CHANCADA [2.24]; ARENA GRUESA [1.9]; CEMENTO PORTLAND TIPO I (42.5 kg) [31.05]; PLASTIMENT TM-40 - PLASTIFICANTE [7.42]; Cost [200] | 4.6 | m3 | 0 | Accesos | 30 |  |  |  |  |  |
|  | 7 | **DE-PR-17BIS-D** |  |  | 2024-10-23 | 2024-12-04 |  |  |  |  |  |  |  |  |  |  |  |  |  |  |
| A2680 |  | Inicio - DE-PR-17BIS-D | milestone | 0d | 2024-10-23 | 2024-10-23 | A2090 | 0d |  |  |  |  | 0 |  | 0 |  |  |  |  |  |
| A2690 |  | Fin - DE-PR-17BIS-D | milestone | 0d | 2024-12-04 | 2024-12-04 | A2450 FF, A2460 FF, A2480 FF, A2570 FF, A2590 FF, A2610 FF, A2630 FF, A2650 FF, A2670 FF | 0d |  |  |  |  | 0 |  | 0 |  |  |  |  |  |
|  | 1 | **EXCAVACIONES** |  |  | 2024-10-23 | 2024-11-11 |  |  |  |  |  |  |  |  |  |  |  |  |  |  |
| A2410 |  | Desbroce |  | 10d | 2024-10-23 | 2024-11-04 | A2680 SS | 0d |  | Peon [8.8 h]; Operador equipo Pesado [6.6 h]; Excavadora Cat 336 [2.2 h]; Tractor D6 [4.4 h]; Capataz [0.04 h]; Petroleo [49.5 gln]; Cost [80] | 0.44 | ha | 1 | Excavacion | 13 | 1 | 0.8 | 1 | 0.44 | 0.55 |
| A2460 |  | Conformacion de Material Excedente en DMO |  | 10d | 2024-10-23 | 2024-11-04 | A2410 SS | 26d |  | Peon [10.05 h]; Operador equipo Pesado [11.1 h]; Excavadora Cat 336 [1.06 h]; Tractor D6 [10.05 h]; Capataz [1.06 h]; Petroleo [79.31 gln]; Cost [80] | 1321.89 | m3 | 1 | Excavacion | 13 | 1 | 1050 | 1 | 1321.89 | 1.25894285714286 |
| A2420 |  | Excavacion de Cimentacion |  | 10d | 2024-10-26 | 2024-11-07 | A2410 SS+3d | 0d |  | Peon [89.74 h]; Operador equipo Pesado [59.83 h]; Operador equipo Liviano [49.86 h]; Excavadora Cat 336 [39.89 h]; Retroexcavadora sobre llantas 94 hp [49.86 h]; Tractor D8 [19.94 h]; Capataz [8.97 h]; Petroleo [652.15 gln]; Cost [80] | 4985.82 | m3 | 0.5 | Excavacion | 13 | 0.5 | 880 | 1 | 9971.64 | 11.3314090909091 |
| A2440 |  | Excavacion de Uña |  | 10d | 2024-10-26 | 2024-11-07 | A2420 SS | 0d |  | Peon [35.97 h]; Operador equipo Pesado [35.97 h]; Excavadora Cat 336 [35.97 h]; Capataz [7.19 h]; Petroleo [406.41 gln]; Cost [80] | 2247.85 | m3 | 0.5 | Excavacion | 13 | 0.5 | 500 | 1 | 4495.7 | 8.9914 |
| A2450 |  | Conformacion de Material Excedente en DME |  | 10d | 2024-10-26 | 2024-11-07 | A2420 SS | 23d |  | Peon [53.91 h]; Operador equipo Pesado [59.59 h]; Excavadora Cat 336 [5.68 h]; Tractor D6 [53.91 h]; Capataz [5.68 h]; Petroleo [425.64 gln]; Cost [80] | 7093.98 | m3 | 1 | Excavacion | 13 | 1 | 1050 | 1 | 7093.98 | 6.75617142857143 |
| A3840 |  | Excavacion Localizada - Sobreexcavacion |  | 10d | 2024-10-26 | 2024-11-07 | A2440 SS | 8d |  | Peon [0.82 h]; Operador equipo Pesado [0.82 h]; Excavadora Cat 336 [0.82 h]; Capataz [0.16 h]; Petroleo [6.96 gln]; Cost [80] | 24.6 | m3 | 0.5 | Excavacion | 13 | 0.5 | 240 | 1 | 49.2 | 0.205 |
| A2430 |  | Perfilado y Conformacion de Plataforma de Fundacion |  | 3d | 2024-11-08 | 2024-11-11 | A2420 | 5d |  | Peon [12.14 h]; Operador equipo Pesado [21.65 h]; Operador equipo Liviano [4.59 h]; Cisterna 5000 gln [4.59 h]; Motoniveladora 140K [10.83 h]; Rodillo liso vibratorio 10 - 12 ton [10.83 h]; Capataz [0.98 h]; Petroleo [93.17 gln]; Cost [24] | 3280.71 | m2 | 0.5 | Excavacion | 4 | 0.5 | 2400 | 1 | 6561.42 | 2.733925 |
|  | 2 | **RELLENOS** |  |  | 2024-11-18 | 2024-12-04 |  |  |  |  |  |  |  |  |  |  |  |  |  |  |
| A2470 |  | Relleno con Material Granular (incluye extraccion de material, zarandeo y combinado) |  | 1d | 2024-11-18 | 2024-11-18 | A2430, A2540, A3840 | 0d |  | Operario [4.3 h]; Oficial [12.52 h]; Peon [41.32 h]; Peon - Vigia [2.18 h]; Operador equipo Pesado [58.44 h]; Operador equipo Liviano [27.77 h]; Cisterna 5000 gln [12.52 h]; Volquete 15 m3 [10.83 h]; Cargador Frontal 966 [17.36 h]; Chancadora Primaria [8.17 h]; Excavadora Cat 336 [12.34 h]; Retroexcavadora sobre llantas 58 hp [2.18 h]; Rodillo liso vibratorio 10 - 12 ton [8.23 h]; Rodillo liso vibratorio 0.80 - 1.10 ton [4.3 h]; Tractor D6 [10.35 h]; Capataz [14.88 h]; Petroleo [468.45 gln]; Cost [8] | 605 | m3 | 1 | Relleno | 1 | 1 | 560 | 1 | 605 | 1.08035714285714 |
| A2500 |  | Perfilado de Talud Dique |  | 1d | 2024-11-19 | 2024-11-19 | A2470 | 0d |  | Peon [5.78 h]; Operador equipo Pesado [1.72 h]; Excavadora Cat 336 [1.72 h]; Capataz [1.17 h]; Petroleo [14.66 gln]; Cost [8] | 507.21 | m2 | 1 | Relleno | 1 | 1 | 700 | 1 | 507.21 | 0.724585714285714 |
| A2700 |  | Grava para Drenaje |  | 1d | 2024-11-19 | 2024-11-19 | A2470 | 0d |  | Peon [3.37 h]; Peon - Vigia [0.11 h]; Operador equipo Pesado [1.38 h]; Operador equipo Liviano [3.1 h]; Volquete 15 m3 [0.53 h]; Cargador Frontal 966 [0.59 h]; Chancadora Primaria [0.39 h]; Excavadora Cat 336 [0.39 h]; Retroexcavadora sobre llantas 94 hp [2.58 h]; Tractor D6; Capataz [1.04 h]; Petroleo [17.62 gln]; Cost [8] | 25.76 | m3 | 1 | Relleno | 1 | 1 | 80 | 1 | 25.76 | 0.322 |
| A2480 |  | Relleno sin Compactar |  | 1d | 2024-12-03 | 2024-12-03 | A2550 FF | 1d |  | Oficial [1.56 h]; Peon [1.56 h]; Operador equipo Pesado [1.56 h]; Tractor D6 [1.56 h]; Capataz [0.32 h]; Petroleo [10.93 gln]; Cost [8] | 175.44 | m3 | 1 | Relleno | 1 | 1 | 900 | 1 | 175.44 | 0.194933333333333 |
| A2490 |  | Relleno Afirmado |  | 1d | 2024-12-04 | 2024-12-04 | A2550 | 0d |  | Oficial [4.13 h]; Peon [12.99 h]; Peon - Vigia [1.39 h]; Operador equipo Pesado [23.81 h]; Operador equipo Liviano [8.78 h]; Cisterna 5000 gln [1.89 h]; Volquete 15 m3 [6.89 h]; Cargador Frontal 966 [2.93 h]; Chancadora LT200 [2.93 h]; Excavadora Cat 336 [5.48 h]; Motoniveladora 140K [4.13 h]; Rodillo liso vibratorio 10 - 12 ton [4.13 h]; Tractor D6 [1.29 h]; Zaranda Metso ST 4.8 168 HP [2.93 h]; Capataz [5.03 h]; Petroleo [167.7 gln]; CANON POR EXTRACCION CANTERA [175.56]; Cost [8] | 167.2 | m3 | 1 | Relleno | 1 | 1 | 324 | 1 | 167.2 | 0.516049382716049 |
|  | 3 | **GEOTEXTIL** |  |  | 2024-10-31 | 2024-12-03 |  |  |  |  |  |  |  |  |  |  |  |  |  |  |
| A2510 |  | Instalacion de Geotextil 400gr/m2 |  | 28d | 2024-10-31 | 2024-12-03 | A2440 SS+4d | 1d | 0d | Oficial [135.51 h]; Peon [203 h]; Operador equipo Liviano [16.75 h]; Camion grua 20 ton [16.75 h]; Capataz [13.7 h]; Petroleo [66.99 gln]; Geotextil no tejido 200gr/m2 [5836.36]; Cost [224] | 5075.1 | m2 | 1 | Geotextil | 34 | 1 | 600 | 1 | 5075.1 | 8.4585 |
| A2520 |  | Zanja de Anclaje |  | 2d | 2024-12-02 | 2024-12-03 | A2510 FF | 1d | 0d | Oficial [2.79 h]; Peon [8.38 h]; Operador equipo Pesado [2.79 h]; Operador equipo Liviano [0.08 h]; Cisterna 5000 gln [0.08 h]; Retroexcavadora sobre llantas 58 hp [2.79 h]; Capataz [0.56 h]; Petroleo [9.93 gln]; Cost [16] | 11.15 | m3 | 1 | Geotextil | 2 | 1 | 32 | 1 | 11.15 | 0.3484375 |

| ID | WBS | Activity | Type | Duration | Start | Finish | Predecessors | Total float | Free float | Resources | Cuadrilla | Unidad | Turno | RCuad | DurCal | AGrupo | Duracion | Rendimiento | Metrado | Dur. Cal. |
| --- | --- | --- | --- | --- | --- | --- | --- | --- | --- | --- | --- | --- | --- | --- | --- | --- | --- | --- | --- | --- |
|  | 4 | **COLOCACION DE ROCA** |  |  | 2024-11-08 | 2024-12-03 |  |  |  |  |  |  |  |  |  |  |  |  |  |  |
| A2530 |  | Suministro de roca |  | 22d | 2024-11-08 | 2024-12-03 | A2540 SS | 1d | 0d | Cost [176] | 1 | ton | 1 | 1 | 0 | Roca | 26 |  |  |  |
| A2540 |  | Colocacion de Roca en Uña |  | 8d | 2024-11-08 | 2024-11-16 | A2440, A2510 SS+1d | 0d |  | Oficial [63.79 h]; Peon [63.79 h]; Operador equipo Pesado [70.25 h]; Excavadora Cat 336 [63.79 h]; Tractor D6 [6.47 h]; Capataz [31.89 h]; Petroleo [587.46 gln]; Roca [2230.28 m3]; Cost [64] | 1 | m3 | 1 | 1 | 2230.28 | Roca | 9 | 280 | 2230.28 | 7.96528571428572 |
| A2550 |  | Colocacion de Roca en Talud |  | 12d | 2024-11-20 | 2024-12-03 | A2540, A2510 SS, A2500, A2700 | 0d |  | Oficial [93.93 h]; Peon [93.93 h]; Operador equipo Pesado [197.09 h]; Excavadora Cat 336 [187.63 h]; Tractor D6 [9.46 h]; Capataz [46.85 h]; Petroleo [1661.17 gln]; Roca [2252.43 m3]; Cost [96] | 1 | m3 | 1 | 1 | 2252.43 | Roca | 14 | 192 | 2252.43 | 11.73140625 |
|  | 5 | **TRANSPORTES** |  |  | 2024-10-23 | 2024-12-04 |  |  |  |  |  |  |  |  |  |  |  |  |  |  |
| A2560 |  | Transporte de Material Organico (a DMO) D<=1km |  | 10d | 2024-10-23 | 2024-11-04 | A2410 SS | 26d | 0d | Peon - Vigia [7.4 h]; Operador equipo Liviano [36.75 h]; Volquete 15 m3 [36.75 h]; Petroleo [102.84 gln]; Cost [80] | 1 | m3k | 1 | 1 | 1321.89 | Transportes | 13 |  | 1321.89 |  |
| A2570 |  | Transporte de Material Organico (a DMO) D>1km |  | 10d | 2024-10-23 | 2024-11-04 | A2560 SS | 26d |  | Operador equipo Liviano [142.59 h]; Volquete 15 m3 [142.59 h]; Petroleo [399.26 gln]; Cost [80] | 1 | m3k | 1 | 1 | 12963.02 | Transportes | 13 |  | 12963.02 |  |
| A2580 |  | Transporte de Material Excedente D<=1km |  | 10d | 2024-10-26 | 2024-11-07 | A2420 SS | 23d | 0d | Peon - Vigia [36.18 h]; Operador equipo Liviano [180.19 h]; Volquete 22 m3 [77.32 h]; Volquete 15 m3 [102.86 h]; Petroleo [603.7 gln]; Cost [80] | 1 | m3k | 1 | 1 | 7093.98 | Transportes | 13 |  | 7093.98 |  |
| A2590 |  | Transporte de Material Excedente D>1km |  | 10d | 2024-10-26 | 2024-11-07 | A2580 SS | 23d |  | Operador equipo Liviano [702.79 h]; Volquete 22 m3 [299.21 h]; Volquete 15 m3 [403.58 h]; Petroleo [2351.91 gln]; Cost [80] | 1 | m3k | 1 | 1 | 69583.14 | Transportes | 13 |  | 69583.14 |  |
| A2620 |  | Transporte de Roca D<=1km |  | 22d | 2024-11-08 | 2024-12-03 | A2530 SS | 1d | 0d | Peon [56.03 h]; Peon - Vigia [26.9 h]; Operador equipo Pesado [56.03 h]; Operador equipo Liviano [134.48 h]; Volquete 22 m3 [134.48 h]; Excavadora Cat 336 [56.03 h]; Petroleo [1009.51 gln]; Peaje local [203.96]; Cost [176] | 1 | m3k | 1 | 1 | 4482.71 | Transportes | 26 |  | 4482.71 |  |
| A2630 |  | Transporte de Roca D>1km |  | 22d | 2024-11-08 | 2024-12-03 | A2620 SS | 1d |  | Operador equipo Liviano [736.71 h]; Volquete 22 m3 [736.71 h]; Petroleo [2933.08 gln]; Cost [176] | 1 | m3k | 1 | 1 | 68851.73 | Transportes | 26 |  | 68851.73 |  |
| A2640 |  | Transporte de Material de Prestamo Cantera de Rio (Cuerpo de Terraplen) D<=1km |  | 1d | 2024-11-18 | 2024-11-18 | A2470 SS | 14d | 0d | Peon - Vigia [2.54 h]; Operador equipo Liviano [12.64 h]; Volquete 22 m3 [12.64 h]; Petroleo [51.85 gln]; Cost [8] | 1 | m3k | 1 | 1 | 605 | Transportes | 1 |  | 605 |  |
| A2650 |  | Transporte de Material de Prestamo Cantera de Rio (Cuerpo de Terraplen) D>1km |  | 1d | 2024-11-18 | 2024-11-18 | A2640 SS | 14d |  | Operador equipo Liviano [70.33 h]; Volquete 22 m3 [70.33 h]; Petroleo [288.08 gln]; Cost [8] | 1 | m3k | 1 | 1 | 8472.98 | Transportes | 1 |  | 8472.98 |  |
| A2660 |  | Transporte de Material Seleccionado para Zanja D<=1km |  | 2d | 2024-12-02 | 2024-12-03 | A2520 SS | 1d | 0d | Peon - Vigia [0.06 h]; Operador equipo Liviano [0.31 h]; Volquete 15 m3 [0.31 h]; Petroleo [0.87 gln]; Cost [16] | 1 | m3k | 1 | 1 | 11.15 | Transportes | 2 |  | 11.15 |  |
| A2670 |  | Transporte de Material Seleccionado para Zanja D>1km |  | 2d | 2024-12-02 | 2024-12-03 | A2660 SS | 1d |  | Operador equipo Liviano [1.72 h]; Volquete 15 m3 [1.72 h]; Petroleo [4.81 gln]; Cost [16] | 1 | m3k | 1 | 1 | 156.06 | Transportes | 2 |  | 156.06 |  |
| A2600 |  | Transporte de Material de Prestamo (Afirmado) D<=1km |  | 2d | 2024-12-03 | 2024-12-04 | A2490 FF | 0d |  | Peon - Vigia [2.1 h]; Operador equipo Liviano [10.47 h]; Volquete 22 m3 [10.47 h]; Petroleo [42.94 gln]; Cost [16] | 1 | m3k | 1 | 1 | 501.03 | Transportes | 2 |  | 501.03 |  |
| A2610 |  | Transporte de Material de Prestamo (Afirmado) D>1km |  | 2d | 2024-12-03 | 2024-12-04 | A2600 SS | 0d |  | Operador equipo Liviano [59.01 h]; Volquete 22 m3 [59.01 h]; Petroleo [241.72 gln]; Cost [16] | 1 | m3k | 1 | 1 | 7109.36 | Transportes | 2 |  | 7109.36 |  |
|  | 9 | **DE-PR-22-D** |  |  | 2025-05-02 | 2025-10-04 |  |  |  |  |  |  |  |  |  |  |  |  |  |  |
| A3370 |  | Inicio - DE-PR-21-D | milestone | 0d | 2025-05-02 | 2025-05-02 | A3710 SS+9d | 7d | 0d |  |  |  |  | 0 |  |  | 0 |  |  |  |
| A3380 |  | Fin - DE-PR-21-D | milestone | 0d | 2025-10-04 | 2025-10-04 | A3100 FF, A3110 FF, A3120 FF, A3140 FF, A3160 FF, A3180 FF, A3260 FF, A3280 FF, A3300 FF, A3320 FF, A3340 FF, A3360 FF, A5590 FF | 7d |  |  |  |  |  | 0 |  |  | 0 |  |  |  |
|  | 1 | **EXCAVACIONES** |  |  | 2025-05-02 | 2025-07-17 |  |  |  |  |  |  |  |  |  |  |  |  |  |  |
| A3050 |  | Desbroce |  | 50d | 2025-05-02 | 2025-06-30 | A3370 SS | 7d | 0d | Peon [38.6 h]; Operador equipo Pesado [28.95 h]; Excavadora Cat 336 [9.65 h]; Tractor D6 [19.3 h]; Capataz [0.19 h]; Petroleo [217.12 gln]; Cost [400] | 1 | ha | 1 | 1 | 1.93 | Excavacion | 60 | 0.8 | 1.93 | 2.4125 |
| A3110 |  | Conformacion de Material Excedente en DMO |  | 50d | 2025-05-02 | 2025-06-30 | A3050 SS | 85d | 78d | Peon [48.43 h]; Operador equipo Pesado [53.53 h]; Excavadora Cat 336 [5.1 h]; Tractor D6 [48.43 h]; Capataz [5.1 h]; Petroleo [382.32 gln]; Cost [400] | 1 | m3 | 1 | 1 | 6372.08 | Excavacion | 60 | 1050 | 6372.08 | 6.06864761904762 |
| A3060 |  | Remocion de Dique Existente |  | 56d | 2025-05-05 | 2025-07-09 | A3050 SS+2d | 7d | 0d | Peon [114.91 h]; Operador equipo Pesado [172.37 h]; Excavadora Cat 336 [114.91 h]; Tractor D8 [57.46 h]; Capataz [22.98 h]; Petroleo [1522.57 gln]; Cost [448] | 0.5 | m3 | 1 | 0.5 | 22982.22 | Excavacion | 66 | 800 | 11491.11 | 28.727775 |
| A3070 |  | Excavacion de Cimentacion |  | 56d | 2025-05-05 | 2025-07-09 | A3060 SS | 7d | 0d | Peon [685.41 h]; Operador equipo Pesado [456.94 h]; Operador equipo Liviano [380.78 h]; Excavadora Cat 336 [304.63 h]; Retroexcavadora sobre llantas 94 hp [380.78 h]; Tractor D8 [152.31 h]; Capataz [68.54 h]; Petroleo [4980.63 gln]; Cost [448] | 0.5 | m3 | 1 | 0.5 | 76156.44 | Excavacion | 66 | 880 | 38078.22 | 86.5414090909091 |
| A3090 |  | Excavacion de Uña |  | 56d | 2025-05-05 | 2025-07-09 | A3070 SS | 7d | 0d | Peon [157.35 h]; Operador equipo Pesado [157.35 h]; Excavadora Cat 336 [157.35 h]; Capataz [31.47 h]; Petroleo [1778.01 gln]; Cost [448] | 0.5 | m3 | 1 | 0.5 | 19668.2 | Excavacion | 66 | 500 | 9834.1 | 39.3364 |
| A3100 |  | Conformacion de Material Excedente en DME |  | 56d | 2025-05-05 | 2025-07-09 | A3060 SS | 77d | 70d | Peon [410.6 h]; Operador equipo Pesado [453.82 h]; Excavadora Cat 336 [43.22 h]; Tractor D6 [410.6 h]; Capataz [43.22 h]; Petroleo [3241.56 gln]; Cost [448] | 1 | m3 | 1 | 1 | 54026 | Excavacion | 66 | 1050 | 54026 | 51.4533333333333 |
| A3120 |  | Excavacion Localizada - Sobreexcavacion |  | 56d | 2025-05-05 | 2025-07-09 | A3090 SS | 77d | 70d | Peon [270.16 h]; Operador equipo Pesado [270.16 h]; Excavadora Cat 336 [270.16 h]; Capataz [54.36 h]; Petroleo [2296.8 gln]; Cost [448] | 0.5 | m3 | 1 | 0.5 | 16226.1 | Excavacion | 66 | 240 | 8113.05 | 67.60875 |
| A3080 |  | Perfilado y Conformacion de Plataforma de Fundacion |  | 30d | 2025-06-13 | 2025-07-17 | A3070 SS+33d | 18d | 0d | Peon [80.24 h]; Operador equipo Pesado [143.14 h]; Operador equipo Liviano [30.36 h]; Cisterna 5000 gln [30.36 h]; Motoniveladora 140K [71.57 h]; Rodillo liso vibratorio 10 - 12 ton [71.57 h]; Capataz [6.51 h]; Petroleo [615.93 gln]; Cost [240] | 0.3 | m2 | 1 | 0.3 | 72291.7 | Excavacion | 35 | 2400 | 21687.51 | 30.1215416666667 |

| ID | WBS | Activity | Duration | Start | Finish | Predecessors | Total float | Free float | Resources | Cuadrilla | Rendimiento | Metrado | Unidad | Turno | RCuad | DurCal | Dur. Cal. | AGrupo | Duracion |
| --- | --- | --- | --- | --- | --- | --- | --- | --- | --- | --- | --- | --- | --- | --- | --- | --- | --- | --- | --- |
|  | 2 | **RELLENOS** |  | 2025-06-21 | 2025-10-04 |  |  |  |  |  |  |  |  |  |  |  |  |  |  |
| A3130 |  | Relleno con Material Granular (incluye extraccion de material, zarandeo y combinado) | 36d | 2025-06-21 | 2025-08-05 | A3080 SS+7d | 18d | 0d | Operario [91.47 h]; Oficial [266.68 h]; Peon [879.91 h]; Peon - Vigia [46.38 h]; Operador equipo Pesado [1244.5 h]; Operador equipo Liviano [591.33 h]; Cisterna 5000 gln [266.68 h]; Volquete 15 m3 [230.61 h]; Cargador Frontal 966 [369.74 h]; Chancadora Primaria [173.92 h]; Excavadora Cat 336 [262.81 h]; Retroexcavadora sobre llantas 58 hp [46.38 h]; Rodillo liso vibratorio 10 - 12 ton [175.21 h]; Rodillo liso vibratorio 0.80 - 1.10 ton [91.47 h]; Tractor D6 [220.3 h]; Capataz [316.92 h]; Petroleo [9975.32 gln]; Cost [288] | 1 | 560 | 12883.02 | m3 | 1 | 1 | 12883.02 | 23.0053928571429 | Relleno | 46 |
| A3170 |  | Relleno con Material Seleccionado (incluye extraccion de material, zarandeo y combinado) | 36d | 2025-06-21 | 2025-08-05 | A3130 SS | 58d | 0d | Oficial [270.16 h]; Peon [554.93 h]; Operador equipo Pesado [810.49 h]; Operador equipo Liviano [56.79 h]; Cisterna 5000 gln [56.79 h]; Excavadora Cat 336 [540.33 h]; Rodillo liso vibratorio 10 - 12 ton [270.16 h]; Capataz [54.36 h]; Petroleo [8262.33 gln]; Cost [288] | 1 | 240 | 8113.05 | m3 | 1 | 1 | 8113.05 | 33.804375 | Relleno | 46 |
| A3160 |  | Perfilado de Talud Dique | 30d | 2025-06-30 | 2025-08-07 | A3130 SS+7d | 56d | 49d | Peon [91.86 h]; Operador equipo Pesado [27.4 h]; Excavadora Cat 336 [27.4 h]; Capataz [18.53 h]; Petroleo [232.88 gln]; Cost [240] | 1 | 700 | 8058.28 | m2 | 1 | 1 | 8058.28 | 11.5118285714286 | Relleno | 39 |
| A3180 |  | Grava para Drenaje | 22d | 2025-07-03 | 2025-07-31 | A3170 SS+10d | 61d | 54d | Peon [108.3 h]; Peon - Vigia [3.4 h]; Operador equipo Pesado [44.41 h]; Operador equipo Liviano [99.85 h]; Volquete 15 m3 [16.99 h]; Cargador Frontal 966 [19.06 h]; Chancadora Primaria [12.68 h]; Excavadora Cat 336 [12.68 h]; Retroexcavadora sobre llantas 94 hp [82.86 h]; Tractor D6; Capataz [33.39 h]; Petroleo [566.68 gln]; Cost [176] | 1 | 80 | 828.6 | m3 | 1 | 1 | 828.6 | 10.3575 | Relleno | 29 |
| A3140 |  | Relleno sin Compactar | 6d | 2025-09-25 | 2025-10-01 | A3230 FF | 10d | 3d | Oficial [42.14 h]; Peon [42.14 h]; Operador equipo Pesado [42.14 h]; Tractor D6 [42.14 h]; Capataz [8.52 h]; Petroleo [295 gln]; Cost [48] | 1 | 900 | 4735.1 | m3 | 1 | 1 | 4735.1 | 5.26122222222222 | Relleno | 7 |
| A3150 |  | Relleno Afirmado | 3d | 2025-10-02 | 2025-10-04 | A3230 | 7d | 0d | Oficial [20.23 h]; Peon [63.65 h]; Peon - Vigia [6.8 h]; Operador equipo Pesado [116.64 h]; Operador equipo Liviano [43 h]; Cisterna 5000 gln [9.26 h]; Volquete 15 m3 [33.75 h]; Cargador Frontal 966 [14.33 h]; Chancadora LT200 [14.33 h]; Excavadora Cat 336 [26.87 h]; Motoniveladora 140K [20.23 h]; Rodillo liso vibratorio 10 - 12 ton [20.23 h]; Tractor D6 [6.31 h]; Zaranda Metso ST 4.8 168 HP [14.33 h]; Capataz [24.66 h]; Petroleo [821.59 gln]; CANON POR EXTRACCION CANTERA [860.09]; Cost [24] | 1 | 324 | 819.13 | m3 | 1 | 1 | 819.13 | 2.52817901234568 | Relleno | 3 |
|  | 3 | **GEOTEXTIL** |  | 2025-06-10 | 2025-08-22 |  |  |  |  |  |  |  |  |  |  |  |  |  |  |
| A3190 |  | Instalacion de Geotextil 400gr/m2 | 60d | 2025-06-10 | 2025-08-22 | A3090 SS+30d | 7d | 0d | Oficial [639.47 h]; Peon [958.01 h]; Operador equipo Liviano [79.04 h]; Camion grua 20 ton [79.04 h]; Capataz [64.67 h]; Petroleo [316.14 gln]; Geotextil no tejido 200gr/m2 [27542.9]; Cost [480] | 1 | 600 | 23950.32 | m2 | 1 | 1 | 23950.32 | 39.9172 | Geotextil | 74 |
| A3200 |  | Zanja de Anclaje | 10d | 2025-08-12 | 2025-08-22 | A3190 FF | 43d | 0d | Oficial [38.77 h]; Peon [116.59 h]; Operador equipo Pesado [38.77 h]; Operador equipo Liviano [1.09 h]; Cisterna 5000 gln [1.09 h]; Retroexcavadora sobre llantas 58 hp [38.77 h]; Capataz [7.75 h]; Petroleo [138.13 gln]; Cost [80] | 1 | 32 | 155.08 | m3 | 1 | 1 | 155.08 | 4.84625 | Geotextil | 11 |
|  | 4 | **COLOCACION DE ROCA** |  | 2025-05-05 | 2025-10-01 |  |  |  |  |  |  |  |  |  |  |  |  |  |  |
| A3240 |  | Extraccion de Rocas Reutilizables | 56d | 2025-05-05 | 2025-07-09 | A3060 SS | 17d | 10d | Peon [631.86 h]; Operador equipo Pesado [631.86 h]; Excavadora Cat 336 [631.86 h]; Capataz [316.21 h]; Petroleo [5371.06 gln]; Cost [448] | 1 | 144 | 5616.5 | m3 | 1 | 1 | 5616.5 | 39.0034722222222 | Roca | 66 |
| A3210 |  | Suministro de roca | 92d | 2025-06-11 | 2025-10-01 | A3220 SS | 10d | 0d | Cost [736] | 1 |  |  | ton | 1 | 1 | 0 |  | Roca | 113 |
| A3220 |  | Colocacion de Roca en Uña | 35d | 2025-06-11 | 2025-07-21 | A3090 SS+7d, A3190 SS+1d | 7d | 0d | Oficial [280.95 h]; Peon [280.95 h]; Operador equipo Pesado [309.44 h]; Excavadora Cat 336 [280.95 h]; Tractor D6 [28.49 h]; Capataz [140.48 h]; Petroleo [2587.52 gln]; Roca [9823.55 m3]; Cost [280] | 1 | 280 | 9823.55 | m3 | 1 | 1 | 9823.55 | 35.0841071428571 | Roca | 41 |
| A3230 |  | Colocacion de Roca en Talud | 57d | 2025-07-22 | 2025-10-01 | A3190 SS, A3130 SS+15d, A3220, A3240 | 7d | 0d | Oficial [456.34 h]; Peon [456.34 h]; Operador equipo Pesado [957.54 h]; Excavadora Cat 336 [911.58 h]; Tractor D6 [45.96 h]; Capataz [227.62 h]; Petroleo [8070.71 gln]; Roca [10943.3 m3]; Cost [456] | 1 | 192 | 10943.33 | m3 | 1 | 1 | 10943.33 | 56.9965104166667 | Roca | 72 |
|  | 5 | **TRANSPORTES** |  | 2025-05-02 | 2025-10-04 |  |  |  |  |  |  |  |  |  |  |  |  |  |  |
| A3250 |  | Transporte de Material Organico (a DMO) D<=1km | 50d | 2025-05-02 | 2025-06-30 | A3050 SS | 85d | 0d | Peon - Vigia [35.68 h]; Operador equipo Liviano [177.14 h]; Volquete 15 m3 [177.14 h]; Petroleo [495.75 gln]; Cost [400] | 1 |  | 6372.08 | m3k | 1 | 1 | 6372.08 |  | Transportes | 60 |
| A3260 |  | Transporte de Material Organico (a DMO) D>1km | 50d | 2025-05-02 | 2025-06-30 | A3250 SS | 85d | 78d | Operador equipo Liviano [539.61 h]; Volquete 15 m3 [539.61 h]; Petroleo [1510.91 gln]; Cost [400] | 1 |  | 49055.47 | m3k | 1 | 1 | 49055.47 |  | Transportes | 60 |
| A3270 |  | Transporte de Material Excedente D<=1km | 56d | 2025-05-05 | 2025-07-09 | A3060 SS | 77d | 0d | Peon - Vigia [275.53 h]; Operador equipo Liviano [1372.26 h]; Volquete 22 m3 [588.88 h]; Volquete 15 m3 [783.38 h]; Petroleo [4597.61 gln]; Cost [448] | 1 |  | 54026 | m3k | 1 | 1 | 54026 |  | Transportes | 66 |
| A3280 |  | Transporte de Material Excedente D>1km | 56d | 2025-05-05 | 2025-07-09 | A3270 SS | 77d | 70d | Operador equipo Liviano [4278.33 h]; Volquete 22 m3 [1821.47 h]; Volquete 15 m3 [2456.86 h]; Petroleo [14317.6 gln]; Cost [448] | 1 |  | 423596.81 | m3k | 1 | 1 | 423596.81 |  | Transportes | 66 |
| A3310 |  | Transporte de Roca D<=1km | 92d | 2025-06-11 | 2025-10-01 | A3210 SS | 10d | 0d | Peon [259.72 h]; Peon - Vigia [124.67 h]; Operador equipo Pesado [259.72 h]; Operador equipo Liviano [623.34 h]; Volquete 22 m3 [623.34 h]; Excavadora Cat 336 [259.72 h]; Petroleo [4679.17 gln]; Peaje local [945.39]; Cost [736] | 1 |  | 2077.86 | m3k | 1 | 1 | 2077.86 |  | Transportes | 113 |
| A3320 |  | Transporte de Roca D>1km | 92d | 2025-06-11 | 2025-10-01 | A3310 SS | 10d | 3d | Operador equipo Liviano [1736.92 h]; Volquete 22 m3 [1736.92 h]; Petroleo [6915.22 gln]; Cost [736] | 1 |  | 162329.17 | m3k | 1 | 1 | 162329.17 |  | Transportes | 113 |
| A3330 |  | Transporte de Material de Prestamo Cantera de Rio (Cuerpo de Terraplen) D<=1km | 36d | 2025-06-21 | 2025-08-05 | A3130 SS | 57d | 0d | Peon - Vigia [110.39 h]; Operador equipo Liviano [549.32 h]; Volquete 22 m3 [549.32 h]; Petroleo [2252.47 gln]; Cost [288] | 1 |  | 26283.21 | m3k | 1 | 1 | 26283.21 |  | Transportes | 46 |
| A3340 |  | Transporte de Material de Prestamo Cantera de Rio (Cuerpo de Terraplen) D>1km | 36d | 2025-06-21 | 2025-08-05 | A3330 SS | 57d | 50d | Operador equipo Liviano [607.43 h]; Volquete 22 m3 [607.43 h]; Petroleo [2488.27 gln]; Cost [288] | 1 |  | 73184.34 | m3k | 1 | 1 | 73184.34 |  | Transportes | 46 |
| A3350 |  | Transporte de Material Seleccionado para Zanja D<=1km | 10d | 2025-08-12 | 2025-08-22 | A3200 SS | 43d | 0d | Peon - Vigia [0.87 h]; Operador equipo Liviano [4.31 h]; Volquete 15 m3 [4.31 h]; Petroleo [12.07 gln]; Cost [80] | 1 |  | 155.08 | m3k | 1 | 1 | 155.08 |  | Transportes | 11 |
| A3360 |  | Transporte de Material Seleccionado para Zanja D>1km | 10d | 2025-08-12 | 2025-08-22 | A3350 SS | 43d | 36d | Operador equipo Liviano [4.7 h]; Volquete 15 m3 [4.7 h]; Petroleo [13.15 gln]; Cost [80] | 1 |  | 427.09 | m3k | 1 | 1 | 427.09 |  | Transportes | 11 |
| A3290 |  | Transporte de Material de Prestamo (Afirmado) D<=1km | 9d | 2025-09-25 | 2025-10-04 | A3150 FF | 7d | 0d | Peon - Vigia [52.28 h]; Operador equipo Liviano [260.16 h]; Volquete 22 m3 [260.16 h]; Petroleo [1066.78 gln]; Cost [72] | 1 |  | 12447.8 | m3k | 1 | 1 | 12447.8 |  | Transportes | 10 |
| A3300 |  | Transporte de Material de Prestamo (Afirmado) D>1km | 9d | 2025-09-25 | 2025-10-04 | A3290 SS | 7d | 0d | Operador equipo Liviano [1262.23 h]; Volquete 22 m3 [1262.23 h]; Petroleo [5170.59 gln]; Cost [72] | 1 |  | 152076.25 | m3k | 1 | 1 | 152076.25 |  | Transportes | 10 |

| ID | WBS | Activity | Duration | Start | Finish | Predecessors | Total float | Free float | Resources | Metrado | Unidad | RCuad | AGrupo | Duracion |
| --- | --- | --- | --- | --- | --- | --- | --- | --- | --- | --- | --- | --- | --- | --- |
|  | 6 | **INTERFERENCIAS** |  | 2025-05-26 | 2025-07-11 |  |  |  |  |  |  |  |  |  |
| A5340 |  | Trazo y replanteo de interferencia | 40d | 2025-05-26 | 2025-07-11 | A3370 SS+20d | 75d | 0d | Peon [34.83 h]; Topografo [17.41 h]; GPS [17.41 h]; Capataz [1.74 h]; MADERA TORNILLO [17.41]; PINTURA ESMALTE [1.74]; Cost [320] | 870.74 | m2 | 0 | Interferencias | 47 |
| A5350 |  | Desvío provisional con tubería | 40d | 2025-05-26 | 2025-07-11 | A5340 SS | 75d | 0d | Operario [13.51 h]; Oficial [13.51 h]; Peon [86.48 h]; Operador equipo Pesado [5.4 h]; Operador equipo Liviano [3.38 h]; Camion grua 20 ton [3.38 h]; Excavadora Cat 336 [5.4 h]; Capataz [7.84 h]; Petroleo [59.44 gln]; TUBERIA CORRUGADA HDPE D=630 mm [42.57]; Cost [320] | 40.54 | m | 0 | Interferencias | 47 |
| A5360 |  | Desvío provisional en tierras | 40d | 2025-05-26 | 2025-07-11 | A5350 SS | 75d | 0d | Peon [38.66 h]; Operador equipo Pesado [38.66 h]; Excavadora Cat 336 [38.66 h]; Capataz [7.74 h]; Petroleo [328.6 gln]; Cost [320] | 290 | m | 0 | Interferencias | 47 |
| A5370 |  | Limpieza de terreno manual | 40d | 2025-05-26 | 2025-07-11 | A5360 SS | 75d | 0d | Oficial [6.97 h]; Peon [13.93 h]; Operador equipo Pesado [2.61 h]; Excavadora Cat 336 [0.87 h]; Tractor D6 [1.74 h]; Capataz [0.35 h]; Petroleo [19.59 gln]; Cost [320] | 870.74 | m2 | 0 | Interferencias | 47 |
| A5380 |  | Excavaciones no clasificada para estructuras | 40d | 2025-05-26 | 2025-07-11 | A5370 SS | 75d | 0d | Peon [3.7 h]; Operador equipo Pesado [3.7 h]; Excavadora Cat 336 [3.7 h]; Capataz [0.74 h]; Petroleo [31.49 gln]; Cost [320] | 115.77 | m3 | 0 | Interferencias | 47 |
| A5390 |  | Excavacion no clasificada de zanja | 40d | 2025-05-26 | 2025-07-11 | A5380 SS | 75d | 0d | Peon [17.5 h]; Operador equipo Pesado [17.5 h]; Excavadora Cat 336 [17.5 h]; Capataz [1.75 h]; Petroleo [148.76 gln]; Cost [320] | 350.02 | m3 | 0 | Interferencias | 47 |
| A5400 |  | Relleno estructural | 40d | 2025-05-26 | 2025-07-11 | A5390 SS | 75d | 0d | Operario [17.29 h]; Oficial [17.29 h]; Peon [41.47 h]; Peon - Vigia [0.5 h]; Operador equipo Pesado [18.39 h]; Operador equipo Liviano [21.47 h]; Cisterna 5000 gln [1.71 h]; Volquete 15 m3 [2.48 h]; Cargador Frontal 966 [2.32 h]; Excavadora Cat 336 [4.17 h]; Retroexcavadora sobre llantas 58 hp [8.64 h]; Rodillo liso vibratorio 0.80 - 1.10 ton [17.29 h]; Tractor D6 [0.93 h]; Zaranda Metso ST 4.8 168 HP [2.32 h]; Capataz [4.98 h]; Petroleo [128.84 gln]; Cost [320] | 120.98 | m3 | 0 | Interferencias | 47 |
| A5410 |  | Suministro de roca (Alcantarillas) | 40d | 2025-05-26 | 2025-07-11 | A5400 SS | 75d | 0d | Peon [2.23 h]; Peon - Vigia [0.18 h]; Operador equipo Pesado [2.23 h]; Operador equipo Liviano [3.55 h]; Volquete 22 m3 [3.55 h]; Excavadora Cat 336 [2.23 h]; Capataz [0.93 h]; Petroleo [33.07 gln]; Peaje local [1.35]; Cost [320] | 29.71 | m3 | 0 | Interferencias | 47 |
| A5420 |  | Colocación de roca en uña (Alcantarillas) | 40d | 2025-05-26 | 2025-07-11 | A5410 SS | 75d | 0d | Oficial [1.24 h]; Peon [1.24 h]; Operador equipo Pesado [1.49 h]; Excavadora Cat 336 [1.24 h]; Tractor D6 [0.25 h]; Capataz [0.62 h]; Petroleo [12.26 gln]; Cost [320] | 29.71 | m3 | 0 | Interferencias | 47 |
| A5430 |  | Concreto de Nivelacion (f'c=100 kg/cm2) | 40d | 2025-05-26 | 2025-07-11 | A5420 SS | 75d | 0d | Operario [0.17 h]; Oficial [1.1 h]; Peon [4.76 h]; Operador equipo Liviano [0.22 h]; Cisterna 5000 gln [0.04 h]; Carmix 4.0 m3 [0.17 h]; Capataz [0.36 h]; Petroleo [1.04 gln]; PIEDRA CHANCADA [1.13]; ARENA GRUESA [0.95]; CEMENTO PORTLAND TIPO I (42.5 kg) [10.39]; Cost [320] | 1.65 | m3 | 0 | Interferencias | 47 |
| A5440 |  | Concreto Clase F (f'c=140 kg/cm2) | 40d | 2025-05-26 | 2025-07-11 | A5430 SS | 75d | 0d | Operario [4.67 h]; Oficial [12.08 h]; Peon [48.34 h]; Operador equipo Liviano [4.67 h]; Carmix 4.0 m3 [4.67 h]; Capataz [3.02 h]; Petroleo [23.35 gln]; PIEDRA CHANCADA [7.59]; ARENA GRUESA [6.42]; CEMENTO PORTLAND TIPO I (42.5 kg) [81.73]; PLASTIMENT TM-40 - PLASTIFICANTE [25.1]; Cost [320] | 11.12 | m3 | 0 | Interferencias | 47 |
| A5450 |  | Concreto Clase C (f'c=280 kg/cm2) Premezclado - Cimientos reforzados | 40d | 2025-05-26 | 2025-07-11 | A5440 SS | 75d | 0d | Operario [6.22 h]; Oficial [8.64 h]; Peon [20.05 h]; Operador equipo Liviano [3.81 h]; Carmix 4.0 m3 [3.81 h]; Capataz [2.16 h]; Petroleo [20.23 gln]; PIEDRA CHANCADA [6.18]; ARENA GRUESA [5.23]; CEMENTO PORTLAND TIPO I (42.5 kg) [99.89]; PLASTIMENT TM-40 - PLASTIFICANTE [20.45]; ADITIVO CURADOR DE CONCRETO [1.36]; Cost [320] | 9.06 | m3 | 0 | Interferencias | 47 |
| A5460 |  | Concreto Clase C (f'c=280 kg/cm2) Premezclado - Muros de contencion | 40d | 2025-05-26 | 2025-07-11 | A5450 SS | 75d | 0d | Operario [13.15 h]; Oficial [18.26 h]; Peon [47.49 h]; Operador equipo Liviano [8.04 h]; Carmix 4.0 m3 [8.04 h]; Capataz [4.56 h]; Petroleo [42.77 gln]; PIEDRA CHANCADA [13.07]; ARENA GRUESA [11.06]; CEMENTO PORTLAND TIPO I (42.5 kg) [211.13]; PLASTIMENT TM-40 - PLASTIFICANTE [43.23]; ADITIVO CURADOR DE CONCRETO [2.87]; Cost [320] | 19.15 | m3 | 0 | Interferencias | 47 |
| A5470 |  | Encofrado y Desencofrado Caravista | 40d | 2025-05-26 | 2025-07-11 | A5460 SS | 75d | 0d | Operario [15.99 h]; Oficial [15.99 h]; Peon [31.99 h]; Capataz [3.2 h]; ALAMBRE NEGRO #8 [6.4]; CLAVOS PARA MADERA CON CABEZA DE 3" [6.4]; LACA DESMOLDEADORA [0.96]; MADERA TORNILLO INCLUYE CORTE PARA ENCOFRADO [95.97]; TRIPLAY DE 18 mm FENOLICO P/ENCOFRADO [2.78]; Cost [320] | 31.99 | m2 | 0 | Interferencias | 47 |
| A5480 |  | Encofrado y Desencofrado Cara Oculta | 40d | 2025-05-26 | 2025-07-11 | A5470 SS | 75d | 0d | Operario [80.16 h]; Oficial [80.16 h]; Capataz [8.02 h]; ALAMBRE NEGRO #8 [36.07]; CLAVOS PARA MADERA CON CABEZA DE 3" [25.25]; MADERA TORNILLO INCLUYE CORTE PARA ENCOFRADO [601.15]; Cost [320] | 120.23 | m2 | 0 | Interferencias | 47 |
| A5490 |  | Acero de refuerzo f'y=4200kg/cm2 | 40d | 2025-05-26 | 2025-07-11 | A5480 SS | 75d | 0d | Operario [37.97 h]; Oficial [37.97 h]; Peon [18.98 h]; Capataz [3.77 h]; ALAMBRE NEGRO #16 [78.45]; ACERO CORRUGADO fy = 4200 kg/cm2 GRADO 60 [1647.45]; Cost [320] | 1569 | kg | 0 | Interferencias | 47 |
| A5500 |  | Emboquillado de piedra e=0.20m | 40d | 2025-05-26 | 2025-07-11 | A5490 SS | 75d | 0d | Operario [90.1 h]; Oficial [180.18 h]; Peon [294.62 h]; Peon - Vigia [0.29 h]; Operador equipo Pesado [0.42 h]; Operador equipo Liviano [63.56 h]; Cisterna 5000 gln [0.81 h]; Volquete 15 m3 [2.81 h]; Excavadora Cat 336 [0.42 h]; Retroexcavadora sobre llantas 94 hp [59.94 h]; Zaranda estatica [6.05 h]; Capataz [31.2 h]; Petroleo [164.46 gln]; ARENA GRUESA [26.03]; CEMENTO PORTLAND TIPO I (42.5 kg) [253.47]; Cost [320] | 323.3 | m2 | 0 | Interferencias | 47 |
| A5510 |  | Emboquillado de piedra e=0.30m | 40d | 2025-05-26 | 2025-07-11 | A5500 SS | 75d | 0d | Operario [3.76 h]; Oficial [7.52 h]; Peon [12.3 h]; Peon - Vigia [0.01 h]; Operador equipo Pesado [0.02 h]; Operador equipo Liviano [2.65 h]; Cisterna 5000 gln [0.03 h]; Volquete 15 m3 [0.12 h]; Excavadora Cat 336 [0.02 h]; Retroexcavadora sobre llantas 94 hp [2.5 h]; Zaranda estatica [0.25 h]; Capataz [1.3 h]; Petroleo [6.87 gln]; ARENA GRUESA [1.09]; CEMENTO PORTLAND TIPO I (42.5 kg) [10.58]; Cost [320] | 9 | m2 | 0 | Interferencias | 47 |
| A5520 |  | Cama de arena e=0.20m | 40d | 2025-05-26 | 2025-07-11 | A5510 SS | 75d | 0d | Operario [1.18 h]; Oficial [2.37 h]; Peon [4.76 h]; Peon - Vigia [0.02 h]; Operador equipo Liviano [0.21 h]; Cisterna 5000 gln [0.08 h]; Volquete 22 m3 [0.12 h]; Capataz [0.24 h]; Petroleo [1.91 gln]; ARENA GRUESA [6.51]; Cost [320] | 29.6 | m2 | 0 | Interferencias | 47 |
| A5530 |  | Tubería HDPE Corrugada Ø=900mm (Suministro e instalación) | 40d | 2025-05-26 | 2025-07-11 | A5520 SS | 75d | 0d | Operario [5.51 h]; Oficial [11.03 h]; Peon [11.03 h]; Operador equipo Pesado [2.76 h]; Operador equipo Liviano [1.38 h]; Camion grua 20 ton [1.38 h]; Excavadora Cat 336 [2.76 h]; Capataz [5.51 h]; Petroleo [28.95 gln]; Tubería HDPE Corrugado de 900 mm [18.19]; Cost [320] | 16.54 | m | 0 | Interferencias | 47 |
| A5540 |  | Compuertas Charnela Ø900 (Suministro e instalacion) | 40d | 2025-05-26 | 2025-07-11 | A5530 SS | 75d | 0d | Operario [8 h]; Oficial [16 h]; Peon [32 h]; Operador equipo Liviano [6 h]; Camion grua 20 ton [6 h]; Capataz [4 h]; Petroleo [24 gln]; ANCLAJES [4]; Suministro de Compuerta tipo CHARNELA, D=900mm [1]; Cost [320] | 1 | und | 0 | Interferencias | 47 |
| A5550 |  | Sello en juntas | 40d | 2025-05-26 | 2025-07-11 | A5540 SS | 75d | 0d | Operario [37.72 h]; Peon [9.43 h]; Capataz [9.43 h]; TECNOPOR DE 1/2"X4X8' [6.45]; SELLADOR ELASTICO POLIURETANO SIKAFLEX 1A [32.37]; Cost [320] | 113.17 | m | 0 | Interferencias | 47 |
| A5560 |  | Waterstop (anillos de estanqueidad) | 40d | 2025-05-26 | 2025-07-11 | A5550 SS | 75d | 0d | Operario [2 h]; Peon [4 h]; Capataz [0.2 h]; WATER STOP (anillos de estanqueidad); DN=900mm [1.82]; WATER STOP (anillos de estanqueidad); DN=1200mm [0.18]; Cost [320] | 2 | und | 0 | Interferencias | 47 |
| A5570 |  | Pintura bituminosa | 40d | 2025-05-26 | 2025-07-11 | A5560 SS | 75d | 0d | Operario [24.03 h]; Peon [48.07 h]; Capataz [2.4 h]; PINTURA ASFALTICA [48.07]; IMPRIMANTE ASFALTICO [21.03]; Cost [320] | 120.17 | m2 | 0 | Interferencias | 47 |
| A5580 |  | Relleno con material granular (incluye extracción de material, zarandeo y combinación de material) | 40d | 2025-05-26 | 2025-07-11 | A5570 SS | 75d | 0d | Peon [3.85 h]; Peon - Vigia [0.12 h]; Operador equipo Pesado [2.97 h]; Operador equipo Liviano [2.43 h]; Cisterna 5000 gln [0.4 h]; Volquete 15 m3 [0.59 h]; Cargador Frontal 966 [0.66 h]; Chancadora Primaria [0.44 h]; Excavadora Cat 336 [1.87 h]; Rodillo liso vibratorio 0.80 - 1.10 ton [1.43 h]; Tractor D6; Capataz [0.73 h]; Petroleo [27.68 gln]; Cost [320] | 28.68 | m3 | 0 | Interferencias | 47 |
| A5590 |  | Suministro e Instalación de geotextil | 40d | 2025-05-26 | 2025-07-11 | A5580 SS | 75d | 68d | Oficial [0.68 h]; Peon [1.02 h]; Operador equipo Liviano [0.08 h]; Camion grua 20 ton [0.08 h]; Capataz [0.07 h]; Petroleo [0.34 gln]; Geotextil no tejido 200gr/m2 [30.72]; Cost [320] | 25.6 | m2 | 0 | Interferencias | 47 |

| ID | WBS | Activity | Type | Duration | Start | Finish | Predecessors | Total float | Free float | Resources | RCuad | Duracion | Cuadrilla | Rendimiento | Metrado | Unidad | Turno | DurCal | Dur. Cal. | AGrupo |
| --- | --- | --- | --- | --- | --- | --- | --- | --- | --- | --- | --- | --- | --- | --- | --- | --- | --- | --- | --- | --- |
|  | 10 | **DE-PR-24A-1** |  |  | 2025-04-21 | 2025-10-14 |  |  |  |  |  |  |  |  |  |  |  |  |  |  |
| A3710 |  | Inicio - DE-PR-24A-1 | milestone | 0d | 2025-04-21 | 2025-04-21 | A5630 SS, A2730 FS+30d | 0d |  |  | 0 | 0 |  |  |  |  |  |  |  |  |
| A3720 |  | Fin - DE-PR-24A-1 | milestone | 0d | 2025-10-14 | 2025-10-14 | A3490 FF, A3480 FF, A3640 FF | 0d |  |  | 0 | 0 |  |  |  |  |  |  |  |  |
|  | 1 | **EXCAVACIONES** |  |  | 2025-04-21 | 2025-07-25 |  |  |  |  |  |  |  |  |  |  |  |  |  |  |
| A3390 |  | Desbroce |  | 60d | 2025-04-21 | 2025-07-01 | A3710 SS | 0d |  | Peon [76 h]; Operador equipo Pesado [57 h]; Excavadora Cat 336 [19 h]; Tractor D6 [38 h]; Capataz [0.38 h]; Petroleo [427.5 gln]; Cost [480] | 1 | 72 | 1 | 0.8 | 3.8 | ha | 1 | 3.8 | 4.75 | Excavacion |
| A3450 |  | Conformacion de Material Excedente en DMO |  | 60d | 2025-04-21 | 2025-07-01 | A3390 SS | 26d |  | Peon [89.74 h]; Operador equipo Pesado [99.19 h]; Excavadora Cat 336 [9.45 h]; Tractor D6 [89.74 h]; Capataz [9.45 h]; Petroleo [708.49 gln]; Cost [480] | 1 | 72 | 1 | 1050 | 11808.13 | m3 | 1 | 11808.13 | 11.2458380952381 | Excavacion |
| A3400 |  | Remocion de Dique Existente |  | 74d | 2025-04-23 | 2025-07-19 | A3390 SS+2d | 0d |  | Peon [84.79 h]; Operador equipo Pesado [127.19 h]; Excavadora Cat 336 [84.79 h]; Tractor D8 [42.4 h]; Capataz [16.96 h]; Petroleo [1123.48 gln]; Cost [592] | 0.5 | 88 | 0.5 | 800 | 8479.06 | m3 | 1 | 16958.12 | 21.19765 | Excavacion |
| A3410 |  | Excavacion de Cimentacion |  | 74d | 2025-04-23 | 2025-07-19 | A3400 SS | 0d |  | Peon [1000.32 h]; Operador equipo Pesado [666.88 h]; Operador equipo Liviano [555.74 h]; Excavadora Cat 336 [444.59 h]; Retroexcavadora sobre llantas 94 hp [555.74 h]; Tractor D8 [222.29 h]; Capataz [100.03 h]; Petroleo [7269.02 gln]; Cost [592] | 0.5 | 88 | 0.5 | 880 | 55573.58 | m3 | 1 | 111147.16 | 126.303590909091 | Excavacion |
| A3430 |  | Excavacion de Uña |  | 74d | 2025-04-23 | 2025-07-19 | A3410 SS | 0d |  | Peon [332.85 h]; Operador equipo Pesado [332.85 h]; Excavadora Cat 336 [332.85 h]; Capataz [66.57 h]; Petroleo [3761.18 gln]; Cost [592] | 0.5 | 88 | 0.5 | 500 | 20802.98 | m3 | 1 | 41605.96 | 83.21192 | Excavacion |
| A3440 |  | Conformacion de Material Excedente en DME |  | 74d | 2025-04-23 | 2025-07-19 | A3400 SS | 10d |  | Peon [522.42 h]; Operador equipo Pesado [577.41 h]; Excavadora Cat 336 [54.99 h]; Tractor D6 [522.42 h]; Capataz [54.99 h]; Petroleo [4124.39 gln]; Cost [592] | 1 | 88 | 1 | 1050 | 68739.76 | m3 | 1 | 68739.76 | 65.4664380952381 | Excavacion |
| A3460 |  | Excavacion Localizada - Sobreexcavacion |  | 74d | 2025-04-23 | 2025-07-19 | A3430 SS | 10d |  | Peon [130.28 h]; Operador equipo Pesado [130.28 h]; Excavadora Cat 336 [130.28 h]; Capataz [26.21 h]; Petroleo [1107.56 gln]; Cost [592] | 0.5 | 88 | 0.5 | 240 | 3912.27 | m3 | 1 | 7824.54 | 32.60225 | Excavacion |
| A3420 |  | Perfilado y Conformacion de Plataforma de Fundacion |  | 60d | 2025-05-15 | 2025-07-25 | A3410 SS+18d | 12d | 0d | Peon [78.28 h]; Operador equipo Pesado [139.63 h]; Operador equipo Liviano [29.62 h]; Cisterna 5000 gln [29.62 h]; Motoniveladora 140K [69.81 h]; Rodillo liso vibratorio 10 - 12 ton [69.81 h]; Capataz [6.35 h]; Petroleo [600.83 gln]; Cost [480] | 0.3 | 72 | 0.3 | 2400 | 21156.07 | m2 | 1 | 70520.2333333333 | 29.3834305555555 | Excavacion |
|  | 2 | **RELLENOS** |  |  | 2025-06-20 | 2025-10-14 |  |  |  |  |  |  |  |  |  |  |  |  |  |  |
| A3470 |  | Relleno con Material Granular (incluye extraccion de material, zarandeo y combinado) |  | 52d | 2025-06-20 | 2025-08-23 | A3420 SS+30d | 12d | 0d | Operario [186.53 h]; Oficial [543.83 h]; Peon [1794.37 h]; Peon - Vigia [94.58 h]; Operador equipo Pesado [2537.87 h]; Operador equipo Liviano [1205.88 h]; Cisterna 5000 gln [543.83 h]; Volquete 15 m3 [470.27 h]; Cargador Frontal 966 [754 h]; Chancadora Primaria [354.67 h]; Excavadora Cat 336 [535.95 h]; Retroexcavadora sobre llantas 58 hp [94.58 h]; Rodillo liso vibratorio 10 - 12 ton [357.3 h]; Rodillo liso vibratorio 0.80 - 1.10 ton [186.53 h]; Tractor D6 [449.25 h]; Capataz [646.29 h]; Petroleo [20342.3 gln]; Cost [416] | 1 | 65 | 1 | 560 | 26271.9 | m3 | 1 | 26271.9 | 46.9141071428571 | Relleno |
| A3510 |  | Relleno con Material Seleccionado (incluye extraccion de material, zarandeo y combinado) |  | 52d | 2025-06-20 | 2025-08-23 | A3470 SS | 43d | 0d | Oficial [130.28 h]; Peon [267.6 h]; Operador equipo Pesado [390.84 h]; Operador equipo Liviano [27.39 h]; Cisterna 5000 gln [27.39 h]; Excavadora Cat 336 [260.56 h]; Rodillo liso vibratorio 10 - 12 ton [130.28 h]; Capataz [26.21 h]; Petroleo [3984.26 gln]; Cost [416] | 1 | 65 | 1 | 240 | 3912.27 | m3 | 1 | 3912.27 | 16.301125 | Relleno |
| A3520 |  | Grava para Drenaje |  | 26d | 2025-06-26 | 2025-07-26 | A3510 SS+5d | 43d | 38d | Peon [556.41 h]; Peon - Vigia [17.45 h]; Operador equipo Pesado [228.19 h]; Operador equipo Liviano [512.99 h]; Volquete 15 m3 [87.27 h]; Cargador Frontal 966 [97.92 h]; Chancadora Primaria [65.14 h]; Excavadora Cat 336 [65.14 h]; Retroexcavadora sobre llantas 94 hp [425.72 h]; Tractor D6; Capataz [171.56 h]; Petroleo [2911.49 gln]; Cost [208] | 1 | 31 | 1 | 80 | 4257.19 | m3 | 1 | 4257.19 | 53.214875 | Relleno |
| A3500 |  | Perfilado de Talud Dique |  | 48d | 2025-07-07 | 2025-09-05 | A3470 SS+14d | 12d | 7d | Peon [184.21 h]; Operador equipo Pesado [54.94 h]; Excavadora Cat 336 [54.94 h]; Capataz [37.16 h]; Petroleo [466.98 gln]; Cost [384] | 1 | 61 | 1 | 700 | 16158.57 | m2 | 1 | 16158.57 | 23.0836714285714 | Relleno |
| A3480 |  | Relleno sin Compactar |  | 20d | 2025-09-15 | 2025-10-07 | A3570 FF, A3500, A3520 | 5d |  | Oficial [118.66 h]; Peon [118.66 h]; Operador equipo Pesado [118.66 h]; Tractor D6 [118.66 h]; Capataz [24 h]; Petroleo [830.64 gln]; Cost [160] | 1 | 24 | 1 | 900 | 13332.95 | m3 | 1 | 13332.95 | 14.8143888888889 | Relleno |
| A3490 |  | Relleno Afirmado |  | 5d | 2025-10-09 | 2025-10-14 | A3570 | 0d |  | Oficial [35.83 h]; Peon [112.71 h]; Peon - Vigia [12.04 h]; Operador equipo Pesado [206.57 h]; Operador equipo Liviano [76.16 h]; Cisterna 5000 gln [16.39 h]; Volquete 15 m3 [59.77 h]; Cargador Frontal 966 [25.39 h]; Chancadora LT200 [25.39 h]; Excavadora Cat 336 [47.58 h]; Motoniveladora 140K [35.83 h]; Rodillo liso vibratorio 10 - 12 ton [35.83 h]; Tractor D6 [11.17 h]; Zaranda Metso ST 4.8 168 HP [25.39 h]; Capataz [43.66 h]; Petroleo [1454.97 gln]; CANON POR EXTRACCION CANTERA [1523.15]; Cost [40] | 1 | 6 | 1 | 324 | 1450.62 | m3 | 1 | 1450.62 | 4.47722222222222 | Relleno |
|  | 3 | **GEOTEXTIL** |  |  | 2025-05-12 | 2025-09-15 |  |  |  |  |  |  |  |  |  |  |  |  |  |  |
| A3530 |  | Instalacion de Geotextil 400gr/m2 |  | 103d | 2025-05-12 | 2025-09-15 | A3430 SS+15d | 0d |  | Oficial [1635.3 h]; Peon [2449.89 h]; Operador equipo Liviano [202.12 h]; Camion grua 20 ton [202.12 h]; Capataz [165.37 h]; Petroleo [808.46 gln]; Geotextil no tejido 200gr/m2 [70434.2]; Cost [824] | 1 | 127 | 1 | 600 | 61247.15 | m2 | 1 | 61247.15 | 102.078583333333 | Geotextil |
| A3540 |  | Zanja de Anclaje |  | 10d | 2025-09-04 | 2025-09-15 | A3530 FF | 9d | 0d | Oficial [66.53 h]; Peon [200.05 h]; Operador equipo Pesado [66.53 h]; Operador equipo Liviano [1.86 h]; Cisterna 5000 gln [1.86 h]; Retroexcavadora sobre llantas 58 hp [66.53 h]; Capataz [13.3 h]; Petroleo [237.02 gln]; Cost [80] | 1 | 12 | 1 | 32 | 266.1 | m3 | 1 | 266.1 | 8.315625 | Geotextil |
|  | 4 | **COLOCACION DE ROCA** |  |  | 2025-04-23 | 2025-10-07 |  |  |  |  |  |  |  |  |  |  |  |  |  |  |
| A3580 |  | Extraccion de Rocas Reutilizables |  | 74d | 2025-04-23 | 2025-07-19 | A3400 SS | 10d |  | Peon [479.59 h]; Operador equipo Pesado [479.59 h]; Excavadora Cat 336 [479.59 h]; Capataz [240.01 h]; Petroleo [4076.71 gln]; Cost [592] | 1 | 88 | 1 | 144 | 4263 | m3 | 1 | 4263 | 29.6041666666667 | Roca |
| A3550 |  | Suministro de roca |  | 92d | 2025-05-13 | 2025-09-03 | A3560 SS | 35d | 0d | Cost [736] | 1 | 114 | 1 |  |  | ton | 1 | 0 |  | Roca |
| A3560 |  | Colocacion de Roca en Uña |  | 75d | 2025-05-13 | 2025-08-13 | A3430 SS+2d, A3530 SS+1d, A3600 SS+10d | 0d |  | Oficial [594.97 h]; Peon [594.97 h]; Operador equipo Pesado [655.29 h]; Excavadora Cat 336 [594.97 h]; Tractor D6 [60.33 h]; Capataz [297.48 h]; Petroleo [5479.5 gln]; Roca [20803 m3]; Cost [600] | 1 | 93 | 1 | 280 | 20802.98 | m3 | 1 | 20802.98 | 74.2963571428572 | Roca |
| A3570 |  | Colocacion de Roca en Talud |  | 53d | 2025-08-05 | 2025-10-07 | A3530 SS, A3470 SS+15d, A3560 SS+68d, A3580, A3440, A3460, A3620, A3450 | 0d |  | Oficial [842.84 h]; Peon [842.84 h]; Operador equipo Pesado [1768.55 h]; Excavadora Cat 336 [1683.66 h]; Tractor D6 [84.89 h]; Capataz [420.41 h]; Petroleo [14906.4 gln]; Roca [20212 m3]; Cost [424] | 2 | 64 | 2 | 192 | 20212.05 | m3 | 1 | 10106.025 | 52.635546875 | Roca |

| ID | WBS | Activity | Type | Duration | Start | Finish | Predecessors | Total float | Free float | Resources | Cuadrilla | Metrado | Unidad | Turno | RCuad | DurCal | AGrupo | Duracion | Rendimiento | Dur. Cal. |
| --- | --- | --- | --- | --- | --- | --- | --- | --- | --- | --- | --- | --- | --- | --- | --- | --- | --- | --- | --- | --- |
|  | 5 | **TRANSPORTES** |  |  | 2025-04-21 | 2025-10-14 |  |  |  |  |  |  |  |  |  |  |  |  |  |  |
| A3590 |  | Transporte de Material Organico (a DMO) D<=1km |  | 60d | 2025-04-21 | 2025-07-01 | A3390 SS | 8d | 0d | Peon - Vigia [66.13 h]; Operador equipo Liviano [328.27 h]; Volquete 15 m3 [328.27 h]; Petroleo [918.67 gln]; Cost [480] | 1 | 11808.13 | m3k | 1 | 1 | 11808.13 | Transportes | 72 |  |  |
| A3600 |  | Transporte de Material Organico (a DMO) D>1km |  | 60d | 2025-04-21 | 2025-07-01 | A3590 SS | 8d |  | Operador equipo Liviano [1129.89 h]; Volquete 15 m3 [1129.89 h]; Petroleo [3163.68 gln]; Cost [480] | 1 | 102716.84 | m3k | 1 | 1 | 102716.84 | Transportes | 72 |  |  |
| A3610 |  | Transporte de Material Excedente D<=1km |  | 74d | 2025-04-23 | 2025-07-19 | A3400 SS | 10d | 0d | Peon - Vigia [350.57 h]; Operador equipo Liviano [1745.99 h]; Volquete 22 m3 [749.26 h]; Volquete 15 m3 [996.73 h]; Petroleo [5849.75 gln]; Cost [592] | 1 | 68739.76 | m3k | 1 | 1 | 68739.76 | Transportes | 88 |  |  |
| A3620 |  | Transporte de Material Excedente D>1km |  | 74d | 2025-04-23 | 2025-07-19 | A3610 SS | 10d |  | Operador equipo Liviano [6019.16 h]; Volquete 22 m3 [2562.61 h]; Volquete 15 m3 [3456.55 h]; Petroleo [20143.3 gln]; Cost [592] | 1 | 595956.09 | m3k | 1 | 1 | 595956.09 | Transportes | 88 |  |  |
| A3650 |  | Transporte de Roca D<=1km |  | 92d | 2025-05-13 | 2025-09-03 | A3550 SS | 35d | 0d | Peon [512.69 h]; Peon - Vigia [246.09 h]; Operador equipo Pesado [512.69 h]; Operador equipo Liviano [1230.45 h]; Volquete 22 m3 [1230.45 h]; Excavadora Cat 336 [512.69 h]; Petroleo [9236.58 gln]; Peaje local [1866.18]; Cost [736] | 1 | 41015.03 | m3k | 1 | 1 | 41015.03 | Transportes | 114 |  |  |
| A3660 |  | Transporte de Roca D>1km |  | 92d | 2025-05-13 | 2025-09-03 | A3650 SS | 35d | 101d | Operador equipo Liviano [3369.8 h]; Volquete 22 m3 [3369.8 h]; Petroleo [13416.2 gln]; Cost [736] | 1 | 314934.85 | m3k | 1 | 1 | 314934.85 | Transportes | 114 |  |  |
| A3670 |  | Transporte de Material de Prestamo Cantera de Rio (Cuerpo de Terraplen) D<=1km |  | 52d | 2025-06-20 | 2025-08-23 | A3470 SS | 43d | 0d | Peon - Vigia [142.71 h]; Operador equipo Liviano [710.15 h]; Volquete 22 m3 [710.15 h]; Petroleo [2911.97 gln]; Cost [416] | 1 | 33978.62 | m3k | 1 | 1 | 33978.62 | Transportes | 65 |  |  |
| A3680 |  | Transporte de Material de Prestamo Cantera de Rio (Cuerpo de Terraplen) D>1km |  | 52d | 2025-06-20 | 2025-08-23 | A3670 SS | 43d | 69d | Operador equipo Liviano [261.39 h]; Volquete 22 m3 [261.39 h]; Petroleo [1070.77 gln]; Cost [416] | 1 | 31493.16 | m3k | 1 | 1 | 31493.16 | Transportes | 65 |  |  |
| A3690 |  | Transporte de Material Seleccionado para Zanja D<=1km |  | 10d | 2025-09-04 | 2025-09-15 | A3540 SS | 9d | 0d | Peon - Vigia [1.49 h]; Operador equipo Liviano [7.4 h]; Volquete 15 m3 [7.4 h]; Petroleo [20.7 gln]; Cost [80] | 1 | 266.1 | m3k | 1 | 1 | 266.1 | Transportes | 12 |  |  |
| A3700 |  | Transporte de Material Seleccionado para Zanja D>1km |  | 10d | 2025-09-04 | 2025-09-15 | A3690 SS | 9d |  | Operador equipo Liviano [2.58 h]; Volquete 15 m3 [2.58 h]; Petroleo [7.23 gln]; Cost [80] | 1 | 234.75 | m3k | 1 | 1 | 234.75 | Transportes | 12 |  |  |
| A3630 |  | Transporte de Material de Prestamo (Afirmado) D<=1km |  | 25d | 2025-09-15 | 2025-10-14 | A3490 FF | 0d |  | Peon - Vigia [87.92 h]; Operador equipo Liviano [437.5 h]; Volquete 22 m3 [437.5 h]; Petroleo [1793.95 gln]; Cost [200] | 1 | 20932.94 | m3k | 1 | 1 | 20932.94 | Transportes | 30 |  |  |
| A3640 |  | Transporte de Material de Prestamo (Afirmado) D>1km |  | 25d | 2025-09-15 | 2025-10-14 | A3630 SS, A3660 SS, A3680 SS, A3700 SS | 0d |  | Operador equipo Liviano [1459.75 h]; Volquete 22 m3 [1459.75 h]; Petroleo [5979.71 gln]; Cost [200] | 1 | 175873.94 | m3k | 1 | 1 | 175873.94 | Transportes | 30 |  |  |
|  | 1 | **DIQUES - GRUPO 2** |  |  | 2024-11-29 | 2025-06-19 |  |  |  |  |  |  |  |  |  |  |  |  |  |  |
| A5650 |  | Inicio - Diques - Grupo 2 | milestone | 0d | 2024-11-29 | 2024-11-29 | A1050, A1380 | 5d | 0d |  |  |  |  |  | 0 |  |  | 0 |  |  |
| A5660 |  | Fin - Diques - Grupo 2 | milestone | 0d | 2025-06-19 | 2025-06-19 | A1720 FF, A2060 FF, A3040 FF | 95d |  |  |  |  |  |  | 0 |  |  | 0 |  |  |
|  | 2 | **DE-PR-09-I** |  |  | 2024-11-29 | 2025-01-28 |  |  |  |  |  |  |  |  |  |  |  |  |  |  |
| A1710 |  | Inicio - DE-PR-09-I | milestone | 0d | 2024-11-29 | 2024-11-29 | A5650 SS | 177d | 0d |  |  |  |  |  | 0 |  |  | 0 |  |  |
| A1720 |  | Fin - DE-PR-09-I | milestone | 0d | 2025-01-28 | 2025-01-28 | A1440 FF, A1450 FF, A1480 FF, A1500 FF, A1600 FF, A1620 FF, A1640 FF, A1660 FF, A1680 FF, A1700 FF | 213d | 118d |  |  |  |  |  | 0 |  |  | 0 |  |  |
|  | 1 | **EXCAVACIONES** |  |  | 2024-11-29 | 2024-12-30 |  |  |  |  |  |  |  |  |  |  |  |  |  |  |
| A1390 |  | Desbroce |  | 18d | 2024-11-29 | 2024-12-20 | A1710 SS | 177d | 0d | Peon [24 h]; Operador equipo Pesado [18 h]; Excavadora Cat 336 [6 h]; Tractor D6 [12 h]; Capataz [0.12 h]; Petroleo [135 gln]; Cost [144] | 1 | 1.2 | ha | 1 | 1 | 1.2 | Excavacion | 22 | 0.8 | 1.5 |
| A1450 |  | Conformacion de Material Excedente en DMO |  | 18d | 2024-11-29 | 2024-12-20 | A1390 SS | 244d | 31d | Peon [27.33 h]; Operador equipo Pesado [30.2 h]; Excavadora Cat 336 [2.88 h]; Tractor D6 [27.33 h]; Capataz [2.88 h]; Petroleo [215.73 gln]; Cost [144] | 1 | 3595.43 | m3 | 1 | 1 | 3595.43 | Excavacion | 22 | 1050 | 3.42421904761905 |
| A1410 |  | Excavacion de Cimentacion |  | 21d | 2024-11-30 | 2024-12-26 | A1390 SS+1d | 177d | 0d | Peon [123.45 h]; Operador equipo Pesado [82.3 h]; Operador equipo Liviano [68.58 h]; Excavadora Cat 336 [54.87 h]; Retroexcavadora sobre llantas 94 hp [68.58 h]; Tractor D8 [27.43 h]; Capataz [12.34 h]; Petroleo [897.05 gln]; Cost [168] | 0.5 | 6858.2 | m3 | 1 | 0.5 | 13716.4 | Excavacion | 25 | 880 | 15.5868181818182 |
| A1430 |  | Excavacion de Uña |  | 21d | 2024-11-30 | 2024-12-26 | A1410 SS | 213d | 0d | Peon [112.32 h]; Operador equipo Pesado [112.32 h]; Excavadora Cat 336 [112.32 h]; Capataz [22.46 h]; Petroleo [1269.21 gln]; Cost [168] | 0.5 | 7019.98 | m3 | 1 | 0.5 | 14039.96 | Excavacion | 25 | 500 | 28.07992 |
| A1440 |  | Conformacion de Material Excedente en DME |  | 21d | 2024-11-30 | 2024-12-26 | A1410 SS | 240d | 27d | Peon [88.66 h]; Operador equipo Pesado [97.99 h]; Excavadora Cat 336 [9.33 h]; Tractor D6 [88.66 h]; Capataz [9.33 h]; Petroleo [699.96 gln]; Cost [168] | 1 | 11665.95 | m3 | 1 | 1 | 11665.95 | Excavacion | 25 | 1050 | 11.1104285714286 |
| A1420 |  | Perfilado y Conformacion de Plataforma de Fundacion |  | 20d | 2024-12-05 | 2024-12-30 | A1410 SS+4d | 196d | 0d | Peon [39.37 h]; Operador equipo Pesado [70.22 h]; Operador equipo Liviano [14.9 h]; Cisterna 5000 gln [14.9 h]; Motoniveladora 140K [35.11 h]; Rodillo liso vibratorio 10 - 12 ton [35.11 h]; Capataz [3.19 h]; Petroleo [302.18 gln]; Cost [160] | 0.5 | 10640.08 | m2 | 1 | 0.5 | 21280.16 | Excavacion | 25 | 2400 | 8.86673333333333 |

| ID | WBS | Activity | Duration | Start | Finish | Predecessors | Total float | Free float | Resources | Cuadrilla | Rendimiento | Metrado | Unidad | Turno | RCuad | DurCal | Dur. Cal. | AGrupo | Duracion |
| --- | --- | --- | --- | --- | --- | --- | --- | --- | --- | --- | --- | --- | --- | --- | --- | --- | --- | --- | --- |
|  | 2 | **RELLENOS** |  | 2024-12-31 | 2025-01-28 |  |  |  |  |  |  |  |  |  |  |  |  |  |  |
| A1470 |  | Relleno con Material Granular (incluye extraccion de material, zarandeo y combinado) | 11d | 2024-12-31 | 2025-01-13 | A1420, A1120 | 196d | 0d | Operario [40.83 h]; Oficial [119.05 h]; Peon [392.81 h]; Peon - Vigia [20.7 h]; Operador equipo Pesado [555.57 h]; Operador equipo Liviano [263.98 h]; Cisterna 5000 gln [119.05 h]; Volquete 15 m3 [102.95 h]; Cargador Frontal 966 [165.06 h]; Chancadora Primaria [77.64 h]; Excavadora Cat 336 [117.33 h]; Retroexcavadora sobre llantas 58 hp [20.7 h]; Rodillo liso vibratorio 10 - 12 ton [78.22 h]; Rodillo liso vibratorio 0.80 - 1.10 ton [40.83 h]; Tractor D6 [98.35 h]; Capataz [141.48 h]; Petroleo [4453.19 gln]; Cost [88] | 1 | 560 | 5751.24 | m3 | 1 | 1 | 5751.24 | 10.2700714285714 | Relleno | 12 |
| A1500 |  | Perfilado de Talud Dique | 6d | 2025-01-07 | 2025-01-13 | A1470 SS+5d | 226d | 13d | Peon [22.48 h]; Operador equipo Pesado [6.7 h]; Excavadora Cat 336 [6.7 h]; Capataz [4.54 h]; Petroleo [56.98 gln]; Cost [48] | 1 | 700 | 1971.75 | m2 | 1 | 1 | 1971.75 | 2.81678571428571 | Relleno | 7 |
| A1480 |  | Relleno sin Compactar | 10d | 2025-01-15 | 2025-01-25 | A1570 FF | 215d | 2d | Oficial [23.82 h]; Peon [23.82 h]; Operador equipo Pesado [23.82 h]; Tractor D6 [23.82 h]; Capataz [4.82 h]; Petroleo [166.77 gln]; Cost [80] | 1 | 900 | 2676.88 | m3 | 1 | 1 | 2676.88 | 2.97431111111111 | Relleno | 11 |
| A1490 |  | Relleno Afirmado | 2d | 2025-01-27 | 2025-01-28 | A1570, A4420 | 213d | 0d | Oficial [13.43 h]; Peon [42.25 h]; Peon - Vigia [4.51 h]; Operador equipo Pesado [77.43 h]; Operador equipo Liviano [28.55 h]; Cisterna 5000 gln [6.14 h]; Volquete 15 m3 [22.4 h]; Cargador Frontal 966 [9.52 h]; Chancadora LT200 [9.52 h]; Excavadora Cat 336 [17.83 h]; Motoniveladora 140K [13.43 h]; Rodillo liso vibratorio 10 - 12 ton [13.43 h]; Tractor D6 [4.19 h]; Zaranda Metso ST 4.8 168 HP [9.52 h]; Capataz [16.37 h]; Petroleo [545.35 gln]; CANON POR EXTRACCION CANTERA [570.91]; Cost [16] | 1 | 324 | 543.72 | m3 | 1 | 1 | 543.72 | 1.67814814814815 | Relleno | 2 |
|  | 3 | **GEOTEXTIL** |  | 2024-12-03 | 2025-01-15 |  |  |  |  |  |  |  |  |  |  |  |  |  |  |
| A1530 |  | Instalacion de Geotextil 400gr/m2 | 35d | 2024-12-03 | 2025-01-15 | A1430 SS+2d | 214d | 0d | Oficial [372.89 h]; Peon [558.64 h]; Operador equipo Liviano [46.09 h]; Camion grua 20 ton [46.09 h]; Capataz [37.71 h]; Petroleo [184.35 gln]; Geotextil no tejido 200gr/m2 [16060.8]; Cost [280] | 1 | 600 | 13965.92 | m2 | 1 | 1 | 13965.92 | 23.2765333333333 | Geotextil | 43 |
| A1540 |  | Zanja de Anclaje | 10d | 2025-01-04 | 2025-01-15 | A1530 FF | 224d | 0d | Oficial [34.56 h]; Peon [103.93 h]; Operador equipo Pesado [34.56 h]; Operador equipo Liviano [0.97 h]; Cisterna 5000 gln [0.97 h]; Retroexcavadora sobre llantas 58 hp [34.56 h]; Capataz [6.91 h]; Petroleo [123.13 gln]; Cost [80] | 1 | 32 | 138.24 | m3 | 1 | 1 | 138.24 | 4.32 | Geotextil | 12 |
|  | 4 | **COLOCACION DE ROCA** |  | 2024-12-05 | 2025-01-25 |  |  |  |  |  |  |  |  |  |  |  |  |  |  |
| A1550 |  | Suministro de roca | 42d | 2024-12-05 | 2025-01-25 | A1560 SS | 215d | 0d | Cost [336] | 1 |  |  | ton | 1 | 1 | 0 |  | Roca | 51 |
| A1560 |  | Colocacion de Roca en Uña | 26d | 2024-12-05 | 2025-01-07 | A1430 SS+4d, A1530 SS+1d | 213d | 0d | Oficial [200.77 h]; Peon [200.77 h]; Operador equipo Pesado [221.13 h]; Excavadora Cat 336 [200.77 h]; Tractor D6 [20.36 h]; Capataz [100.39 h]; Petroleo [1849.06 gln]; Roca [7019.98 m3]; Cost [208] | 1 | 280 | 7019.98 | m3 | 1 | 1 | 7019.98 | 25.0713571428571 | Roca | 33 |
| A1570 |  | Colocacion de Roca en Talud | 16d | 2025-01-08 | 2025-01-25 | A1560, A1530 SS | 213d | 0d | Oficial [126.47 h]; Peon [126.47 h]; Operador equipo Pesado [265.38 h]; Excavadora Cat 336 [252.64 h]; Tractor D6 [12.74 h]; Capataz [63.08 h]; Petroleo [2236.75 gln]; Roca [3032.88 m3]; Cost [128] | 1 | 192 | 3032.88 | m3 | 1 | 1 | 3032.88 | 15.79625 | Roca | 18 |
|  | 5 | **TRANSPORTES** |  | 2024-11-29 | 2025-01-28 |  |  |  |  |  |  |  |  |  |  |  |  |  |  |
| A1590 |  | Transporte de Material Organico (a DMO) D<=1km | 18d | 2024-11-29 | 2024-12-20 | A1390 SS | 244d | 0d | Peon - Vigia [20.13 h]; Operador equipo Liviano [99.95 h]; Volquete 15 m3 [99.95 h]; Petroleo [279.72 gln]; Cost [144] | 1 |  | 3595.43 | m3k | 1 | 1 | 3595.43 |  | Transportes | 22 |
| A1600 |  | Transporte de Material Organico (a DMO) D>1km | 18d | 2024-11-29 | 2024-12-20 | A1590 SS | 244d | 31d | Operador equipo Liviano [554.74 h]; Volquete 15 m3 [554.74 h]; Petroleo [1553.28 gln]; Cost [144] | 1 |  | 50431.18 | m3k | 1 | 1 | 50431.18 |  | Transportes | 22 |
| A1610 |  | Transporte de Material Excedente D<=1km | 21d | 2024-11-30 | 2024-12-26 | A1410 SS | 240d | 0d | Peon - Vigia [59.5 h]; Operador equipo Liviano [296.32 h]; Volquete 22 m3 [127.16 h]; Volquete 15 m3 [169.16 h]; Petroleo [992.77 gln]; Cost [168] | 1 |  | 11665.95 | m3k | 1 | 1 | 11665.95 |  | Transportes | 25 |
| A1620 |  | Transporte de Material Excedente D>1km | 21d | 2024-11-30 | 2024-12-26 | A1610 SS | 240d | 27d | Operador equipo Liviano [1650.43 h]; Volquete 22 m3 [702.66 h]; Volquete 15 m3 [947.77 h]; Petroleo [5523.21 gln]; Cost [168] | 1 |  | 163408.49 | m3k | 1 | 1 | 163408.49 |  | Transportes | 25 |
| A1650 |  | Transporte de Roca D<=1km | 42d | 2024-12-05 | 2025-01-25 | A1550 SS | 215d | 0d | Peon [126.1 h]; Peon - Vigia [60.53 h]; Operador equipo Pesado [126.1 h]; Operador equipo Liviano [302.64 h]; Volquete 22 m3 [302.64 h]; Excavadora Cat 336 [126.1 h]; Petroleo [2271.8 gln]; Peaje local [459]; Cost [336] | 1 |  | 10087.92 | m3k | 1 | 1 | 10087.92 |  | Transportes | 51 |
| A1660 |  | Transporte de Roca D>1km | 42d | 2024-12-05 | 2025-01-25 | A1650 SS | 215d | 2d | Operador equipo Liviano [2112.28 h]; Volquete 22 m3 [2112.28 h]; Petroleo [8409.62 gln]; Cost [336] | 1 |  | 197409 | m3k | 1 | 1 | 197409 |  | Transportes | 51 |
| A1670 |  | Transporte de Material de Prestamo Cantera de Rio (Cuerpo de Terraplen) D<=1km | 10d | 2024-12-31 | 2025-01-11 | A1470 SS | 227d | 0d | Peon - Vigia [24.16 h]; Operador equipo Liviano [120.2 h]; Volquete 22 m3 [120.2 h]; Petroleo [492.88 gln]; Cost [80] | 1 |  | 5751.24 | m3k | 1 | 1 | 5751.24 |  | Transportes | 12 |
| A1680 |  | Transporte de Material de Prestamo Cantera de Rio (Cuerpo de Terraplen) D>1km | 10d | 2024-12-31 | 2025-01-11 | A1670 SS | 227d | 14d | Operador equipo Liviano [50.96 h]; Volquete 22 m3 [50.96 h]; Petroleo [208.77 gln]; Cost [80] | 1 |  | 6140.33 | m3k | 1 | 1 | 6140.33 |  | Transportes | 12 |
| A1690 |  | Transporte de Material Seleccionado para Zanja D<=1km | 10d | 2025-01-04 | 2025-01-15 | A1540 SS | 224d | 0d | Peon - Vigia [0.77 h]; Operador equipo Liviano [3.84 h]; Volquete 15 m3 [3.84 h]; Petroleo [10.76 gln]; Cost [80] | 1 |  | 138.24 | m3k | 1 | 1 | 138.24 |  | Transportes | 12 |
| A1700 |  | Transporte de Material Seleccionado para Zanja D>1km | 10d | 2025-01-04 | 2025-01-15 | A1690 SS | 224d | 11d | Operador equipo Liviano [1.64 h]; Volquete 15 m3 [1.64 h]; Petroleo [4.58 gln]; Cost [80] | 1 |  | 148.82 | m3k | 1 | 1 | 148.82 |  | Transportes | 12 |
| A1630 |  | Transporte de Material de Prestamo (Afirmado) D<=1km | 2d | 2025-01-27 | 2025-01-28 | A1490 SS | 213d | 0d | Peon - Vigia [17.36 h]; Operador equipo Liviano [86.37 h]; Volquete 22 m3 [86.37 h]; Petroleo [354.15 gln]; Cost [16] | 1 |  | 4132.41 | m3k | 1 | 1 | 4132.41 |  | Transportes | 2 |
| A1640 |  | Transporte de Material de Prestamo (Afirmado) D>1km | 2d | 2025-01-27 | 2025-01-28 | A1630 SS | 213d | 0d | Operador equipo Liviano [610.66 h]; Volquete 22 m3 [610.66 h]; Petroleo [2501.49 gln]; Cost [16] | 1 |  | 73573.29 | m3k | 1 | 1 | 73573.29 |  | Transportes | 2 |

| ID | WBS | Activity | Duration | Start | Finish | Predecessors | Total float | Free float | Resources | Metrado | Unidad | RCuad | AGrupo | Duracion |
| --- | --- | --- | --- | --- | --- | --- | --- | --- | --- | --- | --- | --- | --- | --- |
|  | 6 | **INTERFERENCIAS** |  | 2024-12-05 | 2025-01-06 |  |  |  |  |  |  |  |  |  |
| A4170 |  | Trazo y replanteo de interferencia | 25d | 2024-12-05 | 2025-01-06 | A1390 SS+5d | 230d | 0d | Peon [10.09 h]; Topografo [5.04 h]; GPS [5.04 h]; Capataz [0.5 h]; MADERA TORNILLO [5.04]; PINTURA ESMALTE [0.5]; Cost [200] | 252.15 | m2 | 0 | Interferencias | 32 |
| A4180 |  | Desvío provisional con tubería | 25d | 2024-12-05 | 2025-01-06 | A4170 SS | 230d | 0d | Operario [20.52 h]; Oficial [20.52 h]; Peon [131.37 h]; Operador equipo Pesado [8.21 h]; Operador equipo Liviano [5.13 h]; Camion grua 20 ton [5.13 h]; Excavadora Cat 336 [8.21 h]; Capataz [11.91 h]; Petroleo [90.29 gln]; TUBERIA CORRUGADA HDPE D=630 mm [64.66]; Cost [200] | 61.58 | m | 0 | Interferencias | 32 |
| A4190 |  | Desvío provisional en tierras | 25d | 2024-12-05 | 2025-01-06 | A4180 SS | 230d | 0d | Peon [2.4 h]; Operador equipo Pesado [2.4 h]; Excavadora Cat 336 [2.4 h]; Capataz [0.48 h]; Petroleo [20.4 gln]; Cost [200] | 18 | m | 0 | Interferencias | 32 |
| A4200 |  | Limpieza de terreno manual | 25d | 2024-12-05 | 2025-01-06 | A4190 SS | 230d | 0d | Oficial [2.02 h]; Peon [4.03 h]; Operador equipo Pesado [0.76 h]; Excavadora Cat 336 [0.25 h]; Tractor D6 [0.5 h]; Capataz [0.1 h]; Petroleo [5.67 gln]; Cost [200] | 252.15 | m2 | 0 | Interferencias | 32 |
| A4210 |  | Excavaciones no clasificada para estructuras | 25d | 2024-12-05 | 2025-01-06 | A4200 SS | 230d | 0d | Peon [3.84 h]; Operador equipo Pesado [3.84 h]; Excavadora Cat 336 [3.84 h]; Capataz [0.77 h]; Petroleo [32.65 gln]; Cost [200] | 120.04 | m3 | 0 | Interferencias | 32 |
| A4220 |  | Excavacion no clasificada de zanja | 25d | 2024-12-05 | 2025-01-06 | A4210 SS | 230d | 0d | Peon [10.32 h]; Operador equipo Pesado [10.32 h]; Excavadora Cat 336 [10.32 h]; Capataz [1.03 h]; Petroleo [87.7 gln]; Cost [200] | 206.36 | m3 | 0 | Interferencias | 32 |
| A4230 |  | Relleno estructural | 25d | 2024-12-05 | 2025-01-06 | A4220 SS | 230d | 0d | Operario [25.15 h]; Oficial [25.15 h]; Peon [60.34 h]; Peon - Vigia [0.72 h]; Operador equipo Pesado [26.75 h]; Operador equipo Liviano [31.24 h]; Cisterna 5000 gln [2.48 h]; Volquete 15 m3 [3.61 h]; Cargador Frontal 966 [3.38 h]; Excavadora Cat 336 [6.07 h]; Retroexcavadora sobre llantas 58 hp [12.57 h]; Rodillo liso vibratorio 0.80 - 1.10 ton [25.15 h]; Tractor D6 [1.36 h]; Zaranda Metso ST 4.8 168 HP [3.38 h]; Capataz [7.25 h]; Petroleo [187.46 gln]; Cost [200] | 176.02 | m3 | 0 | Interferencias | 32 |
| A4240 |  | Suministro de roca (Alcantarillas) | 25d | 2024-12-05 | 2025-01-06 | A4230 SS | 230d | 0d | Peon [2.63 h]; Peon - Vigia [0.21 h]; Operador equipo Pesado [2.63 h]; Operador equipo Liviano [4.19 h]; Volquete 22 m3 [4.19 h]; Excavadora Cat 336 [2.63 h]; Capataz [1.1 h]; Petroleo [39.03 gln]; Peaje local [1.6]; Cost [200] | 35.06 | m3 | 0 | Interferencias | 32 |
| A4250 |  | Colocación de roca en uña (Alcantarillas) | 25d | 2024-12-05 | 2025-01-06 | A4240 SS | 230d | 0d | Oficial [1.46 h]; Peon [1.46 h]; Operador equipo Pesado [1.75 h]; Excavadora Cat 336 [1.46 h]; Tractor D6 [0.29 h]; Capataz [0.73 h]; Petroleo [14.47 gln]; Cost [200] | 35.06 | m3 | 0 | Interferencias | 32 |
| A4260 |  | Concreto de Nivelacion (f'c=100 kg/cm2) | 25d | 2024-12-05 | 2025-01-06 | A4250 SS | 230d | 0d | Operario [0.78 h]; Oficial [4.97 h]; Peon [21.48 h]; Operador equipo Liviano [0.98 h]; Cisterna 5000 gln [0.2 h]; Carmix 4.0 m3 [0.78 h]; Capataz [1.63 h]; Petroleo [4.7 gln]; PIEDRA CHANCADA [5.08]; ARENA GRUESA [4.3]; CEMENTO PORTLAND TIPO I (42.5 kg) [46.94]; Cost [200] | 7.45 | m3 | 0 | Interferencias | 32 |
| A4270 |  | Concreto Clase F (f'c=140 kg/cm2) | 25d | 2024-12-05 | 2025-01-06 | A4260 SS | 230d | 0d | Operario [15.65 h]; Oficial [40.5 h]; Peon [162 h]; Operador equipo Liviano [15.65 h]; Carmix 4.0 m3 [15.65 h]; Capataz [10.13 h]; Petroleo [78.27 gln]; PIEDRA CHANCADA [25.44]; ARENA GRUESA [21.52]; CEMENTO PORTLAND TIPO I (42.5 kg) [273.93]; PLASTIMENT TM-40 - PLASTIFICANTE [84.14]; Cost [200] | 37.27 | m3 | 0 | Interferencias | 32 |
| A4280 |  | Concreto Clase C (f'c=280 kg/cm2) Premezclado - Cimientos reforzados | 25d | 2024-12-05 | 2025-01-06 | A4270 SS | 230d | 0d | Operario [18.58 h]; Oficial [25.8 h]; Peon [59.89 h]; Operador equipo Liviano [11.37 h]; Carmix 4.0 m3 [11.37 h]; Capataz [6.45 h]; Petroleo [60.43 gln]; PIEDRA CHANCADA [18.47]; ARENA GRUESA [15.63]; CEMENTO PORTLAND TIPO I (42.5 kg) [298.34]; PLASTIMENT TM-40 - PLASTIFICANTE [61.09]; ADITIVO CURADOR DE CONCRETO [4.06]; Cost [200] | 27.06 | m3 | 0 | Interferencias | 32 |
| A4290 |  | Concreto Clase C (f'c=280 kg/cm2) Premezclado - Muros de contencion | 25d | 2024-12-05 | 2025-01-06 | A4280 SS | 230d | 0d | Operario [27.83 h]; Oficial [38.63 h]; Peon [100.49 h]; Operador equipo Liviano [17.02 h]; Carmix 4.0 m3 [17.02 h]; Capataz [9.66 h]; Petroleo [90.49 gln]; PIEDRA CHANCADA [27.65]; ARENA GRUESA [23.4]; CEMENTO PORTLAND TIPO I (42.5 kg) [446.73]; PLASTIMENT TM-40 - PLASTIFICANTE [91.47]; ADITIVO CURADOR DE CONCRETO [6.08]; Cost [200] | 40.52 | m3 | 0 | Interferencias | 32 |
| A4300 |  | Encofrado y Desencofrado Caravista | 25d | 2024-12-05 | 2025-01-06 | A4290 SS | 230d | 0d | Operario [64.75 h]; Oficial [64.75 h]; Peon [129.49 h]; Capataz [12.95 h]; ALAMBRE NEGRO #8 [25.9]; CLAVOS PARA MADERA CON CABEZA DE 3" [25.9]; LACA DESMOLDEADORA [3.88]; MADERA TORNILLO INCLUYE CORTE PARA ENCOFRADO [388.47]; TRIPLAY DE 18 mm FENOLICO P/ENCOFRADO [11.27]; Cost [200] | 129.49 | m2 | 0 | Interferencias | 32 |
| A4310 |  | Encofrado y Desencofrado Cara Oculta | 25d | 2024-12-05 | 2025-01-06 | A4300 SS | 230d | 0d | Operario [145.79 h]; Oficial [145.79 h]; Capataz [14.59 h]; ALAMBRE NEGRO #8 [65.6]; CLAVOS PARA MADERA CON CABEZA DE 3" [45.92]; MADERA TORNILLO INCLUYE CORTE PARA ENCOFRADO [1093.35]; Cost [200] | 218.67 | m2 | 0 | Interferencias | 32 |
| A4320 |  | Acero de refuerzo f'y=4200kg/cm2 | 25d | 2024-12-05 | 2025-01-06 | A4310 SS | 230d | 0d | Operario [104.91 h]; Oficial [104.91 h]; Peon [52.45 h]; Capataz [10.4 h]; ALAMBRE NEGRO #16 [216.75]; ACERO CORRUGADO fy = 4200 kg/cm2 GRADO 60 [4551.82]; Cost [200] | 4335.07 | kg | 0 | Interferencias | 32 |
| A4330 |  | Emboquillado de piedra e=0.20m | 25d | 2024-12-05 | 2025-01-06 | A4320 SS | 230d | 0d | Operario [2.21 h]; Oficial [4.41 h]; Peon [7.22 h]; Peon - Vigia [0.01 h]; Operador equipo Pesado [0.01 h]; Operador equipo Liviano [1.56 h]; Cisterna 5000 gln [0.02 h]; Volquete 15 m3 [0.07 h]; Excavadora Cat 336 [0.01 h]; Retroexcavadora sobre llantas 94 hp [1.47 h]; Zaranda estatica [0.15 h]; Capataz [0.76 h]; Petroleo [4.03 gln]; ARENA GRUESA [0.64]; CEMENTO PORTLAND TIPO I (42.5 kg) [6.21]; Cost [200] | 7.92 | m2 | 0 | Interferencias | 32 |
| A4340 |  | Emboquillado de piedra e=0.30m | 25d | 2024-12-05 | 2025-01-06 | A4330 SS | 230d | 0d | Operario [6.44 h]; Oficial [12.87 h]; Peon [21.05 h]; Peon - Vigia [0.02 h]; Operador equipo Pesado [0.03 h]; Operador equipo Liviano [4.54 h]; Cisterna 5000 gln [0.06 h]; Volquete 15 m3 [0.2 h]; Excavadora Cat 336 [0.03 h]; Retroexcavadora sobre llantas 94 hp [4.28 h]; Zaranda estatica [0.43 h]; Capataz [2.23 h]; Petroleo [11.75 gln]; ARENA GRUESA [1.86]; CEMENTO PORTLAND TIPO I (42.5 kg) [18.11]; Cost [200] | 15.4 | m2 | 0 | Interferencias | 32 |
| A4350 |  | Emboquillado de piedra e=0.50m | 25d | 2024-12-05 | 2025-01-06 | A4340 SS | 230d | 0d | Operario [57.96 h]; Oficial [115.92 h]; Peon [183.5 h]; Peon - Vigia [0.21 h]; Operador equipo Pesado [0.31 h]; Operador equipo Liviano [38.27 h]; Cisterna 5000 gln [0.59 h]; Volquete 15 m3 [2.05 h]; Excavadora Cat 336 [0.31 h]; Retroexcavadora sobre llantas 94 hp [35.64 h]; Capataz [18.84 h]; Petroleo [99.79 gln]; ARENA GRUESA [19.01]; CEMENTO PORTLAND TIPO I (42.5 kg) [185.22]; Cost [200] | 94.5 | m2 | 0 | Interferencias | 32 |
| A4360 |  | Cama de arena e=0.20m | 25d | 2024-12-05 | 2025-01-06 | A4350 SS | 230d | 0d | Operario [1.35 h]; Oficial [2.71 h]; Peon [5.44 h]; Peon - Vigia [0.03 h]; Operador equipo Liviano [0.24 h]; Cisterna 5000 gln [0.09 h]; Volquete 22 m3 [0.14 h]; Capataz [0.27 h]; Petroleo [2.18 gln]; ARENA GRUESA [7.45]; Cost [200] | 33.86 | m2 | 0 | Interferencias | 32 |
| A4370 |  | Tubería HDPE Corrugada Ø=900mm (Suministro e instalación) | 25d | 2024-12-05 | 2025-01-06 | A4360 SS | 230d | 0d | Operario [4.53 h]; Oficial [9.05 h]; Peon [9.05 h]; Operador equipo Pesado [2.26 h]; Operador equipo Liviano [1.13 h]; Camion grua 20 ton [1.13 h]; Excavadora Cat 336 [2.26 h]; Capataz [4.53 h]; Petroleo [23.77 gln]; Tubería HDPE Corrugado de 900 mm [14.94]; Cost [200] | 13.58 | m | 0 | Interferencias | 32 |
| A4380 |  | Sello en juntas | 25d | 2024-12-05 | 2025-01-06 | A4370 SS | 230d | 0d | Operario [4.52 h]; Peon [1.13 h]; Capataz [1.13 h]; TECNOPOR DE 1/2"X4X8' [0.77]; SELLADOR ELASTICO POLIURETANO SIKAFLEX 1A [3.88]; Cost [200] | 13.56 | m | 0 | Interferencias | 32 |
| A4390 |  | Waterstop (anillos de estanqueidad) | 25d | 2024-12-05 | 2025-01-06 | A4380 SS | 230d | 0d | Operario [4 h]; Peon [8 h]; Capataz [0.4 h]; WATER STOP (anillos de estanqueidad); DN=900mm [3.64]; WATER STOP (anillos de estanqueidad); DN=1200mm [0.36]; Cost [200] | 4 | und | 0 | Interferencias | 32 |
| A4400 |  | Pintura bituminosa | 25d | 2024-12-05 | 2025-01-06 | A4390 SS | 230d | 0d | Operario [43.73 h]; Peon [87.47 h]; Capataz [4.37 h]; PINTURA ASFALTICA [87.47]; IMPRIMANTE ASFALTICO [38.27]; Cost [200] | 218.67 | m2 | 0 | Interferencias | 32 |
| A4410 |  | Relleno con material granular (incluye extracción de material, zarandeo y combinación de material) | 25d | 2024-12-05 | 2025-01-06 | A4400 SS | 230d | 0d | Peon [33.99 h]; Peon - Vigia [1.04 h]; Operador equipo Pesado [26.24 h]; Operador equipo Liviano [21.43 h]; Cisterna 5000 gln [3.57 h]; Volquete 15 m3 [5.19 h]; Cargador Frontal 966 [5.83 h]; Chancadora Primaria [3.88 h]; Excavadora Cat 336 [16.54 h]; Rodillo liso vibratorio 0.80 - 1.10 ton [12.66 h]; Tractor D6; Capataz [6.41 h]; Petroleo [244.49 gln]; Cost [200] | 253.28 | m3 | 0 | Interferencias | 32 |
| A4420 |  | Suministro e Instalación de geotextil | 25d | 2024-12-05 | 2025-01-06 | A4410 SS | 230d | 17d | Oficial [1.04 h]; Peon [1.56 h]; Operador equipo Liviano [0.13 h]; Camion grua 20 ton [0.13 h]; Capataz [0.11 h]; Petroleo [0.51 gln]; Geotextil no tejido 200gr/m2 [46.8]; Cost [200] | 39 | m2 | 0 | Interferencias | 32 |

| ID | WBS | Activity | Type | Duration | Start | Finish | Predecessors | Total float | Free float | Resources | RCuad | Duracion | Cuadrilla | Rendimiento | Metrado | Unidad | Turno | DurCal | Dur. Cal. | AGrupo |
| --- | --- | --- | --- | --- | --- | --- | --- | --- | --- | --- | --- | --- | --- | --- | --- | --- | --- | --- | --- | --- |
|  | 3 | **DE-PR-10-I** |  |  | 2024-12-27 | 2025-03-11 |  |  |  |  |  |  |  |  |  |  |  |  |  |  |
| A2050 |  | Inicio - DE-PR-10-I | milestone | 0d | 2024-12-27 | 2024-12-27 | A1410 | 177d | 0d |  | 0 | 0 |  |  |  |  |  |  |  |  |
| A2060 |  | Fin - DE-PR-10-I | milestone | 0d | 2025-03-11 | 2025-03-11 | A1780 FF, A1790 FF, A1800 FF, A1820 FF, A1840 FF, A1860 FF, A1920 FF, A1940 FF, A1960 FF, A1980 FF, A2000 FF, A2020 FF, A2040 FF | 177d | 82d |  | 0 | 0 |  |  |  |  |  |  |  |  |
|  | 1 | **EXCAVACIONES** |  |  | 2024-12-27 | 2025-02-03 |  |  |  |  |  |  |  |  |  |  |  |  |  |  |
| A1730 |  | Desbroce |  | 20d | 2024-12-27 | 2025-01-20 | A2050 SS | 177d | 0d | Peon [25.6 h]; Operador equipo Pesado [19.2 h]; Excavadora Cat 336 [6.4 h]; Tractor D6 [12.8 h]; Capataz [0.13 h]; Petroleo [144 gln]; Cost [160] | 1 | 25 | 1 | 0.8 | 1.28 | ha | 1 | 1.28 | 1.6 | Excavacion |
| A1790 |  | Conformacion de Material Excedente en DMO |  | 20d | 2024-12-27 | 2025-01-20 | A1730 SS | 220d | 43d | Peon [29.33 h]; Operador equipo Pesado [32.42 h]; Excavadora Cat 336 [3.09 h]; Tractor D6 [29.33 h]; Capataz [3.09 h]; Petroleo [231.56 gln]; Cost [160] | 1 | 25 | 1 | 1050 | 3859.34 | m3 | 1 | 3859.34 | 3.67556190476191 | Excavacion |
| A1740 |  | Remocion de Dique Existente |  | 28d | 2024-12-30 | 2025-01-31 | A1730 SS+2d | 177d | 0d | Peon [6.98 h]; Operador equipo Pesado [10.47 h]; Excavadora Cat 336 [6.98 h]; Tractor D8 [3.49 h]; Capataz [1.4 h]; Petroleo [92.5 gln]; Cost [224] | 0.5 | 33 | 0.5 | 800 | 698.14 | m3 | 1 | 1396.28 | 1.74535 | Excavacion |
| A1750 |  | Excavacion de Cimentacion |  | 28d | 2024-12-30 | 2025-01-31 | A1740 SS | 177d | 0d | Peon [441.21 h]; Operador equipo Pesado [294.14 h]; Operador equipo Liviano [245.12 h]; Excavadora Cat 336 [196.09 h]; Retroexcavadora sobre llantas 94 hp [245.12 h]; Tractor D8 [98.05 h]; Capataz [44.12 h]; Petroleo [3206.11 gln]; Cost [224] | 0.5 | 33 | 0.5 | 880 | 24511.53 | m3 | 1 | 49023.06 | 55.7080227272727 | Excavacion |
| A1770 |  | Excavacion de Uña |  | 28d | 2024-12-30 | 2025-01-31 | A1750 SS | 177d | 0d | Peon [117.8 h]; Operador equipo Pesado [117.8 h]; Excavadora Cat 336 [117.8 h]; Capataz [23.56 h]; Petroleo [1331.13 gln]; Cost [224] | 0.5 | 33 | 0.5 | 500 | 7362.44 | m3 | 1 | 14724.88 | 29.44976 | Excavacion |
| A1780 |  | Conformacion de Material Excedente en DME |  | 20d | 2024-12-30 | 2025-01-22 | A1740 SS | 218d | 41d | Peon [216.39 h]; Operador equipo Pesado [239.16 h]; Excavadora Cat 336 [22.78 h]; Tractor D6 [216.39 h]; Capataz [22.78 h]; Petroleo [1708.31 gln]; Cost [160] | 1 | 24 | 1 | 1050 | 28471.9 | m3 | 1 | 28471.9 | 27.1160952380952 | Excavacion |
| A1800 |  | Excavacion Localizada - Sobreexcavacion |  | 28d | 2024-12-30 | 2025-01-31 | A1770 SS | 210d | 33d | Peon [26.43 h]; Operador equipo Pesado [26.43 h]; Excavadora Cat 336 [26.43 h]; Capataz [5.32 h]; Petroleo [224.7 gln]; Cost [224] | 0.5 | 33 | 0.5 | 240 | 793.71 | m3 | 1 | 1587.42 | 6.61425 | Excavacion |
| A1760 |  | Perfilado y Conformacion de Plataforma de Fundacion |  | 21d | 2025-01-10 | 2025-02-03 | A1750 SS+9d | 192d | 0d | Peon [56.11 h]; Operador equipo Pesado [100.09 h]; Operador equipo Liviano [21.23 h]; Cisterna 5000 gln [21.23 h]; Motoniveladora 140K [50.04 h]; Rodillo liso vibratorio 10 - 12 ton [50.04 h]; Capataz [4.55 h]; Petroleo [430.67 gln]; Cost [168] | 0.3 | 25 | 0.3 | 2400 | 15164.48 | m2 | 1 | 50548.2666666667 | 21.0617777777778 | Excavacion |
|  | 2 | **RELLENOS** |  |  | 2025-01-18 | 2025-03-11 |  |  |  |  |  |  |  |  |  |  |  |  |  |  |
| A1810 |  | Relleno con Material Granular (incluye extraccion de material, zarandeo y combinado) |  | 30d | 2025-01-18 | 2025-02-21 | A1760 SS+7d, A1470 | 192d | 0d | Operario [114.17 h]; Oficial [332.87 h]; Peon [1098.32 h]; Peon - Vigia [57.89 h]; Operador equipo Pesado [1553.41 h]; Operador equipo Liviano [738.11 h]; Cisterna 5000 gln [332.87 h]; Volquete 15 m3 [287.85 h]; Cargador Frontal 966 [461.52 h]; Chancadora Primaria [217.09 h]; Excavadora Cat 336 [328.05 h]; Retroexcavadora sobre llantas 58 hp [57.89 h]; Rodillo liso vibratorio 10 - 12 ton [218.7 h]; Rodillo liso vibratorio 0.80 - 1.10 ton [114.17 h]; Tractor D6 [274.98 h]; Capataz [395.59 h]; Petroleo [12451.4 gln]; Cost [240] | 1 | 36 | 1 | 560 | 16080.88 | m3 | 1 | 16080.88 | 28.7158571428571 | Relleno |
| A1850 |  | Relleno con Material Seleccionado (incluye extraccion de material, zarandeo y combinado) |  | 30d | 2025-01-18 | 2025-02-21 | A1810 SS | 192d | 0d | Oficial [26.43 h]; Peon [54.29 h]; Operador equipo Pesado [79.29 h]; Operador equipo Liviano [5.56 h]; Cisterna 5000 gln [5.56 h]; Excavadora Cat 336 [52.86 h]; Rodillo liso vibratorio 10 - 12 ton [26.43 h]; Capataz [5.32 h]; Petroleo [808.31 gln]; Cost [240] | 1 | 36 | 1 | 240 | 793.71 | m3 | 1 | 793.71 | 3.307125 | Relleno |
| A1840 |  | Perfilado de Talud Dique |  | 20d | 2025-01-25 | 2025-02-17 | A1810 SS+6d | 196d | 19d | Peon [79.78 h]; Operador equipo Pesado [23.79 h]; Excavadora Cat 336 [23.79 h]; Capataz [16.1 h]; Petroleo [202.24 gln]; Cost [160] | 1 | 25 | 1 | 700 | 6997.9 | m2 | 1 | 6997.9 | 9.997 | Relleno |
| A1860 |  | Grava para Drenaje |  | 9d | 2025-01-27 | 2025-02-05 | A1850 SS+7d | 206d | 29d | Peon [88 h]; Peon - Vigia [2.76 h]; Operador equipo Pesado [36.09 h]; Operador equipo Liviano [81.13 h]; Volquete 15 m3 [13.8 h]; Cargador Frontal 966 [15.49 h]; Chancadora Primaria [10.3 h]; Excavadora Cat 336 [10.3 h]; Retroexcavadora sobre llantas 94 hp [67.33 h]; Tractor D6; Capataz [27.13 h]; Petroleo [460.47 gln]; Cost [72] | 1 | 10 | 1 | 80 | 673.3 | m3 | 1 | 673.3 | 8.41625 | Relleno |
| A1820 |  | Relleno sin Compactar |  | 5d | 2025-03-03 | 2025-03-07 | A1910 FF | 180d | 3d | Oficial [44.04 h]; Peon [44.04 h]; Operador equipo Pesado [44.04 h]; Tractor D6 [44.04 h]; Capataz [8.91 h]; Petroleo [308.28 gln]; Cost [40] | 1 | 6 | 1 | 900 | 4948.3 | m3 | 1 | 4948.3 | 5.49811111111111 | Relleno |
| A1830 |  | Relleno Afirmado |  | 3d | 2025-03-08 | 2025-03-11 | A1910, A4670 | 177d | 0d | Oficial [23.51 h]; Peon [73.97 h]; Peon - Vigia [7.9 h]; Operador equipo Pesado [135.57 h]; Operador equipo Liviano [49.98 h]; Cisterna 5000 gln [10.76 h]; Volquete 15 m3 [39.22 h]; Cargador Frontal 966 [16.66 h]; Chancadora LT200 [16.66 h]; Excavadora Cat 336 [31.23 h]; Motoniveladora 140K [23.51 h]; Rodillo liso vibratorio 10 - 12 ton [23.51 h]; Tractor D6 [7.33 h]; Zaranda Metso ST 4.8 168 HP [16.66 h]; Capataz [28.66 h]; Petroleo [954.87 gln]; CANON POR EXTRACCION CANTERA [999.61]; Cost [24] | 1 | 3 | 1 | 324 | 952.01 | m3 | 1 | 952.01 | 2.9383024691358 | Relleno |
|  | 3 | **GEOTEXTIL** |  |  | 2025-01-08 | 2025-02-22 |  |  |  |  |  |  |  |  |  |  |  |  |  |  |
| A1870 |  | Instalacion de Geotextil 400gr/m2 |  | 40d | 2025-01-08 | 2025-02-22 | A1770 SS+7d | 177d | 0d | Oficial [412.3 h]; Peon [617.68 h]; Operador equipo Liviano [50.96 h]; Camion grua 20 ton [50.96 h]; Capataz [41.69 h]; Petroleo [203.84 gln]; Geotextil no tejido 200gr/m2 [17758.4]; Cost [320] | 1 | 48 | 1 | 600 | 15442.05 | m2 | 1 | 15442.05 | 25.73675 | Geotextil |
| A1880 |  | Zanja de Anclaje |  | 10d | 2025-02-12 | 2025-02-22 | A1870 FF | 191d | 0d | Oficial [30.94 h]; Peon [93.04 h]; Operador equipo Pesado [30.94 h]; Operador equipo Liviano [0.87 h]; Cisterna 5000 gln [0.87 h]; Retroexcavadora sobre llantas 58 hp [30.94 h]; Capataz [6.19 h]; Petroleo [110.22 gln]; Cost [80] | 1 | 12 | 1 | 32 | 123.75 | m3 | 1 | 123.75 | 3.8671875 | Geotextil |
|  | 4 | **COLOCACION DE ROCA** |  |  | 2024-12-30 | 2025-03-07 |  |  |  |  |  |  |  |  |  |  |  |  |  |  |
| A1920 |  | Extraccion de Rocas Reutilizables |  | 20d | 2024-12-30 | 2025-01-22 | A1740 SS | 218d | 41d | Peon [40.16 h]; Operador equipo Pesado [40.16 h]; Excavadora Cat 336 [40.16 h]; Capataz [20.1 h]; Petroleo [341.4 gln]; Cost [160] | 1 | 24 | 1 | 144 | 357 | m3 | 1 | 357 | 2.47916666666667 | Roca |
| A1890 |  | Suministro de roca |  | 50d | 2025-01-09 | 2025-03-07 | A1900 SS | 180d | 0d | Cost [400] | 1 | 62 | 1 |  |  | ton | 1 | 0 |  | Roca |
| A1900 |  | Colocacion de Roca en Uña |  | 27d | 2025-01-09 | 2025-02-08 | A1770 SS+7d, A1870 SS+1d | 177d | 0d | Oficial [210.57 h]; Peon [210.57 h]; Operador equipo Pesado [231.92 h]; Excavadora Cat 336 [210.57 h]; Tractor D6 [21.35 h]; Capataz [105.28 h]; Petroleo [1939.27 gln]; Roca [7362.44 m3]; Cost [216] | 1 | 31 | 1 | 280 | 7362.44 | m3 | 1 | 7362.44 | 26.2944285714286 | Roca |
| A1910 |  | Colocacion de Roca en Talud |  | 23d | 2025-02-10 | 2025-03-07 | A1900, A1870 SS | 177d | 0d | Oficial [178.73 h]; Peon [178.73 h]; Operador equipo Pesado [375.04 h]; Excavadora Cat 336 [357.04 h]; Tractor D6 [18 h]; Capataz [89.15 h]; Petroleo [3161.03 gln]; Roca [4286.14 m3]; Cost [184] | 1 | 29 | 1 | 192 | 4286.14 | m3 | 1 | 4286.14 | 22.3236458333333 | Roca |

| ID | WBS | Activity | Duration | Start | Finish | Predecessors | Total float | Free float | Resources | Cuadrilla | Metrado | Unidad | Turno | RCuad | DurCal | AGrupo | Duracion |
| --- | --- | --- | --- | --- | --- | --- | --- | --- | --- | --- | --- | --- | --- | --- | --- | --- | --- |
|  | 5 | **TRANSPORTES** |  | 2024-12-27 | 2025-03-11 |  |  |  |  |  |  |  |  |  |  |  |  |
| A1930 |  | Transporte de Material Organico (a DMO) D<=1km | 20d | 2024-12-27 | 2025-01-20 | A1730 SS | 220d | 0d | Peon - Vigia [21.61 h]; Operador equipo Liviano [107.29 h]; Volquete 15 m3 [107.29 h]; Petroleo [300.26 gln]; Cost [160] | 1 | 3859.34 | m3k | 1 | 1 | 3859.34 | Transportes | 25 |
| A1940 |  | Transporte de Material Organico (a DMO) D>1km | 20d | 2024-12-27 | 2025-01-20 | A1930 SS | 220d | 43d | Operador equipo Liviano [558.12 h]; Volquete 15 m3 [558.12 h]; Petroleo [1562.74 gln]; Cost [160] | 1 | 50738.23 | m3k | 1 | 1 | 50738.23 | Transportes | 25 |
| A1950 |  | Transporte de Material Excedente D<=1km | 20d | 2024-12-30 | 2025-01-22 | A1740 SS | 218d | 0d | Peon - Vigia [145.21 h]; Operador equipo Liviano [723.19 h]; Volquete 22 m3 [310.34 h]; Volquete 15 m3 [412.84 h]; Petroleo [2422.96 gln]; Cost [160] | 1 | 28471.9 | m3k | 1 | 1 | 28471.9 | Transportes | 24 |
| A1960 |  | Transporte de Material Excedente D>1km | 20d | 2024-12-30 | 2025-01-22 | A1950 SS | 218d | 41d | Operador equipo Liviano [3758.71 h]; Volquete 22 m3 [1600.24 h]; Volquete 15 m3 [2158.47 h]; Petroleo [12578.7 gln]; Cost [160] | 1 | 372149.85 | m3k | 1 | 1 | 372149.85 | Transportes | 24 |
| A1990 |  | Transporte de Roca D<=1km | 50d | 2025-01-09 | 2025-03-07 | A1890 SS | 180d | 0d | Peon [168.4 h]; Peon - Vigia [80.83 h]; Operador equipo Pesado [168.4 h]; Operador equipo Liviano [404.16 h]; Volquete 22 m3 [404.16 h]; Excavadora Cat 336 [168.4 h]; Petroleo [3033.89 gln]; Peaje local [612.98]; Cost [400] | 1 | 13472 | m3k | 1 | 1 | 13472 | Transportes | 62 |
| A2000 |  | Transporte de Roca D>1km | 50d | 2025-01-09 | 2025-03-07 | A1990 SS | 180d | 3d | Operador equipo Liviano [2617.16 h]; Volquete 22 m3 [2617.16 h]; Petroleo [10419.7 gln]; Cost [400] | 1 | 244594.44 | m3k | 1 | 1 | 244594.44 | Transportes | 62 |
| A2010 |  | Transporte de Material de Prestamo Cantera de Rio (Cuerpo de Terraplen) D<=1km | 30d | 2025-01-18 | 2025-02-21 | A1810 SS | 192d | 0d | Peon - Vigia [72.16 h]; Operador equipo Liviano [359.1 h]; Volquete 22 m3 [359.1 h]; Petroleo [1472.46 gln]; Cost [240] | 1 | 17181.62 | m3k | 1 | 1 | 17181.62 | Transportes | 36 |
| A2020 |  | Transporte de Material de Prestamo Cantera de Rio (Cuerpo de Terraplen) D>1km | 30d | 2025-01-18 | 2025-02-21 | A2010 SS | 192d | 15d | Operador equipo Liviano [21.1 h]; Volquete 22 m3 [21.1 h]; Petroleo [86.42 gln]; Cost [240] | 1 | 2541.86 | m3k | 1 | 1 | 2541.86 | Transportes | 36 |
| A2030 |  | Transporte de Material Seleccionado para Zanja D<=1km | 10d | 2025-02-12 | 2025-02-22 | A1880 SS | 191d | 0d | Peon - Vigia [0.69 h]; Operador equipo Liviano [3.44 h]; Volquete 15 m3 [3.44 h]; Petroleo [9.62 gln]; Cost [80] | 1 | 123.69 | m3k | 1 | 1 | 123.69 | Transportes | 12 |
| A2040 |  | Transporte de Material Seleccionado para Zanja D>1km | 10d | 2025-02-12 | 2025-02-22 | A2030 SS | 191d | 14d | Operador equipo Liviano [0.27 h]; Volquete 15 m3 [0.27 h]; Petroleo [0.75 gln]; Cost [80] | 1 | 24.5 | m3k | 1 | 1 | 24.5 | Transportes | 12 |
| A1970 |  | Transporte de Material de Prestamo (Afirmado) D<=1km | 3d | 2025-03-08 | 2025-03-11 | A1830 SS | 177d | 0d | Peon - Vigia [43.59 h]; Operador equipo Liviano [216.91 h]; Volquete 22 m3 [216.91 h]; Petroleo [889.45 gln]; Cost [24] | 1 | 10378.65 | m3k | 1 | 1 | 10378.65 | Transportes | 3 |
| A1980 |  | Transporte de Material de Prestamo (Afirmado) D>1km | 3d | 2025-03-08 | 2025-03-11 | A1970 SS | 177d | 0d | Operador equipo Liviano [1576.61 h]; Volquete 22 m3 [1576.61 h]; Petroleo [6458.41 gln]; Cost [24] | 1 | 189953.1 | m3k | 1 | 1 | 189953.1 | Transportes | 3 |
|  | 6 | **INTERFERENCIAS** |  | 2025-01-09 | 2025-02-12 |  |  |  |  |  |  |  |  |  |  |  |  |
| A4430 |  | Trazo y replanteo de interferencia | 30d | 2025-01-09 | 2025-02-12 | A1730 SS+10d | 197d | 0d | Peon [46.2 h]; Topografo [23.1 h]; GPS [23.1 h]; Capataz [2.31 h]; MADERA TORNILLO [23.1]; PINTURA ESMALTE [2.31]; Cost [240] |  | 1154.95 | m2 |  | 0 |  | Interferencias | 36 |
| A4440 |  | Desvío provisional con tubería | 30d | 2025-01-09 | 2025-02-12 | A4430 SS | 197d | 0d | Operario [12.31 h]; Oficial [12.31 h]; Peon [78.78 h]; Operador equipo Pesado [4.92 h]; Operador equipo Liviano [3.08 h]; Camion grua 20 ton [3.08 h]; Excavadora Cat 336 [4.92 h]; Capataz [7.14 h]; Petroleo [54.15 gln]; TUBERIA CORRUGADA HDPE D=630 mm [38.78]; Cost [240] |  | 36.93 | m |  | 0 |  | Interferencias | 36 |
| A4450 |  | Desvío provisional en tierras | 30d | 2025-01-09 | 2025-02-12 | A4440 SS | 197d | 0d | Peon [56.3 h]; Operador equipo Pesado [56.3 h]; Excavadora Cat 336 [56.3 h]; Capataz [11.28 h]; Petroleo [478.55 gln]; Cost [240] |  | 422.34 | m |  | 0 |  | Interferencias | 36 |
| A4460 |  | Limpieza de terreno manual | 30d | 2025-01-09 | 2025-02-12 | A4450 SS | 197d | 0d | Oficial [9.24 h]; Peon [18.48 h]; Operador equipo Pesado [3.46 h]; Excavadora Cat 336 [1.16 h]; Tractor D6 [2.31 h]; Capataz [0.46 h]; Petroleo [25.99 gln]; Cost [240] |  | 1154.95 | m2 |  | 0 |  | Interferencias | 36 |
| A4470 |  | Excavaciones no clasificada para estructuras | 30d | 2025-01-09 | 2025-02-12 | A4460 SS | 197d | 0d | Peon [1.68 h]; Operador equipo Pesado [1.68 h]; Excavadora Cat 336 [1.68 h]; Capataz [0.34 h]; Petroleo [14.29 gln]; Cost [240] |  | 52.52 | m3 |  | 0 |  | Interferencias | 36 |
| A4480 |  | Excavacion no clasificada de zanja | 30d | 2025-01-09 | 2025-02-12 | A4470 SS | 197d | 0d | Peon [22.67 h]; Operador equipo Pesado [22.67 h]; Excavadora Cat 336 [22.67 h]; Capataz [2.27 h]; Petroleo [192.72 gln]; Cost [240] |  | 453.45 | m3 |  | 0 |  | Interferencias | 36 |
| A4490 |  | Relleno estructural | 30d | 2025-01-09 | 2025-02-12 | A4480 SS | 197d | 0d | Operario [24.23 h]; Oficial [24.23 h]; Peon [58.13 h]; Peon - Vigia [0.7 h]; Operador equipo Pesado [25.78 h]; Operador equipo Liviano [30.1 h]; Cisterna 5000 gln [2.39 h]; Volquete 15 m3 [3.48 h]; Cargador Frontal 966 [3.26 h]; Excavadora Cat 336 [5.85 h]; Retroexcavadora sobre llantas 58 hp [12.11 h]; Rodillo liso vibratorio 0.80 - 1.10 ton [24.23 h]; Tractor D6 [1.31 h]; Zaranda Metso ST 4.8 168 HP [3.26 h]; Capataz [6.99 h]; Petroleo [180.6 gln]; Cost [240] |  | 169.58 | m3 |  | 0 |  | Interferencias | 36 |
| A4500 |  | Suministro de roca (Alcantarillas) | 30d | 2025-01-09 | 2025-02-12 | A4490 SS | 197d | 0d | Peon [0.28 h]; Peon - Vigia [0.02 h]; Operador equipo Pesado [0.28 h]; Operador equipo Liviano [0.45 h]; Volquete 22 m3 [0.45 h]; Excavadora Cat 336 [0.28 h]; Capataz [0.12 h]; Petroleo [4.16 gln]; Peaje local [0.17]; Cost [240] |  | 3.74 | m3 |  | 0 |  | Interferencias | 36 |
| A4510 |  | Colocación de roca en uña (Alcantarillas) | 30d | 2025-01-09 | 2025-02-12 | A4500 SS | 197d | 0d | Oficial [0.16 h]; Peon [0.16 h]; Operador equipo Pesado [0.19 h]; Excavadora Cat 336 [0.16 h]; Tractor D6 [0.03 h]; Capataz [0.08 h]; Petroleo [1.54 gln]; Cost [240] |  | 3.74 | m3 |  | 0 |  | Interferencias | 36 |
| A4520 |  | Concreto de Nivelacion (f'c=100 kg/cm2) | 30d | 2025-01-09 | 2025-02-12 | A4510 SS | 197d | 0d | Operario [0.15 h]; Oficial [0.96 h]; Peon [4.15 h]; Operador equipo Liviano [0.19 h]; Cisterna 5000 gln [0.04 h]; Carmix 4.0 m3 [0.15 h]; Capataz [0.32 h]; Petroleo [0.91 gln]; PIEDRA CHANCADA [0.98]; ARENA GRUESA [0.83]; CEMENTO PORTLAND TIPO I (42.5 kg) [9.07]; Cost [240] |  | 1.44 | m3 |  | 0 |  | Interferencias | 36 |
| A4530 |  | Concreto Clase F (f'c=140 kg/cm2) | 30d | 2025-01-09 | 2025-02-12 | A4520 SS | 197d | 0d | Operario [3.4 h]; Oficial [8.79 h]; Peon [35.16 h]; Operador equipo Liviano [3.4 h]; Carmix 4.0 m3 [3.4 h]; Capataz [2.2 h]; Petroleo [16.99 gln]; PIEDRA CHANCADA [5.52]; ARENA GRUESA [4.67]; CEMENTO PORTLAND TIPO I (42.5 kg) [59.46]; PLASTIMENT TM-40 - PLASTIFICANTE [18.26]; Cost [240] |  | 8.09 | m3 |  | 0 |  | Interferencias | 36 |
| A4540 |  | Concreto Clase C (f'c=280 kg/cm2) Premezclado - Cimientos reforzados | 30d | 2025-01-09 | 2025-02-12 | A4530 SS | 197d | 0d | Operario [4.28 h]; Oficial [5.94 h]; Peon [13.79 h]; Operador equipo Liviano [2.62 h]; Carmix 4.0 m3 [2.62 h]; Capataz [1.48 h]; Petroleo [13.91 gln]; PIEDRA CHANCADA [4.25]; ARENA GRUESA [3.6]; CEMENTO PORTLAND TIPO I (42.5 kg) [68.69]; PLASTIMENT TM-40 - PLASTIFICANTE [14.06]; ADITIVO CURADOR DE CONCRETO [0.93]; Cost [240] |  | 6.23 | m3 |  | 0 |  | Interferencias | 36 |
| A4550 |  | Concreto Clase C (f'c=280 kg/cm2) Premezclado - Muros de contencion | 30d | 2025-01-09 | 2025-02-12 | A4540 SS | 197d | 0d | Operario [11.05 h]; Oficial [15.34 h]; Peon [39.9 h]; Operador equipo Liviano [6.76 h]; Carmix 4.0 m3 [6.76 h]; Capataz [3.83 h]; Petroleo [35.93 gln]; PIEDRA CHANCADA [10.98]; ARENA GRUESA [9.29]; CEMENTO PORTLAND TIPO I (42.5 kg) [177.39]; PLASTIMENT TM-40 - PLASTIFICANTE [36.32]; ADITIVO CURADOR DE CONCRETO [2.41]; Cost [240] |  | 16.09 | m3 |  | 0 |  | Interferencias | 36 |
| A4560 |  | Encofrado y Desencofrado Caravista | 30d | 2025-01-09 | 2025-02-12 | A4550 SS | 197d | 0d | Operario [14.61 h]; Oficial [14.61 h]; Peon [29.22 h]; Capataz [2.92 h]; ALAMBRE NEGRO #8 [5.84]; CLAVOS PARA MADERA CON CABEZA DE 3" [5.84]; LACA DESMOLDEADORA [0.88]; MADERA TORNILLO INCLUYE CORTE PARA ENCOFRADO [87.66]; TRIPLAY DE 18 mm FENOLICO P/ENCOFRADO [2.54]; Cost [240] |  | 29.22 | m2 |  | 0 |  | Interferencias | 36 |
| A4570 |  | Encofrado y Desencofrado Cara Oculta | 30d | 2025-01-09 | 2025-02-12 | A4560 SS | 197d | 0d | Operario [39.01 h]; Oficial [39.01 h]; Capataz [3.9 h]; ALAMBRE NEGRO #8 [17.55]; CLAVOS PARA MADERA CON CABEZA DE 3" [12.29]; MADERA TORNILLO INCLUYE CORTE PARA ENCOFRADO [292.55]; Cost [240] |  | 58.51 | m2 |  | 0 |  | Interferencias | 36 |
| A4580 |  | Acero de refuerzo f'y=4200kg/cm2 | 30d | 2025-01-09 | 2025-02-12 | A4570 SS | 197d | 0d | Operario [29.19 h]; Oficial [29.19 h]; Peon [14.6 h]; Capataz [2.9 h]; ALAMBRE NEGRO #16 [60.31]; ACERO CORRUGADO fy = 4200 kg/cm2 GRADO 60 [1266.59]; Cost [240] |  | 1206.28 | kg |  | 0 |  | Interferencias | 36 |
| A4590 |  | Emboquillado de piedra e=0.20m | 30d | 2025-01-09 | 2025-02-12 | A4580 SS | 197d | 0d | Operario [1.48 h]; Oficial [2.95 h]; Peon [4.83 h]; Peon - Vigia [0 h]; Operador equipo Pesado [0.01 h]; Operador equipo Liviano [1.04 h]; Cisterna 5000 gln [0.01 h]; Volquete 15 m3 [0.05 h]; Excavadora Cat 336 [0.01 h]; Retroexcavadora sobre llantas 94 hp [0.98 h]; Zaranda estatica [0.1 h]; Capataz [0.51 h]; Petroleo [2.7 gln]; ARENA GRUESA [0.43]; CEMENTO PORTLAND TIPO I (42.5 kg) [4.16]; Cost [240] |  | 5.3 | m2 |  | 0 |  | Interferencias | 36 |
| A4600 |  | Emboquillado de piedra e=0.30m | 30d | 2025-01-09 | 2025-02-12 | A4590 SS | 197d | 0d | Operario [9.28 h]; Oficial [18.56 h]; Peon [30.34 h]; Peon - Vigia [0.03 h]; Operador equipo Pesado [0.04 h]; Operador equipo Liviano [6.54 h]; Cisterna 5000 gln [0.08 h]; Volquete 15 m3 [0.29 h]; Excavadora Cat 336 [0.04 h]; Retroexcavadora sobre llantas 94 hp [6.17 h]; Zaranda estatica [0.62 h]; Capataz [3.21 h]; Petroleo [16.94 gln]; ARENA GRUESA [2.68]; CEMENTO PORTLAND TIPO I (42.5 kg) [26.11]; Cost [240] |  | 22.2 | m2 |  | 0 |  | Interferencias | 36 |
| A4610 |  | Cama de arena e=0.20m | 30d | 2025-01-09 | 2025-02-12 | A4600 SS | 197d | 0d | Operario [0.92 h]; Oficial [1.85 h]; Peon [3.71 h]; Peon - Vigia [0.02 h]; Operador equipo Liviano [0.16 h]; Cisterna 5000 gln [0.06 h]; Volquete 22 m3 [0.1 h]; Capataz [0.18 h]; Petroleo [1.49 gln]; ARENA GRUESA [5.08]; Cost [240] |  | 23.08 | m2 |  | 0 |  | Interferencias | 36 |
| A4620 |  | Tubería HDPE Corrugada Ø=900mm (Suministro e instalación) | 30d | 2025-01-09 | 2025-02-12 | A4610 SS | 197d | 0d | Operario [4.31 h]; Oficial [8.62 h]; Peon [8.62 h]; Operador equipo Pesado [2.16 h]; Operador equipo Liviano [1.08 h]; Camion grua 20 ton [1.08 h]; Excavadora Cat 336 [2.16 h]; Capataz [4.31 h]; Petroleo [22.63 gln]; Tubería HDPE Corrugado de 900 mm [14.22]; Cost [240] |  | 12.93 | m |  | 0 |  | Interferencias | 36 |
| A4630 |  | Compuertas Charnela Ø900 (Suministro e instalacion) | 30d | 2025-01-09 | 2025-02-12 | A4620 SS | 197d | 0d | Operario [8 h]; Oficial [16 h]; Peon [32 h]; Operador equipo Liviano [6 h]; Camion grua 20 ton [6 h]; Capataz [4 h]; Petroleo [24 gln]; ANCLAJES [4]; Suministro de Compuerta tipo CHARNELA, D=900mm [1]; Cost [240] |  | 1 | und |  | 0 |  | Interferencias | 36 |
| A4640 |  | Sello en juntas | 30d | 2025-01-09 | 2025-02-12 | A4630 SS | 197d | 0d | Operario [3.35 h]; Peon [0.84 h]; Capataz [0.84 h]; TECNOPOR DE 1/2"X4X8' [0.57]; SELLADOR ELASTICO POLIURETANO SIKAFLEX 1A [2.87]; Cost [240] |  | 10.05 | m |  | 0 |  | Interferencias | 36 |
| A4650 |  | Waterstop (anillos de estanqueidad) | 30d | 2025-01-09 | 2025-02-12 | A4640 SS | 197d | 0d | Operario [2 h]; Peon [4 h]; Capataz [0.2 h]; WATER STOP (anillos de estanqueidad); DN=900mm [1.82]; WATER STOP (anillos de estanqueidad); DN=1200mm [0.18]; Cost [240] |  | 2 | und |  | 0 |  | Interferencias | 36 |
| A4660 |  | Pintura bituminosa | 30d | 2025-01-09 | 2025-02-12 | A4650 SS | 197d | 0d | Operario [12.78 h]; Peon [25.56 h]; Capataz [1.28 h]; PINTURA ASFALTICA [25.56]; IMPRIMANTE ASFALTICO [11.18]; Cost [240] |  | 63.9 | m2 |  | 0 |  | Interferencias | 36 |
| A4670 |  | Suministro e Instalación de geotextil | 30d | 2025-01-09 | 2025-02-12 | A4660 SS | 197d | 20d | Oficial [0.43 h]; Peon [0.64 h]; Operador equipo Liviano [0.05 h]; Camion grua 20 ton [0.05 h]; Capataz [0.04 h]; Petroleo [0.21 gln]; Geotextil no tejido 200gr/m2 [19.2]; Cost [240] |  | 16 | m2 |  | 0 |  | Interferencias | 36 |

| ID | WBS | Activity | Type | Duration | Start | Finish | Predecessors | Total float | Free float | Resources | RCuad | Duracion | Cuadrilla | Rendimiento | Metrado | Unidad | Turno | DurCal | Dur. Cal. | AGrupo |
| --- | --- | --- | --- | --- | --- | --- | --- | --- | --- | --- | --- | --- | --- | --- | --- | --- | --- | --- | --- | --- |
|  | 8 | **DE-PR-21--I** |  |  | 2024-12-05 | 2025-06-19 |  |  |  |  |  |  |  |  |  |  |  |  |  |  |
| A3030 |  | Inicio - DE-PR-21-I | milestone | 0d | 2024-12-05 | 2024-12-05 | A5650 SS, A2690 | 0d |  |  | 0 | 0 |  |  |  |  |  |  |  |  |
| A3040 |  | Fin - DE-PR-21-I | milestone | 0d | 2025-06-19 | 2025-06-19 | A2760 FF, A2770 FF, A2780 FF, A2800 FF, A2820 FF, A2840 FF, A2900 FF, A2920 FF, A2940 FF, A2960 FF, A2980 FF, A3000 FF, A3020 FF | 95d | 0d |  | 0 | 0 |  |  |  |  |  |  |  |  |
|  | 1 | **EXCAVACIONES** |  |  | 2024-12-05 | 2025-05-08 |  |  |  |  |  |  |  |  |  |  |  |  |  |  |
| A2710 |  | Desbroce |  | 60d | 2024-12-05 | 2025-02-15 | A3030 SS | 0d |  | Peon [72.6 h]; Operador equipo Pesado [54.45 h]; Excavadora Cat 336 [18.15 h]; Tractor D6 [36.3 h]; Capataz [0.36 h]; Petroleo [408.38 gln]; Cost [480] | 1 | 73 | 1 | 0.8 | 3.63 | ha | 1 | 3.63 | 4.5375 | Excavacion |
| A2770 |  | Conformacion de Material Excedente en DMO |  | 60d | 2024-12-05 | 2025-02-15 | A2710 SS | 197d | 102d | Peon [96.86 h]; Operador equipo Pesado [107.06 h]; Excavadora Cat 336 [10.2 h]; Tractor D6 [96.86 h]; Capataz [10.2 h]; Petroleo [764.7 gln]; Cost [480] | 1 | 73 | 1 | 1050 | 12745.06 | m3 | 1 | 12745.06 | 12.1381523809524 | Excavacion |
| A2730 |  | Excavacion de Cimentacion |  | 80d | 2024-12-07 | 2025-03-13 | A2710 SS+2d | 0d |  | Peon [1124.64 h]; Operador equipo Pesado [749.76 h]; Operador equipo Liviano [624.8 h]; Excavadora Cat 336 [499.84 h]; Retroexcavadora sobre llantas 94 hp [624.8 h]; Tractor D8 [249.92 h]; Capataz [112.46 h]; Petroleo [8172.36 gln]; Cost [640] | 0.5 | 97 | 0.5 | 880 | 62479.85 | m3 | 1 | 124959.7 | 141.999659090909 | Excavacion |
| A2750 |  | Excavacion de Uña |  | 80d | 2024-12-07 | 2025-03-13 | A2730 SS | 95d | 0d | Peon [271.97 h]; Operador equipo Pesado [271.97 h]; Excavadora Cat 336 [271.97 h]; Capataz [54.39 h]; Petroleo [3073.3 gln]; Cost [640] | 0.5 | 97 | 0.5 | 500 | 16998.35 | m3 | 1 | 33996.7 | 67.9934 | Excavacion |
| A2760 |  | Conformacion de Material Excedente en DME |  | 125d | 2024-12-07 | 2025-05-08 | A2730 SS | 130d | 35d | Peon [598.56 h]; Operador equipo Pesado [661.56 h]; Excavadora Cat 336 [63.01 h]; Tractor D6 [598.56 h]; Capataz [63.01 h]; Petroleo [4725.46 gln]; Cost [1000] | 1 | 153 | 1 | 1050 | 78757.68 | m3 | 1 | 78757.68 | 75.0073142857143 | Excavacion |
| A2780 |  | Excavacion Localizada - Sobreexcavacion |  | 80d | 2024-12-07 | 2025-03-13 | A2750 SS | 175d | 80d | Peon [89.44 h]; Operador equipo Pesado [89.44 h]; Excavadora Cat 336 [89.44 h]; Capataz [17.99 h]; Petroleo [760.34 gln]; Cost [640] | 0.5 | 97 | 0.5 | 240 | 2685.76 | m3 | 1 | 5371.52 | 22.3813333333333 | Excavacion |
| A2740 |  | Perfilado y Conformacion de Plataforma de Fundacion |  | 58d | 2025-01-27 | 2025-04-03 | A2730 SS+40d | 125d | 0d | Peon [153 h]; Operador equipo Pesado [272.93 h]; Operador equipo Liviano [57.89 h]; Cisterna 5000 gln [57.89 h]; Motoniveladora 140K [136.46 h]; Rodillo liso vibratorio 10 - 12 ton [136.46 h]; Capataz [12.41 h]; Petroleo [1174.41 gln]; Cost [464] | 0.3 | 67 | 0.3 | 2400 | 41352.31 | m2 | 1 | 137841.033333333 | 57.4337638888888 | Excavacion |
| A2720 |  | Remocion de Dique Existente |  | 65d | 2025-02-19 | 2025-05-08 | A2710 SS+2d, A2730 SS+60d | 105d | 0d | Peon [258.89 h]; Operador equipo Pesado [388.33 h]; Excavadora Cat 336 [258.89 h]; Tractor D8 [129.44 h]; Capataz [51.78 h]; Petroleo [3430.25 gln]; Cost [520] | 0.5 | 79 | 1 | 800 | 25888.7 | m3 | 1 | 51777.4 | 64.72175 | Excavacion |
|  | 2 | **RELLENOS** |  |  | 2025-02-04 | 2025-06-19 |  |  |  |  |  |  |  |  |  |  |  |  |  |  |
| A2790 |  | Relleno con Material Granular (incluye extraccion de material, zarandeo y combinado) |  | 61d | 2025-02-04 | 2025-04-15 | A2740 SS+7d | 125d | 0d | Operario [236.5 h]; Oficial [689.53 h]; Peon [2275.1 h]; Peon - Vigia [119.92 h]; Operador equipo Pesado [3217.79 h]; Operador equipo Liviano [1528.95 h]; Cisterna 5000 gln [689.53 h]; Volquete 15 m3 [596.26 h]; Cargador Frontal 966 [956.01 h]; Chancadora Primaria [449.69 h]; Excavadora Cat 336 [679.53 h]; Retroexcavadora sobre llantas 58 hp [119.92 h]; Rodillo liso vibratorio 10 - 12 ton [453.02 h]; Rodillo liso vibratorio 0.80 - 1.10 ton [236.5 h]; Tractor D6 [569.61 h]; Capataz [819.44 h]; Petroleo [25792.3 gln]; Cost [488] | 1 | 71 | 1 | 560 | 33310.42 | m3 | 1 | 33310.42 | 59.4828928571428 | Relleno |
| A2830 |  | Relleno con Material Seleccionado (incluye extraccion de material, zarandeo y combinado) |  | 61d | 2025-02-04 | 2025-04-15 | A2790 SS | 147d | 0d | Oficial [89.44 h]; Peon [183.71 h]; Operador equipo Pesado [268.31 h]; Operador equipo Liviano [18.8 h]; Cisterna 5000 gln [18.8 h]; Excavadora Cat 336 [178.87 h]; Rodillo liso vibratorio 10 - 12 ton [89.44 h]; Capataz [17.99 h]; Petroleo [2735.18 gln]; Cost [488] | 1 | 71 | 1 | 240 | 2685.76 | m3 | 1 | 2685.76 | 11.1906666666667 | Relleno |
| A2840 |  | Grava para Drenaje |  | 25d | 2025-02-12 | 2025-03-12 | A2830 SS+7d | 176d | 81d | Peon [254.06 h]; Peon - Vigia [7.97 h]; Operador equipo Pesado [104.19 h]; Operador equipo Liviano [234.24 h]; Volquete 15 m3 [39.85 h]; Cargador Frontal 966 [44.71 h]; Chancadora Primaria [29.74 h]; Excavadora Cat 336 [29.74 h]; Retroexcavadora sobre llantas 94 hp [194.39 h]; Tractor D6; Capataz [78.34 h]; Petroleo [1329.41 gln]; Cost [200] | 1 | 29 | 1 | 80 | 1943.86 | m3 | 1 | 1943.86 | 24.29825 | Relleno |
| A2820 |  | Perfilado de Talud Dique |  | 55d | 2025-02-28 | 2025-05-06 | A2790 SS+21d | 132d | 37d | Peon [221.08 h]; Operador equipo Pesado [65.94 h]; Excavadora Cat 336 [65.94 h]; Capataz [44.6 h]; Petroleo [560.45 gln]; Cost [440] | 1 | 68 | 1 | 700 | 19392.82 | m2 | 1 | 19392.82 | 27.7040285714286 | Relleno |
| A2800 |  | Relleno sin Compactar |  | 13d | 2025-05-29 | 2025-06-13 | A2890 FF | 100d | 5d | Oficial [98.62 h]; Peon [98.62 h]; Operador equipo Pesado [98.62 h]; Tractor D6 [98.62 h]; Capataz [19.95 h]; Petroleo [690.35 gln]; Cost [104] | 1 | 16 | 1 | 900 | 11081.06 | m3 | 1 | 11081.06 | 12.3122888888889 | Relleno |
| A2810 |  | Relleno Afirmado |  | 5d | 2025-06-14 | 2025-06-19 | A2890, A5330 | 95d | 0d | Oficial [42.51 h]; Peon [133.73 h]; Peon - Vigia [14.29 h]; Operador equipo Pesado [245.09 h]; Operador equipo Liviano [90.36 h]; Cisterna 5000 gln [19.45 h]; Volquete 15 m3 [70.91 h]; Cargador Frontal 966 [30.12 h]; Chancadora LT200 [30.12 h]; Excavadora Cat 336 [56.45 h]; Motoniveladora 140K [42.51 h]; Rodillo liso vibratorio 10 - 12 ton [42.51 h]; Tractor D6 [13.25 h]; Zaranda Metso ST 4.8 168 HP [30.12 h]; Capataz [51.81 h]; Petroleo [1726.33 gln]; CANON POR EXTRACCION CANTERA [1807.23]; Cost [40] | 1 | 6 | 1 | 324 | 1721.17 | m3 | 1 | 1721.17 | 5.31225308641975 | Relleno |
|  | 3 | **GEOTEXTIL** |  |  | 2025-01-15 | 2025-04-19 |  |  |  |  |  |  |  |  |  |  |  |  |  |  |
| A2850 |  | Instalacion de Geotextil 400gr/m2 |  | 80d | 2025-01-15 | 2025-04-19 | A2750 SS+30d | 95d | 0d | Oficial [1095.24 h]; Peon [1640.81 h]; Operador equipo Liviano [135.37 h]; Camion grua 20 ton [135.37 h]; Capataz [110.75 h]; Petroleo [541.47 gln]; Geotextil no tejido 200gr/m2 [47173.3]; Cost [640] | 1 | 95 | 1 | 600 | 41020.27 | m2 | 1 | 41020.27 | 68.3671166666667 | Geotextil |
| A2860 |  | Zanja de Anclaje |  | 10d | 2025-04-07 | 2025-04-19 | A2850 FF | 145d | 0d | Oficial [75 h]; Peon [225.54 h]; Operador equipo Pesado [75 h]; Operador equipo Liviano [2.1 h]; Cisterna 5000 gln [2.1 h]; Retroexcavadora sobre llantas 58 hp [75 h]; Capataz [15 h]; Petroleo [267.21 gln]; Cost [80] | 1 | 13 | 1 | 32 | 300 | m3 | 1 | 300 | 9.375 | Geotextil |
|  | 4 | **COLOCACION DE ROCA** |  |  | 2025-01-16 | 2025-06-13 |  |  |  |  |  |  |  |  |  |  |  |  |  |  |
| A2870 |  | Suministro de roca |  | 124d | 2025-01-16 | 2025-06-13 | A2880 SS | 100d | 0d | Cost [992] | 1 | 149 | 1 |  |  | ton | 1 | 0 |  | Roca |
| A2880 |  | Colocacion de Roca en Uña |  | 61d | 2025-01-16 | 2025-03-27 | A2750 SS+7d, A2850 SS+1d | 95d | 0d | Oficial [486.15 h]; Peon [486.15 h]; Operador equipo Pesado [535.45 h]; Excavadora Cat 336 [486.15 h]; Tractor D6 [49.3 h]; Capataz [243.08 h]; Petroleo [4477.37 gln]; Roca [16998.3 m3]; Cost [488] | 1 | 71 | 1 | 280 | 16998.35 | m3 | 1 | 16998.35 | 60.7083928571428 | Roca |
| A2900 |  | Extraccion de Rocas Reutilizables |  | 90d | 2025-02-19 | 2025-06-06 | A2720 SS | 105d | 10d | Peon [815.06 h]; Operador equipo Pesado [815.06 h]; Excavadora Cat 336 [815.06 h]; Capataz [407.89 h]; Petroleo [6928.39 gln]; Cost [720] | 1 | 108 | 1 | 144 | 7245 | m3 | 1 | 7245 | 50.3125 | Roca |
| A2890 |  | Colocacion de Roca en Talud |  | 63d | 2025-03-28 | 2025-06-13 | A2880 SS+15d, A2850 SS, A2790 SS+15d, A2880 | 95d | 0d | Oficial [501.47 h]; Peon [501.47 h]; Operador equipo Pesado [1052.25 h]; Excavadora Cat 336 [1001.75 h]; Tractor D6 [50.51 h]; Capataz [250.14 h]; Petroleo [8869 gln]; Roca [12025.8 m3]; Cost [504] | 1 | 78 | 1 | 192 | 12025.76 | m3 | 1 | 12025.76 | 62.6341666666667 | Roca |

| ID | WBS | Activity | Duration | Start | Finish | Predecessors | Total float | Free float | Resources | Cuadrilla | Metrado | Unidad | Turno | RCuad | DurCal | AGrupo | Duracion |
| --- | --- | --- | --- | --- | --- | --- | --- | --- | --- | --- | --- | --- | --- | --- | --- | --- | --- |
|  | 5 | **TRANSPORTES** |  | 2024-12-05 | 2025-06-19 |  |  |  |  |  |  |  |  |  |  |  |  |
| A2910 |  | Transporte de Material Organico (a DMO) D<=1km | 60d | 2024-12-05 | 2025-02-15 | A2710 SS | 197d | 0d | Peon - Vigia [71.37 h]; Operador equipo Liviano [354.31 h]; Volquete 15 m3 [354.31 h]; Petroleo [991.57 gln]; Cost [480] | 1 | 12745.06 | m3k | 1 | 1 | 12745.06 | Transportes | 73 |
| A2920 |  | Transporte de Material Organico (a DMO) D>1km | 60d | 2024-12-05 | 2025-02-15 | A2910 SS | 197d | 102d | Operador equipo Liviano [336.16 h]; Volquete 15 m3 [336.16 h]; Petroleo [941.26 gln]; Cost [480] | 1 | 30560.34 | m3k | 1 | 1 | 30560.34 | Transportes | 73 |
| A2930 |  | Transporte de Material Excedente D<=1km | 125d | 2024-12-07 | 2025-05-08 | A2730 SS | 130d | 0d | Peon - Vigia [401.66 h]; Operador equipo Liviano [2000.45 h]; Volquete 22 m3 [858.46 h]; Volquete 15 m3 [1141.99 h]; Petroleo [6702.28 gln]; Cost [1000] | 1 | 78757.68 | m3k | 1 | 1 | 78757.68 | Transportes | 153 |
| A2940 |  | Transporte de Material Excedente D>1km | 125d | 2024-12-07 | 2025-05-08 | A2930 SS | 130d | 35d | Operador equipo Liviano [1850.54 h]; Volquete 22 m3 [787.85 h]; Volquete 15 m3 [1062.68 h]; Petroleo [6192.88 gln]; Cost [1000] | 1 | 183221.43 | m3k | 1 | 1 | 183221.43 | Transportes | 153 |
| A2970 |  | Transporte de Roca D<=1km | 124d | 2025-01-16 | 2025-06-13 | A2870 SS | 100d | 0d | Peon [363.13 h]; Peon - Vigia [174.3 h]; Operador equipo Pesado [363.13 h]; Operador equipo Liviano [871.5 h]; Volquete 22 m3 [871.5 h]; Excavadora Cat 336 [363.13 h]; Petroleo [6542.09 gln]; Peaje local [1321.78]; Cost [992] | 1 | 29050.14 | m3k | 1 | 1 | 29050.14 | Transportes | 149 |
| A2980 |  | Transporte de Roca D>1km | 124d | 2025-01-16 | 2025-06-13 | A2970 SS | 100d | 5d | Operador equipo Liviano [1856.67 h]; Volquete 22 m3 [1856.67 h]; Petroleo [7391.98 gln]; Cost [992] | 1 | 173520.68 | m3k | 1 | 1 | 173520.68 | Transportes | 149 |
| A2990 |  | Transporte de Material de Prestamo Cantera de Rio (Cuerpo de Terraplen) D<=1km | 61d | 2025-02-04 | 2025-04-15 | A2790 SS | 147d | 0d | Peon - Vigia [221.66 h]; Operador equipo Liviano [1103.01 h]; Volquete 22 m3 [1103.01 h]; Petroleo [4522.86 gln]; Cost [488] | 1 | 52775.51 | m3k | 1 | 1 | 52775.51 | Transportes | 71 |
| A3000 |  | Transporte de Material de Prestamo Cantera de Rio (Cuerpo de Terraplen) D>1km | 61d | 2025-02-04 | 2025-04-15 | A2990 SS | 147d | 52d | Operador equipo Liviano [423.25 h]; Volquete 22 m3 [423.25 h]; Petroleo [1733.79 gln]; Cost [488] | 1 | 50993.83 | m3k | 1 | 1 | 50993.83 | Transportes | 71 |
| A3010 |  | Transporte de Material Seleccionado para Zanja D<=1km | 10d | 2025-04-07 | 2025-04-19 | A2860 SS | 145d | 0d | Peon - Vigia [1.68 h]; Operador equipo Liviano [8.34 h]; Volquete 15 m3 [8.34 h]; Petroleo [23.34 gln]; Cost [80] | 1 | 300 | m3k | 1 | 1 | 300 | Transportes | 13 |
| A3020 |  | Transporte de Material Seleccionado para Zanja D>1km | 10d | 2025-04-07 | 2025-04-19 | A3010 SS | 145d | 50d | Operador equipo Liviano [3.3 h]; Volquete 15 m3 [3.3 h]; Petroleo [9.24 gln]; Cost [80] | 1 | 300 | m3k | 1 | 1 | 300 | Transportes | 13 |
| A2950 |  | Transporte de Material de Prestamo (Afirmado) D<=1km | 5d | 2025-06-14 | 2025-06-19 | A2810 SS | 95d | 0d | Peon - Vigia [98.2 h]; Operador equipo Liviano [488.65 h]; Volquete 22 m3 [488.65 h]; Petroleo [2003.7 gln]; Cost [40] | 1 | 23380.41 | m3k | 1 | 1 | 23380.41 | Transportes | 6 |
| A2960 |  | Transporte de Material de Prestamo (Afirmado) D>1km | 5d | 2025-06-14 | 2025-06-19 | A2950 SS | 95d | 0d | Operador equipo Liviano [1770.15 h]; Volquete 22 m3 [1770.15 h]; Petroleo [7251.21 gln]; Cost [40] | 1 | 213270.85 | m3k | 1 | 1 | 213270.85 | Transportes | 6 |
|  | 6 | **INTERFERENCIAS** |  | 2025-03-14 | 2025-05-02 |  |  |  |  |  |  |  |  |  |  |  |  |
| A5020 |  | Trazo y replanteo de interferencia | 40d | 2025-03-14 | 2025-05-02 | A2730 | 105d | 0d | Peon [119.6 h]; Topografo [59.8 h]; GPS [59.8 h]; Capataz [5.98 h]; MADERA TORNILLO [59.8]; PINTURA ESMALTE [5.98]; Cost [320] |  | 2990.12 | m2 |  | 0 |  | Interferencias | 50 |
| A5030 |  | Desvío provisional con tubería | 40d | 2025-03-14 | 2025-05-02 | A5020 SS | 105d | 0d | Operario [15.16 h]; Oficial [15.16 h]; Peon [97 h]; Operador equipo Pesado [6.06 h]; Operador equipo Liviano [3.79 h]; Camion grua 20 ton [3.79 h]; Excavadora Cat 336 [6.06 h]; Capataz [8.79 h]; Petroleo [66.67 gln]; TUBERIA CORRUGADA HDPE D=630 mm [47.74]; Cost [320] |  | 45.47 | m |  | 0 |  | Interferencias | 50 |
| A5040 |  | Desvío provisional en tierras | 40d | 2025-03-14 | 2025-05-02 | A5030 SS | 105d | 0d | Peon [115.93 h]; Operador equipo Pesado [115.93 h]; Excavadora Cat 336 [115.93 h]; Capataz [23.22 h]; Petroleo [985.46 gln]; Cost [320] |  | 869.7 | m |  | 0 |  | Interferencias | 50 |
| A5050 |  | Limpieza de terreno manual | 40d | 2025-03-14 | 2025-05-02 | A5040 SS | 105d | 0d | Oficial [23.92 h]; Peon [47.84 h]; Operador equipo Pesado [8.97 h]; Excavadora Cat 336 [2.99 h]; Tractor D6 [5.98 h]; Capataz [1.2 h]; Petroleo [67.28 gln]; Cost [320] |  | 2990.12 | m2 |  | 0 |  | Interferencias | 50 |
| A5060 |  | Excavaciones no clasificada para estructuras | 40d | 2025-03-14 | 2025-05-02 | A5050 SS | 105d | 0d | Peon [0.27 h]; Operador equipo Pesado [0.27 h]; Excavadora Cat 336 [0.27 h]; Capataz [0.05 h]; Petroleo [2.27 gln]; Cost [320] |  | 8.36 | m3 |  | 0 |  | Interferencias | 50 |
| A5070 |  | Excavacion no clasificada de zanja | 40d | 2025-03-14 | 2025-05-02 | A5060 SS | 105d | 0d | Peon [32.73 h]; Operador equipo Pesado [32.73 h]; Excavadora Cat 336 [32.73 h]; Capataz [3.27 h]; Petroleo [278.24 gln]; Cost [320] |  | 654.69 | m3 |  | 0 |  | Interferencias | 50 |
| A5080 |  | Relleno estructural | 40d | 2025-03-14 | 2025-05-02 | A5070 SS | 105d | 0d | Operario [127.71 h]; Oficial [127.71 h]; Peon [306.35 h]; Peon - Vigia [3.66 h]; Operador equipo Pesado [135.84 h]; Operador equipo Liviano [158.63 h]; Cisterna 5000 gln [12.6 h]; Volquete 15 m3 [18.32 h]; Cargador Frontal 966 [17.16 h]; Excavadora Cat 336 [30.83 h]; Retroexcavadora sobre llantas 58 hp [63.81 h]; Rodillo liso vibratorio 0.80 - 1.10 ton [127.71 h]; Tractor D6 [6.88 h]; Zaranda Metso ST 4.8 168 HP [17.16 h]; Capataz [36.82 h]; Petroleo [951.76 gln]; Cost [320] |  | 893.67 | m3 |  | 0 |  | Interferencias | 50 |
| A5090 |  | Suministro de roca (Alcantarillas) | 40d | 2025-03-14 | 2025-05-02 | A5080 SS | 105d | 0d | Peon [1.95 h]; Peon - Vigia [0.16 h]; Operador equipo Pesado [1.95 h]; Operador equipo Liviano [3.11 h]; Volquete 22 m3 [3.11 h]; Excavadora Cat 336 [1.95 h]; Capataz [0.81 h]; Petroleo [28.97 gln]; Peaje local [1.18]; Cost [320] |  | 26.03 | m3 |  | 0 |  | Interferencias | 50 |
| A5100 |  | Colocación de roca en uña (Alcantarillas) | 40d | 2025-03-14 | 2025-05-02 | A5090 SS | 105d | 0d | Oficial [1.09 h]; Peon [1.09 h]; Operador equipo Pesado [1.3 h]; Excavadora Cat 336 [1.09 h]; Tractor D6 [0.22 h]; Capataz [0.54 h]; Petroleo [10.74 gln]; Cost [320] |  | 26.03 | m3 |  | 0 |  | Interferencias | 50 |
| A5110 |  | Concreto de Nivelacion (f'c=100 kg/cm2) | 40d | 2025-03-14 | 2025-05-02 | A5100 SS | 105d | 0d | Operario [0.73 h]; Oficial [4.63 h]; Peon [20.01 h]; Operador equipo Liviano [0.91 h]; Cisterna 5000 gln [0.19 h]; Carmix 4.0 m3 [0.73 h]; Capataz [1.52 h]; Petroleo [4.38 gln]; PIEDRA CHANCADA [4.74]; ARENA GRUESA [4.01]; CEMENTO PORTLAND TIPO I (42.5 kg) [43.72]; Cost [320] |  | 6.94 | m3 |  | 0 |  | Interferencias | 50 |
| A5120 |  | Concreto Clase F (f'c=140 kg/cm2) | 40d | 2025-03-14 | 2025-05-02 | A5110 SS | 105d | 0d | Operario [7.8 h]; Oficial [20.17 h]; Peon [80.67 h]; Operador equipo Liviano [7.8 h]; Carmix 4.0 m3 [7.8 h]; Capataz [5.04 h]; Petroleo [38.98 gln]; PIEDRA CHANCADA [12.67]; ARENA GRUESA [10.72]; CEMENTO PORTLAND TIPO I (42.5 kg) [136.42]; PLASTIMENT TM-40 - PLASTIFICANTE [41.9]; Cost [320] |  | 18.56 | m3 |  | 0 |  | Interferencias | 50 |
| A5130 |  | Concreto Clase C (f'c=280 kg/cm2) Premezclado - Cimientos reforzados | 40d | 2025-03-14 | 2025-05-02 | A5120 SS | 105d | 0d | Operario [8.75 h]; Oficial [12.14 h]; Peon [28.2 h]; Operador equipo Liviano [5.35 h]; Carmix 4.0 m3 [5.35 h]; Capataz [3.04 h]; Petroleo [28.45 gln]; PIEDRA CHANCADA [8.7]; ARENA GRUESA [7.36]; CEMENTO PORTLAND TIPO I (42.5 kg) [140.46]; PLASTIMENT TM-40 - PLASTIFICANTE [28.76]; ADITIVO CURADOR DE CONCRETO [1.91]; Cost [320] |  | 12.74 | m3 |  | 0 |  | Interferencias | 50 |
| A5140 |  | Concreto Clase C (f'c=280 kg/cm2) Premezclado - Muros de contencion | 40d | 2025-03-14 | 2025-05-02 | A5130 SS | 105d | 0d | Operario [16.5 h]; Oficial [22.91 h]; Peon [59.59 h]; Operador equipo Liviano [10.09 h]; Carmix 4.0 m3 [10.09 h]; Capataz [5.73 h]; Petroleo [53.67 gln]; PIEDRA CHANCADA [16.4]; ARENA GRUESA [13.88]; CEMENTO PORTLAND TIPO I (42.5 kg) [264.93]; PLASTIMENT TM-40 - PLASTIFICANTE [54.25]; ADITIVO CURADOR DE CONCRETO [3.6]; Cost [320] |  | 24.03 | m3 |  | 0 |  | Interferencias | 50 |
| A5150 |  | Encofrado y Desencofrado Caravista | 40d | 2025-03-14 | 2025-05-02 | A5140 SS | 105d | 0d | Operario [15.48 h]; Oficial [15.48 h]; Peon [30.97 h]; Capataz [3.1 h]; ALAMBRE NEGRO #8 [6.19]; CLAVOS PARA MADERA CON CABEZA DE 3" [6.19]; LACA DESMOLDEADORA [0.93]; MADERA TORNILLO INCLUYE CORTE PARA ENCOFRADO [92.91]; TRIPLAY DE 18 mm FENOLICO P/ENCOFRADO [2.69]; Cost [320] |  | 30.97 | m2 |  | 0 |  | Interferencias | 50 |
| A5160 |  | Encofrado y Desencofrado Cara Oculta | 40d | 2025-03-14 | 2025-05-02 | A5150 SS | 105d | 0d | Operario [46.44 h]; Oficial [46.44 h]; Capataz [4.65 h]; ALAMBRE NEGRO #8 [20.89]; CLAVOS PARA MADERA CON CABEZA DE 3" [14.63]; MADERA TORNILLO INCLUYE CORTE PARA ENCOFRADO [348.25]; Cost [320] |  | 69.65 | m2 |  | 0 |  | Interferencias | 50 |
| A5170 |  | Acero de refuerzo f'y=4200kg/cm2 | 40d | 2025-03-14 | 2025-05-02 | A5160 SS | 105d | 0d | Operario [44.05 h]; Oficial [44.05 h]; Peon [22.02 h]; Capataz [4.37 h]; ALAMBRE NEGRO #16 [91.01]; ACERO CORRUGADO fy = 4200 kg/cm2 GRADO 60 [1911.25]; Cost [320] |  | 1820.24 | kg |  | 0 |  | Interferencias | 50 |
| A5180 |  | Emboquillado de piedra e=0.20m | 40d | 2025-03-14 | 2025-05-02 | A5170 SS | 105d | 0d | Operario [155.36 h]; Oficial [310.67 h]; Peon [508.01 h]; Peon - Vigia [0.5 h]; Operador equipo Pesado [0.72 h]; Operador equipo Liviano [109.6 h]; Cisterna 5000 gln [1.39 h]; Volquete 15 m3 [4.85 h]; Excavadora Cat 336 [0.72 h]; Retroexcavadora sobre llantas 94 hp [103.35 h]; Zaranda estatica [10.42 h]; Capataz [53.79 h]; Petroleo [283.58 gln]; ARENA GRUESA [44.88]; CEMENTO PORTLAND TIPO I (42.5 kg) [437.05]; Cost [320] |  | 557.46 | m2 |  | 0 |  | Interferencias | 50 |
| A5190 |  | Emboquillado de piedra e=0.30m | 40d | 2025-03-14 | 2025-05-02 | A5180 SS | 105d | 0d | Operario [27.09 h]; Oficial [54.17 h]; Peon [88.57 h]; Peon - Vigia [0.08 h]; Operador equipo Pesado [0.13 h]; Operador equipo Liviano [19.1 h]; Cisterna 5000 gln [0.24 h]; Volquete 15 m3 [0.84 h]; Excavadora Cat 336 [0.13 h]; Retroexcavadora sobre llantas 94 hp [18.01 h]; Zaranda estatica [1.81 h]; Capataz [9.38 h]; Petroleo [49.44 gln]; ARENA GRUESA [7.82]; CEMENTO PORTLAND TIPO I (42.5 kg) [76.2]; Cost [320] |  | 64.8 | m2 |  | 0 |  | Interferencias | 50 |
| A5200 |  | Emboquillado de piedra e=0.50m | 40d | 2025-03-14 | 2025-05-02 | A5190 SS | 105d | 0d | Operario [14.72 h]; Oficial [29.44 h]; Peon [46.6 h]; Peon - Vigia [0.05 h]; Operador equipo Pesado [0.08 h]; Operador equipo Liviano [9.72 h]; Cisterna 5000 gln [0.15 h]; Volquete 15 m3 [0.52 h]; Excavadora Cat 336 [0.08 h]; Retroexcavadora sobre llantas 94 hp [9.05 h]; Capataz [4.79 h]; Petroleo [25.34 gln]; ARENA GRUESA [4.83]; CEMENTO PORTLAND TIPO I (42.5 kg) [47.04]; Cost [320] |  | 24 | m2 |  | 0 |  | Interferencias | 50 |
| A5210 |  | Cama de arena e=0.20m | 40d | 2025-03-14 | 2025-05-02 | A5200 SS | 105d | 0d | Operario [1.09 h]; Oficial [2.17 h]; Peon [4.36 h]; Peon - Vigia [0.02 h]; Operador equipo Liviano [0.19 h]; Cisterna 5000 gln [0.08 h]; Volquete 22 m3 [0.11 h]; Capataz [0.22 h]; Petroleo [1.75 gln]; ARENA GRUESA [5.97]; Cost [320] |  | 27.13 | m2 |  | 0 |  | Interferencias | 50 |
| A5220 |  | Tubería HDPE Corrugada Ø=1200mm (Suministro e instalación) | 40d | 2025-03-14 | 2025-05-02 | A5210 SS | 105d | 0d | Operario [5.16 h]; Oficial [10.31 h]; Peon [10.31 h]; Operador equipo Pesado [2.58 h]; Operador equipo Liviano [1.29 h]; Camion grua 20 ton [1.29 h]; Excavadora Cat 336 [2.58 h]; Capataz [5.16 h]; Petroleo [27.07 gln]; TUBERIA CORRUGADA HDPE D=1200 mm [17.02]; Cost [320] |  | 15.47 | m |  | 0 |  | Interferencias | 50 |
| A5230 |  | Compuertas Charnela Ø1200 (Suministro e instalacion) | 40d | 2025-03-14 | 2025-05-02 | A5220 SS | 105d | 0d | Operario [8 h]; Oficial [16 h]; Peon [32 h]; Operador equipo Liviano [6 h]; Camion grua 20 ton [6 h]; Capataz [4 h]; Petroleo [24 gln]; ANCLAJES [4]; Suministro de Compuerta tipo CHARNELA, D=1200mm [1]; Cost [320] |  | 1 | und |  | 0 |  | Interferencias | 50 |
| A5240 |  | Sello en juntas | 40d | 2025-03-14 | 2025-05-02 | A5230 SS | 105d | 0d | Operario [73.01 h]; Peon [18.25 h]; Capataz [18.25 h]; TECNOPOR DE 1/2"X4X8' [12.49]; SELLADOR ELASTICO POLIURETANO SIKAFLEX 1A [62.65]; Cost [320] |  | 219.05 | m |  | 0 |  | Interferencias | 50 |
| A5250 |  | Waterstop (anillos de estanqueidad) | 40d | 2025-03-14 | 2025-05-02 | A5240 SS | 105d | 0d | Operario [2 h]; Peon [4 h]; Capataz [0.2 h]; WATER STOP (anillos de estanqueidad); DN=900mm [1.82]; WATER STOP (anillos de estanqueidad); DN=1200mm [0.18]; Cost [320] |  | 2 | und |  | 0 |  | Interferencias | 50 |
| A5260 |  | Pintura bituminosa | 40d | 2025-03-14 | 2025-05-02 | A5250 SS | 105d | 0d | Operario [13.93 h]; Peon [27.86 h]; Capataz [1.39 h]; PINTURA ASFALTICA [27.86]; IMPRIMANTE ASFALTICO [12.19]; Cost [320] |  | 69.65 | m2 |  | 0 |  | Interferencias | 50 |
| A5270 |  | Relleno con material granular (incluye extracción de material, zarandeo y combinación de material) | 40d | 2025-03-14 | 2025-05-02 | A5260 SS | 105d | 0d | Peon [20.29 h]; Peon - Vigia [0.62 h]; Operador equipo Pesado [15.66 h]; Operador equipo Liviano [12.79 h]; Cisterna 5000 gln [2.13 h]; Volquete 15 m3 [3.1 h]; Cargador Frontal 966 [3.48 h]; Chancadora Primaria [2.31 h]; Excavadora Cat 336 [9.87 h]; Rodillo liso vibratorio 0.80 - 1.10 ton [7.56 h]; Tractor D6; Capataz [3.82 h]; Petroleo [145.93 gln]; Cost [320] |  | 151.18 | m3 |  | 0 |  | Interferencias | 50 |
| A5280 |  | Suministro e Instalación de geotextil | 40d | 2025-03-14 | 2025-05-02 | A5270 SS | 105d | 0d | Oficial [0.53 h]; Peon [0.8 h]; Operador equipo Liviano [0.07 h]; Camion grua 20 ton [0.07 h]; Capataz [0.05 h]; Petroleo [0.26 gln]; Geotextil no tejido 200gr/m2 [24]; Cost [320] |  | 20 | m2 |  | 0 |  | Interferencias | 50 |
| A5290 |  | Juntas de dilatacion | 40d | 2025-03-14 | 2025-05-02 | A5280 SS | 105d | 0d | Operario [1.67 h]; Peon [1.67 h]; Capataz [0.42 h]; MATERIAL DE RESPALDO 1/2" PARA JUNTAS 10 mm [5]; TECNOPOR DE 1/2"X4X8' [0.28]; SELLADOR ELASTICO POLIURETANO SIKAFLEX 1A [1.43]; Cost [320] |  | 5 | m |  | 0 |  | Interferencias | 50 |

| ID | WBS | Activity | Duration | Start | Finish | Predecessors | Total float | Free float | Resources | Metrado | Unidad | RCuad | AGrupo | Duracion |
| --- | --- | --- | --- | --- | --- | --- | --- | --- | --- | --- | --- | --- | --- | --- |
|  | 7 | **ACCESOS** |  | 2025-05-03 | 2025-05-31 |  |  |  |  |  |  |  |  |  |
| A5300 |  | Concreto clase C (f'c=280 kg/cm2) en losa | 25d | 2025-05-03 | 2025-05-31 | A5290 | 105d | 0d | Operario [48.58 h]; Oficial [72.27 h]; Peon [194.31 h]; Operador equipo Liviano [24.88 h]; Carmix 4.0 m3 [24.88 h]; Capataz [18.07 h]; Petroleo [136.25 gln]; PIEDRA CHANCADA [40.43]; ARENA GRUESA [34.21]; CEMENTO PORTLAND TIPO I (42.5 kg) [653.12]; PLASTIMENT TM-40 - PLASTIFICANTE [133.73]; ADITIVO CURADOR DE CONCRETO [8.89]; Cost [200] | 59.24 | m3 | 0 | Accesos | 29 |
| A5310 |  | Encofrado y desencofrado pavimento rígido e=0.15m | 25d | 2025-05-03 | 2025-05-31 | A5300 SS | 105d | 0d | Operario [18.8 h]; Oficial [18.8 h]; Peon [37.6 h]; Capataz [18.8 h]; ALAMBRE NEGRO #8 [9.4]; CLAVOS PARA MADERA CON CABEZA [18.8]; DESMOLDANTE PARA MADERA [1.5]; MADERA TORNILLO INCLUYE CORTE PARA ENCOFRADO [94]; TRIPLAY DE 19 mm PARA ENCOFRADO [4.7]; Cost [200] | 188 | m | 0 | Accesos | 29 |
| A5320 |  | Junta en Pavimentos con Pasadores | 25d | 2025-05-03 | 2025-05-31 | A5310 SS | 105d | 0d | Operario [19.92 h]; Oficial [9.12 h]; Peon [30.72 h]; Capataz [3.97 h]; DOWELL LISO Ø 3/4", L=500, c/0.50m [334.53]; MATERIAL DE RESPALDO 1" PARA JUNTAS 20 mm [113.4]; SELLO ELASTOMETRICO A BASE DE SILICONA [5.18]; Cost [200] | 108 | m | 0 | Accesos | 29 |
| A5330 |  | Concreto Ciclopeo f'c=210 kg/cm2 + 30% PM | 25d | 2025-05-03 | 2025-05-31 | A5320 SS | 105d | 10d | Operario [2.7 h]; Oficial [3.2 h]; Peon [17.32 h]; Peon - Vigia [0 h]; Operador equipo Pesado [0 h]; Operador equipo Liviano [1.23 h]; Volquete 15 m3 [0.01 h]; Carmix 4.0 m3 [1.2 h]; Excavadora Cat 336 [0 h]; Retroexcavadora sobre llantas 94 hp [0.02 h]; Zaranda estatica [0.02 h]; Capataz [1.55 h]; Petroleo [6.1 gln]; PIEDRA CHANCADA [1.95]; ARENA GRUESA [1.65]; CEMENTO PORTLAND TIPO I (42.5 kg) [27]; PLASTIMENT TM-40 - PLASTIFICANTE [6.45]; Cost [200] | 4 | m3 | 0 | Accesos | 29 |
|  | 7 | **MEDIO AMBIENTE** |  | 2024-10-23 | 2024-12-21 |  |  |  |  |  |  |  |  |  |
| A5600 |  | Camarones | 50d | 2024-10-23 | 2024-12-21 | A5610 SS, A2680 SS | 242d |  | Cost [400] |  |  | 0 |  | 60 |
